# 匈塞铁路诺苏段总体施工组织进度计划/ Hungarian-Serbian railway Novi Sad-Subotica section overall construction organization progress plan/ План напретка опште организације извођења радова на секцији Нови Сад-Суботица мађарско-српске пруге

Schedule from MS Project, 2022-07-01 to 2025-12-31, status date 2007-09-03.

## Calendars

- 标准: Mon-Sat 08:00-12:00, 13:00-17:00; Sun off. Exceptions (off unless hours are given): 2022-11-11 (2022年老兵节), 2022-12-01 to 2023-01-31 (2023年冬休), 2023-02-15 to 2023-02-16 (2023年国庆节), 2023-04-14 to 2023-04-17 (2023年复活节), 2023-05-01 to 2023-05-02 (2023年劳动节), 2023-11-11 (2023年老兵节), 2023-12-01 to 2024-01-31 (2024年冬休), 2024-02-15 to 2024-02-16 (2024年国庆节), 2024-05-01 to 2024-05-02 (2024年劳动节), 2024-05-03 to 2024-05-06 (2024年复活节), 2024-11-11 (2024年老兵节), 2024-12-01 to 2025-01-31 (2025年冬休), 2025-02-15 to 2025-02-16 (2025年国庆节), 2025-04-18 to 2025-04-21 (2025年复活节), 2025-05-01 to 2025-05-02 (2025年劳动节), 2025-11-11 (2025年老兵节).
- 非冬季施工: Mon-Sat 08:00-12:00, 13:00-17:00; Sun off. Exceptions (off unless hours are given): 2022-11-11 (2022年老兵节), 2023-02-15 to 2023-02-16 (2023年国庆节), 2023-04-14 to 2023-04-17 (2023年复活节), 2023-05-01 to 2023-05-02 (2023年劳动节), 2023-11-11 (2023年老兵节), 2024-02-15 to 2024-02-16 (2024年国庆节), 2024-05-01 to 2024-05-02 (2024年劳动节), 2024-05-03 to 2024-05-06 (2024年复活节), 2024-11-11 (2024年老兵节), 2025-02-15 to 2025-02-16 (2025年国庆节), 2025-04-18 to 2025-04-21 (2025年复活节), 2025-05-01 to 2025-05-02 (2025年劳动节), 2025-11-11 (2025年老兵节).

## Schedule

| ID | WBS | Task | Type | Duration | Start | Finish | Predecessors | Total slack | Free slack | Constraint |
| --- | --- | --- | --- | --- | --- | --- | --- | --- | --- | --- |
| 1 | 1 | 下达开工令/ Issuing of order for starting of construction / Издавање налога за почетак радова | milestone | 0d | 2022-07-01 | 2022-07-01 |  | 0d |  | start no earlier than 2022-07-01 |
| 2 | 2 | **施工准备Construction preparationConstruction preparation / Припрема за изградњу** |  | 757d | 2022-07-01 | 2025-06-30 |  | 61d |  |  |
| 3 | 2.1 | **施工营地建设/ Building of construction camp / Изградња кампа за извођење радова** |  | 308d | 2022-07-01 | 2023-09-04 |  | 336d |  |  |
| 4 | 2.1.1 | **NS-1标施工营地建设/ Building of construction camp for NS-1 bid section / Изградња кампа за извођење радова за деоницу NS-1** |  | 26d | 2022-07-01 | 2022-07-30 |  | 888d |  |  |
| 5 | 2.1.1.1 | 项目营地（已完成）/ Project camp (already completed) / Камп пројекта (већ завршен) | milestone | 0d | 2022-07-01 | 2022-07-01 | 1 | 888d | 0d |  |
| 6 | 2.1.1.2 | 一分部营地/ Camp of subsection I / Камп сектора I | milestone | 0d | 2022-07-01 | 2022-07-01 | 5 | 914d |  |  |
| 7 | 2.1.1.3 | 二分部营地/ Camp of subsection II / Камп сектора II | milestone | 0d | 2022-07-01 | 2022-07-01 | 5 | 914d |  |  |
| 8 | 2.1.1.4 | 三分部营地/ Camp of subsection III / Камп сектора III |  | 26d | 2022-07-01 | 2022-07-30 | 5 | 888d |  |  |
| 9 | 2.1.2 | **NS-2标施工营地建设/ Building of construction camp for NS-2 bid section / Изградња кампа за извођење радова за деоницу NS-2** |  | 132d | 2022-07-01 | 2023-02-02 |  | 336d |  |  |
| 10 | 2.1.2.1 | 项目营地（已完成）/ Project camp (already completed) / Камп пројекта (већ завршен) | milestone | 0d | 2022-07-01 | 2022-07-01 | 1 | 914d |  |  |
| 11 | 2.1.2.2 | 巴奇卡托波拉分部营地/Bachka Toppola Division Camp |  | 61d | 2022-07-01 | 2022-09-09 | 1 | 853d |  |  |
| 12 | 2.1.2.3 | 预制梁场（合作）/Prefab Beam Yard (Cooperative) |  | 132d | 2022-07-01 | 2023-02-02 | 1 | 336d | 0d |  |
| 13 | 2.1.3 | **NS-3标施工营地建设/ Building of construction camp for NS-3 bid section / Изградња кампа за извођење радова за деоницу NS-3** |  | 308d | 2022-07-01 | 2023-09-04 |  | 606d |  |  |
| 14 | 2.1.3.1 | 项目营地（已完成）/ Project camp (already completed) / Камп пројекта (већ завршен) | milestone | 0d | 2022-07-01 | 2022-07-01 | 1 | 914d |  |  |
| 15 | 2.1.3.2 | 斯帕诺维彻沃分部营地/Spanovichever branch camp | milestone | 0d | 2022-07-01 | 2022-07-01 | 1 | 914d |  |  |
| 16 | 2.1.3.3 | 苏博蒂察分部营地 |  | 30d | 2023-08-01 | 2023-09-04 |  | 606d |  | start no earlier than 2023-08-01 |
| 17 | 2.1.4 | **NS-4标施工营地建设/ Building of construction camp for NS-4 bid section / Изградња кампа за извођење радова за деоницу NS-4** |  | 308d | 2022-07-01 | 2023-09-04 |  | 606d |  |  |
| 18 | 2.1.4.1 | 项目营地（已完成）/ Project camp (already completed) / Камп пројекта (већ завршен) | milestone | 0d | 2022-07-01 | 2022-07-01 | 1 | 914d |  |  |
| 19 | 2.1.4.2 | 一分部营地/ Camp of subsection I / Камп сектора I |  | 30d | 2023-04-01 | 2023-05-11 |  | 705d |  | start no earlier than 2023-04-01 |
| 20 | 2.1.4.3 | 二分部营地/ Camp of subsection I / Камп сектора I |  | 30d | 2023-08-01 | 2023-09-04 |  | 606d |  | start no earlier than 2023-08-01 |
| 21 | 2.2 | **存料场建设/ Building of storage yard / Изградња депоније за складиштење** |  | 95d | 2022-07-25 | 2022-11-12 |  | 157d |  |  |
| 22 | 2.2.1 | K79+500小型存砟场/ Small scale ballast storage yard at K79+500 / Мала депонија за туцаник на K79+500 |  | 30d | 2022-08-06 | 2022-09-09 | 1SS+31d | 853d |  |  |
| 23 | 2.2.2 | K80+300大型存砟场/ Large scale ballast storage yard at K80+300 / Велика депонија за туцаник на K80+300 |  | 33d | 2022-07-25 | 2022-08-31 | 1SS+20d | 157d | 0d |  |
| 24 | 2.2.3 | K102+200大型存砟场/ Large scale ballast storage yard at K102+200 / Велика депонија за туцаник на K102+200 |  | 31d | 2022-09-01 | 2022-10-06 | 23 | 799d | 0d |  |
| 25 | 2.2.4 | K128+000小型存砟场/ Small scale ballast storage yard at K128+000 / Мала депонија за туцаник на K128+000 |  | 31d | 2022-10-07 | 2022-11-12 | 24 | 799d |  |  |
| 26 | 2.2.5 | K155+000大型存砟场/ Large scale ballast storage yard at K155+000 / Велика депонија за туцаник на K155+000 |  | 36d | 2022-08-01 | 2022-09-10 | 1SS+26d | 827d | 0d |  |
| 27 | 2.2.6 | K166+500小型存砟场/ Small scale ballast storage yard at K166+500 / Мала депонија за туцаник на K155+500 |  | 25d | 2022-09-12 | 2022-10-10 | 26 | 827d |  |  |

| ID | WBS | Task | Duration | Start | Finish | Predecessors | Total slack | Free slack |
| --- | --- | --- | --- | --- | --- | --- | --- | --- |
| 28 | 2.3 | **铺轨基地建设/ Building of track-laying base / Изградња базе за извођење радова на горњем строју** | 130d | 2022-07-01 | 2022-12-30 |  | 31d |  |
| 29 | 2.3.1 | 萨耶罗沃铺轨基地（K80+300）/ Track-laying base in Sajlovo（K80+300）/ База за извођење радова на горњем строју у Сајлову（K80+300） | 182ed | 2022-07-01 | 2022-12-30 | 1SS | 213d | 94.12d |
| 30 | 2.3.2 | 那维切沃铺轨基地（K164+800）/ Track-laying base in Naumovićevo (K164+800) / База за извођење радова на горњем строју у Наумовићевом（K166+500） | 151ed | 2022-08-01 | 2022-12-30 | 1SS+27d | 118.88d | 0d |
| 31 | 2.4 | **主要施工设备进场组织/ Organization of arrival of main construction equipment to site / Организација доласка главне грађевинске опреме на градилиште** | 113d | 2022-08-01 | 2023-02-10 |  | 239d |  |
| 32 | 2.4.1 | **铺轨基地设备/ Equipment for track-laying base / Опрема за базу за радове на горњем строју** | 103d | 2022-08-01 | 2022-12-31 |  | 238d |  |
| 33 | 2.4.1.1 | 基地群吊、移动龙门吊调遣（包括海运、清关等）/ Base ground hang, mobile gantry crane assigning (including sea transportation, customs clearance etc.) / Отпремање базних конзолних кранова, портални кранови (укључујући транспорт воденим путем, пролазак кроз царину, итд.) | 92ed | 2022-08-01 | 2022-11-01 | 29SS, 30SS | 1047d | 0d |
| 34 | 2.4.1.2 | 安装调试/ Installation and commissioning / Постављање и проба | 60ed | 2022-11-01 | 2022-12-31 | 33 | 1047d | 0d |
| 35 | 2.4.2 | **轨道施工专用设备/ Equipment used specially for track works / Опрема која се користи посебно за радове на горњем строју** | 113d | 2022-08-01 | 2023-02-10 |  | 273d |  |
| 36 | 2.4.2.1 | 第一批:机车、老K车、平板车、大机养设备等设备调遣（包括海运、清关等）/ First batch: Assigning of equipment such as locomotive, ballast wagon, flat wagon, machine for track regulation, etc. (including sea transport, customs clearance etc.) / Прва тура: Отпремање опреме попут локомотиве, х | 56d | 2022-08-01 | 2022-10-04 | 1SS+26d | 305d | 48d |
| 37 | 2.4.2.2 | 第二批：铺轨机组、机车、老K车、平板车等设备调遣（包括海运、清关等）/ Second batch: Assigning of equipment such as track laying set, locomotive, ballast wagon, flat wagon, etc. (including sea transport, customs clearance etc.) / Друга тура: Отпремање опреме попут опреме за полагање колос | 91ed | 2022-08-01 | 2022-10-31 | 1SS+27d | 1177.88d | 150d |
| 38 | 2.4.2.3 | 第三批：机车、老K车、平板车、大机养设备及焊轨等设备调遣（包括海运、清关等）/ Third batch: Assigning of equipment such as locomotive, ballast wagon, flat wagon, machine for track regulation and track welding etc. (including sea transport, customs clearance etc.) / Трећа тура: Отпремање опрем | 92ed | 2022-10-10 | 2023-01-10 | 37SS+60d | 1177.88d | 0d |
| 39 | 2.4.2.4 | 安装调试/ Installation and commissioning / Постављање и проба | 31ed | 2023-01-10 | 2023-02-10 | 38, 36, 37 | 1177.88d | 927d |
| 40 | 2.5 | **主要材料及设备组织进场/ Organization of arrival to site of main material and equipment / Организација доласка на градилиште главног материјала и орпеме** | 757d | 2022-07-01 | 2025-06-30 |  | 157d |  |
| 41 | 2.5.1 | **诺维萨德枢纽相关工程/ Novi Sad terminal related projects / Припадајући пројекти железничког чвора Нови Сад** | 130d | 2022-07-01 | 2022-12-30 |  | 759d |  |
| 42 | 2.5.1.1 | 道砟/ Ballast / Туцаник | 182ed | 2022-07-01 | 2022-12-30 | 1SS | 3292.12d | 453d |
| 43 | 2.5.1.2 | 轨枕（含扣件）/ Sleeper (including fastenings)/ Праг (укључујући причврсни прибор) | 120ed | 2022-09-01 | 2022-12-30 | 1SS+62ed | 3292.12d | 267d |
| 44 | 2.5.1.3 | 钢轨/ Rails /Шине | 90ed | 2022-10-01 | 2022-12-30 | 1SS+92ed | 3292.12d | 177d |
| 45 | 2.5.1.4 | 道岔/ Turnout / Скретница | 120ed | 2022-09-01 | 2022-12-30 | 1SS+62ed | 3292.12d | 267d |
| 46 | 2.5.2 | **正线、站线工程/ Main track, station track projects / Пројекти главног колосека, станичних колосека** | 704d | 2022-09-01 | 2025-06-30 |  | 109d |  |
| 47 | 2.5.2.1 | 道砟/ Ballast / Туцаник | 704d | 2022-09-01 | 2025-06-30 | 23 | 157d |  |
| 48 | 2.5.2.2 | 轨枕（含扣件）/ Sleeper (including fastenings)/ Праг (укључујући причврсни прибор) | 700ed | 2023-01-31 | 2024-12-31 | 34FS+31ed | 1095d | 957d |
| 49 | 2.5.2.3 | 钢轨/ Rails /Шине | 715ed | 2023-02-01 | 2025-01-16 | 34FS+32ed | 1047d | 954d |
| 50 | 2.5.2.4 | 道岔/ Turnout / Скретница | 715ed | 2023-02-01 | 2025-01-16 | 29SS+184ed, 30SS+184ed | 118.88d |  |
| 51 | 2.5.3 | **苏博蒂察编组站及支线相关工程/ Subotica marshalling station and branch line related project / Припадајући пројекат ранжирне станице Суботица и одвојне пруге Суботица** | 420d | 2022-11-07 | 2024-07-30 |  | 384d |  |
| 52 | 2.5.3.1 | 道砟/ Ballast / Туцаник | 300d | 2022-11-07 | 2024-03-06 | 1FS+110d | 504d |  |
| 53 | 2.5.3.2 | 轨枕（含扣件）/ Sleeper (including fastenings)/ Праг (укључујући причврсни прибор) | 400d | 2023-02-01 | 2024-07-30 | 1FS+130d | 384d |  |
| 54 | 2.5.3.3 | 钢轨/ Rails /Шине | 400d | 2023-02-01 | 2024-07-30 | 1FS+130d | 384d |  |
| 55 | 2.5.3.4 | 道岔/ Turnout / Скретница | 400d | 2023-02-01 | 2024-07-30 | 1FS+130d | 384d |  |

| ID | WBS | Task | Type | Duration | Start | Finish | Predecessors | Total slack | Free slack | Constraint |
| --- | --- | --- | --- | --- | --- | --- | --- | --- | --- | --- |
| 56 | 3 | **施工总工期(不含前段准备期)/ Total construction period (not including the previous preparation period) / Укупан рок трајања радова (не укључујући претходни припремни период)** |  | 810d? | 2022-07-01 | 2025-08-30 |  | 0d |  |  |
| 57 | 3.1 | **诺维萨德站/ Novi Sad station / Станица Нови Сад** |  | 659d | 2022-07-01 | 2025-03-01 |  | 255d |  |  |
| 58 | 3.1.1 | 既有线拆除/ Dismantling of existing tracks / Демонтажа постојећих колосека | milestone | 0d | 2022-07-01 | 2022-07-01 |  | 914d |  |  |
| 59 | 3.1.2 | **土建工程/ Civil engineering works / Грађевински радови** |  | 252d | 2022-07-01 | 2023-06-30 |  | 635d |  |  |
| 60 | 3.1.2.1 | 征地和房屋拆迁，见附件Land expropriation and house dismantle, refer to Attachment / Експропријација земљишта и демонтажа куће, види Прилог |  | 30d | 2022-07-01 | 2022-08-04 | 1 | 786d | 75d |  |
| 61 | 3.1.2.2 | 图纸批复Approval of drawings | milestone | 0d | 2022-07-01 | 2022-07-01 | 1 | 816d | 0d |  |
| 62 | 3.1.2.3 | 管线迁改，见附件2Pipeline relocation, refer to Attachment 2 / Премештање цевовода, погледајте Прилог 2 |  | 30d | 2022-07-01 | 2022-08-04 | 1 | 786d | 75d |  |
| 63 | 3.1.2.4 | **车站施工Station** |  | 252d | 2022-07-01 | 2023-06-30 |  | 635d |  |  |
| 64 | 3.1.2.4.1 | 进站道路/ Access roads / Приступни путеви | milestone | 0d | 2022-07-01 | 2022-07-01 | 61 | 816d | 105d |  |
| 65 | 3.1.2.4.2 | 车站外墙、功能房间、屋顶防水的施工/Construction of station exterior walls, functional rooms and roof waterproofing/Izgradnja spoljnih zidova stanice, funkcionalnih prostorija i krovne hidroizolacije |  | 175ed | 2022-07-08 | 2022-12-30 | 1FS+7d | 2745d | 0d |  |
| 66 | 3.1.2.4.3 | 车站其他房间施工/Construction of other rooms in the station/Izgradnja ostalih prostorija u stanici |  | 182ed | 2022-12-30 | 2023-06-30 | 65 | 2745d | 0d |  |
| 67 | 3.1.2.4.4 | 电梯/ Elevators / Лифтови |  | 51d | 2022-10-01 | 2022-12-30 | 1, 65FF | 784d |  |  |
| 68 | 3.1.2.4.5 | 车站标志/ Station signs / Знакови у станици |  | 30d | 2022-10-26 | 2022-12-30 | 1, 65FF | 784d |  |  |
| 69 | 3.1.2.4.6 | 消防设施/ Fire-fighting facilities / Противпожарни уређаји |  | 90d | 2022-08-17 | 2022-12-30 | 1, 65FF | 784d |  |  |
| 70 | 3.1.2.4.7 | 雨蓬/ Canopies / Надстрешнице |  | 120d | 2022-07-13 | 2022-12-30 | 1, 65FF | 784d |  |  |
| 71 | 3.1.2.4.8 | 旅客通道/ Passenger underpass / Путнички потходник |  | 114d | 2022-07-01 | 2022-11-10 | 1 | 711d | 75d |  |
| 72 | 3.1.2.4.9 | 站台/ Platforms / Перони |  | 130d | 2022-07-01 | 2022-11-30 | 1 | 711d | 75d |  |
| 73 | 3.1.2.4.10 | 排水工程/ Drainage works / Радови на дренажи |  | 40ed | 2022-10-03 | 2022-11-12 | 77FF-15d | 3435d |  |  |
| 74 | 3.1.2.4.11 | 接触网基础/ Overhead contact system foundations / Темељи контактне мреже |  | 40ed | 2022-11-20 | 2022-12-30 | 77FF | 3291d |  |  |
| 75 | 3.1.2.4.12 | 路基通信、信号过轨管/ Subgrade TK and SS pipes passing through track / ТК и СС продори доњег строја |  | 20ed | 2022-11-04 | 2022-11-24 | 77FF-5d | 3399d |  |  |
| 76 | 3.1.2.4.13 | 诺维萨德站km77+000～km77+325段加筋土挡墙/ Reinforced retaining wall of Novi Sad station Km77+000～Km77+325 section / Армирани потпорни зид деонице Km77+000～Km77+325 станице Нови Сад |  | 50ed | 2022-11-10 | 2022-12-30 | 77FF | 3291d |  |  |
| 77 | 3.1.2.4.14 | 路基/ Subgrade / Доњи строј |  | 60ed | 2022-10-31 | 2022-12-30 | 71SS+105d, 72SS+105d, 64, 60, 62 | 3126d | 0d |  |
| 78 | 3.1.3 | **轨道工程Rails** |  | 2d | 2022-11-29 | 2023-01-31 |  | 738d |  |  |
| 79 | 3.1.3.1 | 铺设9、10、11股道及25、22、21、19、17、16、15号道岔/ Laying of tracks 9, 10, 11 and turnouts No. 25, 22, 21, 19, 17, 16, 15 / Полагање колосека 9, 10, 11 и скретница бр. 25, 22, 21, 19, 17, 16, 15 |  | 25ed | 2022-11-29 | 2022-12-24 | 77FS-2d, 42SS, 43SS, 45SS, 44SS | 3214.12d | 19.12d |  |
| 80 | 3.1.3.2 | 新铺Novi sad车站3~6股道及9、13、14、18、20、23、24#道岔/ Laying of new tracks 3~6 and turnouts No. 9, 13, 14, 18, 20, 23, 24 of Novi Sad station / Полагање нових колосека 3~6 и скретница број 9, 13, 14, 18, 20, 23, 24 у станици Нови Сад |  | 32ed | 2022-12-30 | 2023-01-31 | 79, 77 | 3195d |  | start no earlier than 2022-12-25 |

| ID | WBS | Task | Duration | Start | Finish | Predecessors | Total slack | Free slack | Constraint |
| --- | --- | --- | --- | --- | --- | --- | --- | --- | --- |
| 81 | 3.1.4 | **电力电气化工程/Electric power Electrification Engineering/Elektrifikacija i elektroenergetski radoviElectric power Electrification Engineering / Elektrifikacija i elektroenergetski radovi** | 652d | 2022-07-09 | 2025-03-01 |  | 255d |  |  |
| 82 | 3.1.4.1 | 接触网立柱、腕臂安装/OCS pole and cantilever installation/Postavljanje stubova kontaktne mreže, montaža konzola | 26d | 2023-07-01 | 2023-07-31 |  | 609d | 0d | start no earlier than 2023-07-01 |
| 83 | 3.1.4.2 | 接触网承导线架设/OCS catenary stretching/Razvlačenje kontaktne mreže | 16d | 2023-08-01 | 2023-08-18 | 82 | 609d | 0d |  |
| 84 | 3.1.4.3 | 接触网悬挂精调/Fine adjustment of catenary suspension/Fina regulacija voznog voda | 11d | 2023-08-19 | 2023-08-31 | 83 | 609d |  |  |
| 85 | 3.1.4.4 | 取电装置安装/Installation of pole mounted substation/Montaža stubnih trafostanica | 70d | 2023-03-15 | 2023-06-09 |  | 680d |  | start no earlier than 2023-03-15 |
| 86 | 3.1.4.5 | 配电室改造/Transformation of distribution room/Rekonstrukcija distributivno transformatorske stanice | 35d | 2023-03-13 | 2023-04-25 |  | 717d |  | start no earlier than 2023-03-12 |
| 87 | 3.1.4.6 | 室内电气工程 /Indoor electrical engineering/Unutrašnja elektroinstalacija | 230d | 2022-07-09 | 2023-06-13 | 65SS | 677d |  | finish no earlier than 2023-05-05 |
| 88 | 3.1.4.7 | 变电所房建主体工程/Main building works of ETS/Strukturalni radovi na objektu EVP | 150d | 2023-02-14 | 2023-08-15 |  | 533d | 0d | start no earlier than 2023-02-14 |
| 89 | 3.1.4.8 | 变电所房建装饰工程/ ETS building decoration project/Dekoraterski radovi na objektu EVP | 90d | 2023-08-16 | 2023-11-29 | 88 | 533d |  |  |
| 90 | 3.1.4.9 | 变电所亭设备安装/Installation of ETS equipment/Montaža opreme u EVP | 180d | 2024-06-01 | 2025-03-01 |  | 255d |  | start no earlier than 2024-06-01 |
| 91 | 3.1.4.10 | 站场照明/Station lighting/Stanična rasveta | 104d | 2022-08-01 | 2022-12-30 | 72SF+31d | 784d |  | finish no earlier than 2022-12-30 |
| 92 | 3.1.5 | **通信信号工程/Telecommunication and Signaling works / ТК и СС радови** | 506d | 2022-12-30 | 2025-02-01 |  | 278d |  |  |
| 93 | 3.1.5.1 | **SS工程/ Signaling works/ СС радови** | 180d | 2024-04-30 | 2025-02-01 |  | 278d |  |  |
| 94 | 3.1.5.1.1 | 临时连锁/Temporary interlocking device / Мобилни уређај међусигналне зависности | 7d | 2024-08-09 | 2024-08-17 | 96SF-1d | 369d |  |  |
| 95 | 3.1.5.1.2 | 光电缆敷设/ Optical cable laying / Полагање оптичких каблова | 90d | 2024-04-30 | 2024-08-19 | 96SF | 368d | 0d |  |
| 96 | 3.1.5.1.3 | 轨旁设备安装/ Trackside equipment mounting / Уградња пружних уређаја | 60d | 2024-08-19 | 2024-10-26 |  | 278d | 0d | start no earlier than 2024-08-19 |
| 97 | 3.1.5.1.4 | 室内设备安装/ Indoor equipment mounting (at station) / Монтажа унутрашње опреме (у станици) | 90d | 2024-04-30 | 2024-08-19 | 95FF | 368d | 0d |  |
| 98 | 3.1.5.1.5 | 信号设备调试/ Testing of the station SS equipment/ Тестирање станичне СС опреме | 60d | 2024-09-23 | 2025-02-01 | 96FS-30d | 278d |  |  |
| 99 | 3.1.5.2 | **TT工程/ Telecommunication works / ТТ радови** | 506d | 2022-12-30 | 2025-02-01 |  | 278d |  |  |
| 100 | 3.1.5.2.1 | 光电缆敷设/ Optical cable laying / Полагање оптичких каблова | 90d | 2024-04-30 | 2024-08-17 | 95SS | 368d |  |  |
| 101 | 3.1.5.2.2 | 综合布线/ Integrated cabling system / структурно каблирање | 182ed | 2022-12-30 | 2023-06-30 | 66FF | 2745d |  |  |
| 102 | 3.1.5.2.3 | 站内通信信息设备安装/Installation of telecommunication and information equipment in the station / Уградња телекомуникационе и информационе опреме у станици | 90d | 2024-04-30 | 2024-08-19 | 97FF | 368d | 0d | finish no earlier than 2023-07-24 |
| 103 | 3.1.5.2.4 | 铁塔工程/Communication tower works/ Радови на ТК стубовима | 276d | 2023-02-02 | 2024-03-02 | 102FF-139d | 507d |  | finish no earlier than 2023-07-24 |
| 104 | 3.1.5.2.5 | TK设备调试/ Testing of the station TK equipment/ Тестирање станичне TK опреме | 60d | 2024-09-23 | 2025-02-01 | 96FS-30d | 278d |  |  |

| ID | WBS | Task | Type | Duration | Start | Finish | Predecessors | Total slack | Free slack | Constraint |
| --- | --- | --- | --- | --- | --- | --- | --- | --- | --- | --- |
| 105 | 3.2 | **诺维萨德站枢-萨耶罗沃站（诺维萨德枢纽相关工程）/ Novi Sad terminal-Sajlovo station (Novi Sad railway terminal related projects) / Станица Нови Сад-станица Сајлово (Припадајући пројекти железничког чвора Нови Сад)** |  | 611d | 2022-07-01 | 2024-11-01 |  | 303d |  |  |
| 106 | 3.2.1 | **土建工程/ Civil engineering works / Грађевински радови** |  | 382d | 2022-07-01 | 2023-12-31 |  | 461d |  |  |
| 107 | 3.2.1.1 | **既有线拆除/ Dismantling of existing tracks / Демонтажа постојећих колосека** |  | 0d | 2022-07-01 | 2022-07-01 |  | 516d |  |  |
| 108 | 3.2.1.1.1 | 拆除诺维萨德至萨耶罗沃之间的既有线（含39#道岔及20道）/ Dismantling of existing track from Novi Sad station to Sajlovo station (including turnout 39# and track 20)/ Демонтажа постојећег колосека између станице Нови Сад и станице Сајлово (укључујући скретницу 39# и колосек 20) | milestone | 0d | 2022-07-01 | 2022-07-01 | 1 | 516d | 0d |  |
| 109 | 3.2.1.2 | **Km77+807铁路桥拆除重建/ Demolition and reconstruction of railway bridge at Km77+807/ Рушење и реконструкција железничког моста на Km77+807** |  | 130d | 2022-07-01 | 2022-12-31 |  | 727d |  |  |
| 110 | 3.2.1.2.1 | 征地和房屋拆迁，见附件Land expropriation and house dismantle, refer to Attachment 1 / Експропријација земљишта и демонтажа куће, види Прилог | milestone | 0d | 2022-07-01 | 2022-07-01 | 1 | 914d |  |  |
| 111 | 3.2.1.2.2 | 图纸批复Approval of drawings |  | 4d | 2022-07-01 | 2022-07-05 | 1 | 910d |  |  |
| 112 | 3.2.1.2.3 | 管线迁改，见附件2Pipeline relocation, refer to Attachment 2 / Премештање цевовода, погледајте Прилог 2 |  | 51d | 2022-07-01 | 2022-08-29 | 1 | 863d |  |  |
| 113 | 3.2.1.2.4 | 交通导改，施作围闭/ Traffic redirection, fencing off and closure of the construction site / Преусмеравање саобраћаја, ограђивање и затварање градилишта | milestone | 0d | 2022-07-01 | 2022-07-01 | 1 | 727d | 0d |  |
| 114 | 3.2.1.2.5 | **桥梁施工Bridges** |  | 130d | 2022-07-01 | 2022-12-31 |  | 727d |  |  |
| 115 | 3.2.1.2.5.1 | 桥梁拆除/ Bridge demolition / Рушење моста | milestone | 0d | 2022-07-01 | 2022-07-01 | 108 | 914d |  |  |
| 116 | 3.2.1.2.5.2 | 试桩/ Test pile / Пробни шип |  | 10ed | 2022-07-01 | 2022-07-11 | 113 | 3183d | 0d |  |
| 117 | 3.2.1.2.5.3 | 桩基施工/ Pile foundations construction / Извођење шипова |  | 57ed | 2022-07-11 | 2022-09-06 | 116 | 3183d | 0d |  |
| 118 | 3.2.1.2.5.4 | 承台施工/ Pile caps construction / Извођење наглавних греда |  | 61d | 2022-07-22 | 2022-09-30 | 117SS+10d | 728d | 0d |  |
| 119 | 3.2.1.2.5.5 | 墩柱、桥台、垫石施工/ Construction of piers, abutments, pedestals / Извођење средњих стубова, крајњих стубова, квадера |  | 70d | 2022-08-06 | 2022-10-26 | 118SS+13d | 728d | 3d | start no earlier than 2022-06-01 |
| 120 | 3.2.1.2.5.6 | 现浇梁施工/ Cast-in-situ beam construction / Извођење греде ливене на лицу места |  | 41ed | 2022-10-31 | 2022-12-11 | 119FS+4d | 3184.88d | 0d |  |
| 121 | 3.2.1.2.5.7 | 桥面系施工、支架模板拆除、交通恢复及动载试验/ Bridge deck system construction, removal of support and formwork, restoring of traffic and dynamic test |  | 20ed | 2022-12-11 | 2022-12-31 | 120 | 3184.88d | 889.88d |  |
| 122 | 3.2.1.3 | **Km78+377空间刚构桥/ Km78+377 gallery / Галерија на Km78+377** |  | 331d | 2022-07-01 | 2023-09-30 |  | 461d |  |  |
| 123 | 3.2.1.3.1 | 征地和房屋拆迁，见附件Land expropriation and house dismantle, refer to Attachment / Експропријација земљишта и демонтажа куће, види Прилог | milestone | 0d | 2022-07-01 | 2022-07-01 | 1 | 485d | 24d |  |
| 124 | 3.2.1.3.2 | **图纸批复Approval of drawings** |  | 59d | 2022-07-01 | 2022-09-07 |  | 461d |  |  |
| 125 | 3.2.1.3.2.1 | 试验桩方案的批复 / Test pile method statement approval / Одобравање методе грађења пробног шипа |  | 24d | 2022-07-01 | 2022-07-28 | 1 | 461d | 0d | finish no earlier than 2022-06-30 |
| 126 | 3.2.1.3.2.2 | 桥梁施工方案的批复 / Bridge construction method statement approval / одобравање методе грађења за грађење моста |  | 35d | 2022-07-29 | 2022-09-07 | 125 | 855d |  | finish no earlier than 2022-07-06 |
| 127 | 3.2.1.3.3 | **桥梁施工Bridges** |  | 307d | 2022-07-29 | 2023-09-30 |  | 461d |  |  |
| 128 | 3.2.1.3.3.1 | 试桩/ Test pile / Пробни шип |  | 25d | 2022-07-29 | 2022-08-26 | 123, 125 | 461d | 0d |  |
| 129 | 3.2.1.3.3.2 | 桩基施工/ Pile foundations construction / Извођење шипова |  | 120d | 2022-08-27 | 2023-03-20 | 128 | 461d | 0d |  |
| 130 | 3.2.1.3.3.3 | 地系梁施工/ Pile caps construction / Извођење наглавних греда |  | 75d | 2022-11-12 | 2023-04-12 | 129SS+65d | 506d | 11d |  |
| 131 | 3.2.1.3.3.4 | 墩柱及墙身施工/ Piers and wall bodies construction / Извођење средњих стубова и тела зидова |  | 150ed | 2022-11-29 | 2023-04-28 | 130SS+15d | 2362.88d | 0d |  |
| 132 | 3.2.1.3.3.5 | 顶板施工/ RC slab construction / Извођење АБ плоче |  | 120ed | 2023-04-28 | 2023-08-26 | 131 | 2362.88d | 4.88d |  |
| 133 | 3.2.1.3.3.6 | 翼墙施工/ Wing walls construction / Извођење крилних зидова |  | 30d | 2023-08-28 | 2023-09-30 | 132 | 583d |  |  |
| 134 | 3.2.1.3.3.7 | 桥面系施工/ Bridge deck system construction / Извођење система коловозне плоче |  | 30d | 2023-08-28 | 2023-09-30 | 132 | 553d | 19d |  |

| ID | WBS | Task | Type | Duration | Start | Finish | Predecessors | Total slack | Free slack | Text2 | Text4 |
| --- | --- | --- | --- | --- | --- | --- | --- | --- | --- | --- | --- |
| 135 | 3.2.1.4 | **Km79+321TPS地道及站台/ Underground passage and platform of TPS station at Km79+321 / Потходник и перон станице ТПС на Km79+321** |  | 382d | 2022-07-01 | 2023-12-31 |  | 506d |  |  |  |
| 136 | 3.2.1.4.1 | 征地，见附件Land expropriation, refer to Attachment / Експропријација земљишта, погледајте Прилог |  | 10d | 2022-07-01 | 2022-07-12 | 1 | 506d | 0d |  |  |
| 137 | 3.2.1.4.2 | 图纸批复Approval of drawings | milestone | 0d | 2022-07-01 | 2022-07-01 | 1 | 516d | 10d |  |  |
| 138 | 3.2.1.4.3 | 管线迁改，见附件2Pipeline relocation, refer to Attachment 2 / Премештање цевовода, погледајте Прилог 2 |  | 30d | 2022-07-13 | 2022-08-16 | 1, 137, 108, 136 | 874d |  |  |  |
| 139 | 3.2.1.4.4 | **TPS站施工TPS** |  | 381d | 2022-07-01 | 2023-12-31 |  | 515d |  |  |  |
| 140 | 3.2.1.4.4.1 | 旅客地道/ Passenger underpass / Путнички потходник |  | 120d | 2022-07-13 | 2022-11-30 | 136, 137, 108 | 506d | 0d |  |  |
| 141 | 3.2.1.4.4.2 | 站台/ Platforms / Перони |  | 152ed | 2022-07-01 | 2022-11-30 | 140FF | 2382d | 0d |  |  |
| 142 | 3.2.1.4.4.3 | 标志/ Signs / Знакови |  | 15d | 2022-11-14 | 2022-11-30 | 141FF, 140FF | 506d | 179.12d |  |  |
| 143 | 3.2.1.4.4.4 | 电梯/ Elevators / Лифтови |  | 33ed | 2023-11-28 | 2023-12-31 | 142FS+250d | 2193d |  |  |  |
| 144 | 3.2.1.4.4.5 | 雨蓬/ Canopies / Надстрешнице |  | 30ed | 2023-11-28 | 2023-12-28 | 142FS+250d | 2202d |  |  |  |
| 145 | 3.2.1.5 | **加筋挡土墙/ Reinforced retaining wall / Армирани потпорни зид** |  | 60d | 2023-05-08 | 2023-07-15 |  | 649d |  |  |  |
| 146 | 3.2.1.5.1 | 新建客车疏解左线k0+783~k0+916段加筋土挡墙/ Reinforced retaining wall of k0+783~k0+916 section of newly built left passenger connecting track / Армирани потпорни зид деонице k0+783~k0+916 новоизграђеног левог путничког везног колосека |  | 60d | 2023-05-08 | 2023-07-15 | 153FF-5d | 649d |  |  |  |
| 147 | 3.2.1.6 | **路基施工/ Subgrade construction / Радови на доњем строју** |  | 330d | 2022-07-01 | 2023-09-29 |  | 521d |  |  |  |
| 148 | 3.2.1.6.1 | 征地和房屋拆迁，见附件Land expropriation and house dismantle, refer to Attachment / Експропријација земљишта и демонтажа куће, види Прилог |  | 30d | 2022-07-01 | 2022-08-04 | 1 | 521d | 0d |  |  |
| 149 | 3.2.1.6.2 | 图纸批复Approval of drawings |  | 30d | 2022-07-01 | 2022-08-04 | 1 | 521d | 0d |  |  |
| 150 | 3.2.1.6.3 | 管线迁改，见附件2Pipeline relocation, refer to Attachment 2 / Премештање цевовода, погледајте Прилог 2 |  | 30d | 2022-07-01 | 2022-08-04 | 1 | 521d | 0d |  |  |
| 151 | 3.2.1.6.4 | **路基施工/ Subgrade construction / Радови на доњем строју** |  | 330d | 2022-07-01 | 2023-09-29 |  | 521d | 0d |  |  |
| 152 | 3.2.1.6.4.1 | 诺维萨德站～萨耶罗沃站路基第一段（Km77+411～Km79+200）/The first section of subgrade from Novi Sad Station ～ Sajlovo Station (Km77+411～Km79+200)/Prva sekcija donjeg stroja od stanice Novi Sad ～ stanice Sajlovo (Km77+411～Km79+200) |  | 110d | 2022-07-01 | 2022-11-05 | 148SS, 149SS, 150SS | 521d | 0d | 21111m3 | 主支线路基共线 |
| 153 | 3.2.1.6.4.2 | 诺维萨德站～萨耶罗沃站路基第二段（Km79+200～Km80+500）/The second section of subgrade from Novi Sad Station ～ Sajlovo Station (Km79+200～Km80+500)/Druga sekcija donjeg stroja od stanice Novi Sad ～ stanice Sajlovo (Km79+200～Km80+500) |  | 160d | 2022-11-07 | 2023-07-21 | 152 | 521d | 0d | 59380m3 | 主支线路基共线 |
| 154 | 3.2.1.6.4.3 | 客运疏解线左线路基（0+550～1+575）/Left line subgrade of passenger diversion railway (0+550～1+575)/Donji stroj levog koloseka za putničko preusmeravanje (0+550～1+575) |  | 60d | 2023-07-22 | 2023-09-29 | 153 | 521d | 0d | 81855m3 | 支线81855m3 |
| 155 | 3.2.1.6.4.4 | 排水工程/ Drainage works / Радови на дренажи |  | 280d | 2022-07-19 | 2023-08-19 | 152SS+15d | 569d |  |  |  |
| 156 | 3.2.1.6.4.5 | 接触网基础/ Overhead contact system foundations / Темељи контактне мреже |  | 240d | 2022-10-14 | 2023-09-29 | 154FF | 534d |  |  |  |
| 157 | 3.2.1.6.4.6 | 路基通信、信号过轨管/ Subgrade TK and SS pipes passing through track / ТК и СС продори доњег строја |  | 280d | 2022-07-19 | 2023-08-19 | 152SS+15d | 569d |  |  |  |
| 158 | 3.2.1.6.4.7 | 诺维萨德站牵引变电工程/ Novi Sad station traction substation project / Пројекат вучне подстанице станице Нови Сад |  | 65d | 2023-07-17 | 2023-09-29 | 154FF | 534d |  |  |  |

| ID | WBS | Task | Duration | Start | Finish | Predecessors | Total slack | Free slack | Constraint |
| --- | --- | --- | --- | --- | --- | --- | --- | --- | --- |
| 159 | 3.2.1.7 | **轨道铺设/ Track laying / Полагање колосека** | 30d | 2023-10-24 | 2023-11-28 |  | 534d |  |  |
| 160 | 3.2.1.7.1 | 诺维萨德~萨耶罗沃基地（包含客车疏解线、松博尔支线、贝切伊支线）Novi Sad~base Sajlovo（including passenger untwining line, branch line Sombor and Bečej） Нови Сад~камп Сајлово（укључује путничку распутницу, огранак Сомбор, огранак Бечеј） | 30d | 2023-10-24 | 2023-11-28 | 121, 134, 151FS+20d | 534d |  |  |
| 161 | 3.2.2 | **通信信号工程/Telecommunication and Signaling works / ТК и СС радови** | 181d | 2024-03-30 | 2024-11-01 |  | 303d |  |  |
| 162 | 3.2.2.1 | **SS工程/ Signaling works/ СС радови** | 181d | 2024-03-30 | 2024-11-01 |  | 303d |  |  |
| 163 | 3.2.2.1.1 | 光电缆敷设/ Optical cable laying / Полагање оптичких каблова | 90d | 2024-03-30 | 2024-07-19 | 164SF | 394d | 0d | start no earlier than 2023-05-10 |
| 164 | 3.2.2.1.2 | 轨旁设备安装/ Trackside equipment mounting / Уградња пружних уређаја | 60d | 2024-07-19 | 2024-09-26 | 1934 | 303d | 0d |  |
| 165 | 3.2.2.1.3 | 信号设备调试/ Testing of the station SS equipment/ Тестирање станичне СС опреме | 61d | 2024-08-23 | 2024-11-01 | 164FS-30d | 303d |  |  |
| 166 | 3.2.2.2 | **TT工程/ Telecommunication works / ТТ радови** | 180d | 2024-03-30 | 2024-10-31 |  | 304d |  |  |
| 167 | 3.2.2.2.1 | 光电缆敷设/ Optical cable laying / Полагање оптичких каблова | 90d | 2024-03-30 | 2024-07-18 | 163SS | 394d | 0d |  |
| 168 | 3.2.2.2.2 | 轨旁设备安装/ Trackside equipment mounting / Уградња пружних уређаја | 60d | 2024-07-19 | 2024-09-26 | 164SS | 334d |  |  |
| 169 | 3.2.2.2.3 | 室内设备安装/ Indoor equipment mounting (at station) / Монтажа унутрашње опреме (у станици) | 90d | 2024-03-30 | 2024-07-18 | 167FF | 394d |  |  |
| 170 | 3.2.2.2.4 | TK设备调试/ Testing of the station TK equipment/ Тестирање станичне TK опреме | 60d | 2024-08-23 | 2024-10-31 | 164FS-30d | 304d |  |  |
| 171 | 3.3 | **萨耶罗沃站/ Sajlovo station / Станица Сајлово** | 647d | 2022-07-01 | 2025-02-14 |  | 267d |  |  |
| 172 | 3.3.1 | **土建工程/ Civil engineering works / Грађевински радови** | 380d | 2022-07-01 | 2023-11-28 |  | 534d |  |  |
| 173 | 3.3.1.1 | 进站道路（含城市绕行道路及服务路）/ Access roads (including the city bypass and service road) / Приступни путеви (укључујући градску обилазницу и сервисни пут) | 45d | 2022-07-01 | 2022-08-22 | 1 | 869d |  |  |
| 174 | 3.3.1.2 | 车站标志/ Station signs / Знакови у станици | 45d | 2022-07-01 | 2022-08-22 | 1 | 869d |  |  |
| 175 | 3.3.1.3 | **路基施工/ Subgrade construction / Радови на доњем строју** | 50d | 2023-09-29 | 2023-11-28 |  | 521d |  |  |
| 176 | 3.3.1.3.1 | 萨耶罗沃站路基右半幅（Km80+500～Km80+726.98）/The right part of the subgrade at Sajlovo Station (Km80+500～Km80+726.98)/Desni deo donjeg stroja stanice Sajlovo (Km80+500～Km80+726.98) | 30ed | 2023-09-29 | 2023-10-29 | 154 | 2247d | 0d |  |
| 177 | 3.3.1.3.2 | 萨耶罗沃站路基左半幅（Km80+500～Km80+726.98）/The left part of the subgrade at Sajlovo Station (Km80+500～Km80+726.98)/Levi deo donjeg stroja stanice Sajlovo (Km80+500～Km80+726.98) | 30ed | 2023-10-29 | 2023-11-28 | 176 | 2247d | 0d |  |
| 178 | 3.3.1.3.3 | 接触网基础/ Overhead contact system foundations / Темељи контактне мреже | 45d | 2023-10-06 | 2023-11-28 | 177FF | 534d |  |  |
| 179 | 3.3.1.3.4 | 排水工程/ Drainage works / Радови на дренажи | 30d | 2023-10-18 | 2023-11-22 | 176SS+15d | 539d |  |  |
| 180 | 3.3.1.3.5 | 路基通信、信号过轨管/ Subgrade TK and SS pipes passing through track / ТК и СС продори доњег строја | 30d | 2023-10-18 | 2023-11-22 | 176SS+15d | 539d |  |  |
| 181 | 3.3.2 | **道岔铺设Turnouts laying Постављање скретница** | 15d | 2023-11-13 | 2023-12-13 |  | 521d |  |  |
| 182 | 3.3.2.1 | 萨耶罗沃站（Km80+300，15组-10组60E1-300,5组49E1-300）Sajlovo station (Km80+300，15 turnouts -10 turnouts 60E1-300,5 turnouts 49e1-300） Станица Сајлово (Km80+300，15скретница-10 скретнице 60E1-300,5 скретница 49E1-300） | 30ed | 2023-11-13 | 2023-12-13 | 176, 177FF+15ed | 2247d |  |  |

| ID | WBS | Task | Type | Duration | Start | Finish | Predecessors | Total slack | Free slack | Constraint |
| --- | --- | --- | --- | --- | --- | --- | --- | --- | --- | --- |
| 183 | 3.3.3 | **通信信号工程/Telecommunication and Signaling works / ТК и СС радови** |  | 517d | 2023-02-01 | 2025-02-14 |  | 267d |  |  |
| 184 | 3.3.3.1 | 房建工程/Construction & renovation for Equipment house / Радови изградње и реновирању зграда |  | 273d | 2023-02-01 | 2024-02-27 | 188SF-90d | 511d | 0d | start no earlier than 2023-02-01 |
| 185 | 3.3.3.2 | **SS工程/ Signaling works/ СС радови** |  | 180d | 2024-05-18 | 2025-02-14 |  | 267d |  |  |
| 186 | 3.3.3.2.1 | 光电缆敷设/ Optical cable laying / Полагање оптичких каблова |  | 90d | 2024-05-18 | 2024-08-31 | 187SF | 357d | 0d |  |
| 187 | 3.3.3.2.2 | 轨旁设备安装/ Trackside equipment mounting / Уградња пружних уређаја |  | 60d | 2024-08-31 | 2024-11-08 | 1935 | 267d | 0d |  |
| 188 | 3.3.3.2.3 | 室内设备安装/ Indoor equipment mounting (at station) / Монтажа унутрашње опреме (у станици) |  | 90d | 2024-05-18 | 2024-08-31 | 186FF | 357d | 0d | start no earlier than 2022-10-08 |
| 189 | 3.3.3.2.4 | 信号设备调试/ Testing of the station SS equipment/ Тестирање станичне СС опреме |  | 60d | 2024-10-05 | 2025-02-14 | 187FS-30d | 267d |  |  |
| 190 | 3.3.3.3 | **TT工程/ Telecommunication works / ТТ радови** |  | 444d | 2023-05-05 | 2025-02-14 |  | 267d |  |  |
| 191 | 3.3.3.3.1 | 光电缆敷设/ Optical cable laying / Полагање оптичких каблова |  | 90d | 2024-05-18 | 2024-08-30 | 186SS | 357d |  |  |
| 192 | 3.3.3.3.2 | 综合布线/ Integrated cabling system / структурно каблирање |  | 90d | 2023-09-11 | 2024-02-27 | 184FF | 511d |  | start no earlier than 2022-09-08 |
| 193 | 3.3.3.3.3 | 站内通信信息设备安装/Installation of telecommunication and information equipment in the station / Уградња телекомуникационе и информационе опреме у станици |  | 90d | 2024-05-18 | 2024-08-31 | 188FF | 357d |  | finish no earlier than 2023-07-24 |
| 194 | 3.3.3.3.4 | 铁塔工程/Communication tower works/ Радови на ТК стубовима |  | 200d | 2023-05-05 | 2024-02-27 | 184FF | 511d |  | finish no earlier than 2023-07-24 |
| 195 | 3.3.3.3.5 | TK设备调试/ Testing of the station TK equipment/ Тестирање станичне TK опреме |  | 60d | 2024-10-05 | 2025-02-14 | 187FS-30d | 267d |  |  |
| 196 | 3.4 | **萨耶罗沃（Km80+300，不含）~鲁门卡站（Km84+043.75，不含）2023.8.10/ Sajlovo station (Km80+300, not including)~Rumenka station (Km84+043.75, not including) / Станица Сајлово (Km80+300, не укључујући)~Станица Руменка (Km84+043.75, не укључујући)** |  | 635d | 2022-07-01 | 2024-12-15 |  | 67d |  |  |
| 197 | 3.4.1 | **土建工程/ Civil engineering works / Грађевински радови** |  | 635d | 2022-07-01 | 2024-12-15 |  | 67d |  |  |
| 198 | 3.4.1.1 | **新建K81+284空间刚构桥/ Newly buillt K81+284 gallery / Новоизграђена галерија на K81+284** |  | 369d | 2022-07-01 | 2023-11-15 |  | 351d |  |  |
| 199 | 3.4.1.1.1 | 征地，见附件Land expropriation, refer to Attachment / Експропријација земљишта, погледајте Прилог | milestone | 0d | 2022-07-01 | 2022-07-01 | 1 | 399d | 48d |  |
| 200 | 3.4.1.1.2 | 图纸批复Approval of drawings |  | 40d | 2022-07-01 | 2022-08-16 | 1 | 351d | 0d |  |
| 201 | 3.4.1.1.3 | 管线迁改，见附件2Pipeline relocation, refer to Attachment 2 / Премештање цевовода, погледајте Прилог 2 |  | 28d | 2022-07-01 | 2022-08-02 | 1 | 886d |  |  |
| 202 | 3.4.1.1.4 | **桥梁施工Bridges** |  | 321d | 2022-08-26 | 2023-11-15 |  | 351d |  |  |
| 203 | 3.4.1.1.4.1 | 试桩/ Test pile / Пробни шип |  | 50d | 2022-08-26 | 2022-10-22 | 199SS, 200FS+8d | 351d | 14.12d |  |
| 204 | 3.4.1.1.4.2 | 桩基施工/ Pile foundations construction / Извођење шипова |  | 60ed | 2022-11-15 | 2023-01-14 | 203FS+19d | 1654.88d | 235d |  |
| 205 | 3.4.1.1.4.3 | 地系梁施工/ Pile caps construction / Извођење наглавних греда |  | 60ed | 2023-02-08 | 2023-04-09 | 204SS+20d | 1468.88d | 58d |  |
| 206 | 3.4.1.1.4.4 | 墩柱及墙身施工/ Piers and wall bodies construction / Извођење средњих стубова и тела зидова |  | 60ed | 2023-03-06 | 2023-05-05 | 205SS+20d | 1459.88d | 1.88d |  |
| 207 | 3.4.1.1.4.5 | 顶板施工/ RC slab construction / Извођење АБ плоче |  | 105d | 2023-05-06 | 2023-09-05 | 206 | 355d | 0d |  |
| 208 | 3.4.1.1.4.6 | 翼墙施工/ Wing walls construction / Извођење крилних зидова |  | 30d | 2023-09-06 | 2023-10-10 | 207 | 355d | 0d |  |
| 209 | 3.4.1.1.4.7 | 桥面系施工/ Bridge deck system construction / Извођење система коловозне плоче |  | 30d | 2023-10-11 | 2023-11-15 | 208 | 355d | 0d |  |

| ID | WBS | Task | Type | Duration | Start | Finish | Predecessors | Total slack | Free slack |
| --- | --- | --- | --- | --- | --- | --- | --- | --- | --- |
| 210 | 3.4.1.2 | **新建Km81+644.83跨河钢桁梁铁路桥（Km81+567.81～Km81+721.86)/ Km81+644.83 river-crossing steel truss railway bridge（Km81+567.81～Km81+721.86) / Железнички челични решеткасти мост преко канала на Km81+644.83（Km81+567.81～Km81+721.86)** |  | 357d | 2022-07-01 | 2023-10-31 |  | 267d |  |
| 211 | 3.4.1.2.1 | 征地，见附件Land expropriation, refer to Attachment / Експропријација земљишта, погледајте Прилог | milestone | 0d | 2022-07-01 | 2022-07-01 | 1 | 372d | 105d |
| 212 | 3.4.1.2.2 | 图纸批复Approval of drawings |  | 30d | 2022-07-01 | 2022-08-04 | 1 | 322d | 69d |
| 213 | 3.4.1.2.3 | 管线迁改，见附件2Pipeline relocation, refer to Attachment 2 / Премештање цевовода, погледајте Прилог 2 |  | 90d | 2022-07-01 | 2022-10-13 | 1 | 267d | 11d |
| 214 | 3.4.1.2.4 | 运河封闭/ Closure of canal / Затварање канала |  | 120d | 2022-07-01 | 2022-11-18 | 1 | 749d | 0d |
| 215 | 3.4.1.2.5 | **桥梁施工Bridges** |  | 252d | 2022-10-31 | 2023-10-31 |  | 267d |  |
| 216 | 3.4.1.2.5.1 | 围堰筑岛、钢板桩施工/ Cofferdam island, sheet piling construction / Формирање загата, подграђивање талпама |  | 45d | 2022-11-19 | 2023-03-15 | 214 | 749d |  |
| 217 | 3.4.1.2.5.2 | 试桩/ Test pile / Пробни шип |  | 21ed | 2022-10-31 | 2022-11-21 | 211, 212FS+20d, 213FS+15d | 1150.88d | 0d |
| 218 | 3.4.1.2.5.3 | 桩基施工/ Pile foundations construction / Извођење шипова |  | 90ed | 2022-11-21 | 2023-02-19 | 217 | 1150.88d | 1.88d |
| 219 | 3.4.1.2.5.4 | 承台施工/ Pile caps construction / Извођење наглавних греда |  | 60d | 2023-02-20 | 2023-05-05 | 218 | 268d | 0d |
| 220 | 3.4.1.2.5.5 | 墩身、桥台、垫石施工/ Construction of pier shafts, abutments, pedestals / Извођење тела средњих стубова, крајњих стубова, квадера |  | 60d | 2023-03-21 | 2023-06-03 | 219SS+25d | 268d | 0d |
| 221 | 3.4.1.2.5.6 | 钢桁梁原位拼装（含支架搭设）/ Steel truss girders on site assembly (including the setting up of support) / Монтажа решеткастих носача на градилишту (укључујући постављање скеле) |  | 120ed | 2023-06-03 | 2023-10-01 | 220 | 1152d | 0d |
| 222 | 3.4.1.2.5.7 | 桥面系施工/ Bridge deck system construction / Извођење система коловозне плоче |  | 30ed | 2023-10-01 | 2023-10-31 | 221 | 1152d | 0d |
| 223 | 3.4.1.3 | **L0+796.33既有双线桥拆除重建/ Demolition and reconstruction of L0+796.33 existing double track bridge / Рушење и реконструкција постојећег двоколосечног моста на L0+796.33** |  | 635d | 2022-07-01 | 2024-12-15 |  | 279d |  |
| 224 | 3.4.1.3.1 | 征地及房屋拆迁，见附件Land expropriation and house dismantle, refer to Attachment / Експропријација земљишта и демонтажа куће, види Прилог | milestone | 0d | 2022-07-01 | 2022-07-01 | 1 | 624d | 357d |
| 225 | 3.4.1.3.2 | 图纸批复Approval of drawings |  | 105d | 2022-07-01 | 2022-10-31 | 1 | 519d | 252d |
| 226 | 3.4.1.3.3 | 运河封闭/ Closure of canal / Затварање канала |  | 30d | 2023-09-27 | 2023-10-31 | 222FF | 267d | 0d |
| 227 | 3.4.1.3.4 | **桥梁施工Bridges** |  | 461d | 2023-03-27 | 2024-12-15 |  | 279d |  |
| 228 | 3.4.1.3.4.1 | 围堰筑岛、钢板桩施工/ Cofferdam island, sheet piling construction / Формирање загата, подграђивање талпама |  | 60ed | 2023-10-31 | 2023-12-30 | 226, 224, 225 | 1153.88d | 0d |
| 229 | 3.4.1.3.4.2 | 既有老桥拆除/ Demolition of the existing old bridge / Рушење постојећег старог моста |  | 40ed | 2023-12-30 | 2024-02-08 | 228 | 1153.88d | 0d |
| 230 | 3.4.1.3.4.3 | 试桩/ Test pile / Пробни шип |  | 21d | 2023-03-27 | 2023-04-22 | 129FS+5d | 461d | 194d |
| 231 | 3.4.1.3.4.4 | 桩基施工/ Pile foundations construction / Извођење шипова |  | 45ed | 2024-02-08 | 2024-03-24 | 230, 229 | 1153.88d | 1.88d |
| 232 | 3.4.1.3.4.5 | 承台施工/ Pile caps construction / Извођење наглавних греда |  | 50d | 2024-02-29 | 2024-04-26 | 231SS+15d | 267d | 0d |
| 233 | 3.4.1.3.4.6 | 墩柱、墩帽、桥台、垫石施工/ Construction of piers, pier caps, abutments, pedestals / Извођење средњих стубова, клупи за лежишта, крајњих стубова, квадера |  | 50d | 2024-03-23 | 2024-05-25 | 232SS+20d | 267d | 5.12d |
| 234 | 3.4.1.3.4.7 | 钢桁梁原位拼装（含支架搭设）/ Steel truss girders on site assembly (including the setting up of support) / Монтажа решеткастих носача на градилишту (укључујући постављање скеле) |  | 160ed | 2024-06-03 | 2024-11-10 | 233FS+7d | 1143d | 0d |
| 235 | 3.4.1.3.4.8 | 桥面系施工/ Bridge deck system construction / Извођење система коловозне плоче |  | 35ed | 2024-11-10 | 2024-12-15 | 234 | 1143d |  |

| ID | WBS | Task | Type | Duration | Start | Finish | Predecessors | Total slack | Free slack |
| --- | --- | --- | --- | --- | --- | --- | --- | --- | --- |
| 236 | 3.4.1.4 | **新建Km82+159.77空间刚构铁路桥 (Km82+125.886～Km82+181.647)/ Newly built Km82+159.77 gallery railway bridge (Km82+125.886～Km82+181.647) / Новоизграђена галерија на Km82+159.77 (Km82+125.886～Km82+181.647)** |  | 270d | 2022-08-11 | 2023-08-31 |  | 33d |  |
| 237 | 3.4.1.4.1 | 征地，见附件Land expropriation, refer to Attachment / Експропријација земљишта, погледајте Прилог |  | 30d | 2022-08-11 | 2022-09-14 | 1FS+35d | 33d | 0d |
| 238 | 3.4.1.4.2 | 图纸批复Approval of drawings |  | 30d | 2022-08-11 | 2022-09-14 | 1FS+35d | 33d | 0d |
| 239 | 3.4.1.4.3 | 管线迁改，见附件2Pipeline relocation, refer to Attachment 2 / Премештање цевовода, погледајте Прилог 2 |  | 30d | 2022-08-11 | 2022-09-14 | 1FS+35d | 33d | 0d |
| 240 | 3.4.1.4.4 | **桥梁施工Bridges** |  | 240d | 2022-09-14 | 2023-08-31 |  | 33d |  |
| 241 | 3.4.1.4.4.1 | 试桩/ Test pile / Пробни шип |  | 21ed | 2022-09-14 | 2022-10-05 | 237, 238, 239 | 118.88d | 17d |
| 242 | 3.4.1.4.4.2 | 桩基施工/ Pile foundations construction / Извођење шипова |  | 60ed | 2022-10-13 | 2022-12-12 | 241FS+7d | 118.88d | 87d |
| 243 | 3.4.1.4.4.3 | 地系梁施工/ Pile caps construction / Извођење наглавних греда |  | 60ed | 2022-11-22 | 2023-01-21 | 242SS+33d | 304.88d | 31.88d |
| 244 | 3.4.1.4.4.4 | 墩柱施工/ Piers construction / Извођење средњих стубова |  | 50d | 2023-02-01 | 2023-04-01 | 243 | 71d | 0d |
| 245 | 3.4.1.4.4.5 | 顶板施工/ RC slab construction / Извођење АБ плоче |  | 75d | 2023-04-03 | 2023-07-04 | 244 | 71d | 0d |
| 246 | 3.4.1.4.4.6 | 挡墙施工/ Wing walls construction / Извођење крилних зидова |  | 43ed | 2023-07-04 | 2023-08-16 | 245 | 250.88d | 0d |
| 247 | 3.4.1.4.4.7 | 桥面系施工/ Bridge deck system construction / Извођење система коловозне плоче |  | 15ed | 2023-08-16 | 2023-08-31 | 246, 245 | 250.88d | 0d |
| 248 | 3.4.1.5 | **涵洞culvert / Пропуст** |  | 130d | 2022-07-01 | 2022-12-30 |  | 252d | 226d |
| 249 | 3.4.1.5.1 | 82+639.61涵洞/ Km82+639.61 culvert / Пропуст на Km82+639.61 |  | 78ed | 2022-10-13 | 2022-12-30 | 250 | 1162.88d |  |
| 250 | 3.4.1.5.2 | 83+567.31涵洞/ Km83+567.31 culvert / Пропуст на Km83+567.31 |  | 90d | 2022-07-01 | 2022-10-13 |  | 271d | 0d |
| 251 | 3.4.1.6 | **路基工程/ Subgrade project / Пројекат доњег строја** |  | 330d | 2022-07-01 | 2023-09-29 |  | 67d |  |
| 252 | 3.4.1.6.1 | 征地，见附件Land expropriation, refer to Attachment / Експропријација земљишта, погледајте Прилог |  | 30d | 2022-07-01 | 2022-08-04 | 1 | 67d | 0d |
| 253 | 3.4.1.6.2 | 图纸批复Approval of drawings | milestone | 0d | 2022-07-01 | 2022-07-01 | 1 | 67d | 0d |
| 254 | 3.4.1.6.3 | 管线迁改，见附件2Pipeline relocation, refer to Attachment 2 / Премештање цевовода, погледајте Прилог 2 |  | 30d | 2022-07-01 | 2022-08-04 | 1 | 67d | 0d |
| 255 | 3.4.1.6.4 | **路基施工/ Subgrade construction / Радови на доњем строју** |  | 330d | 2022-07-01 | 2023-09-29 |  | 67d |  |
| 256 | 3.4.1.6.4.1 | 区间路基/ Open track subgrade / Доњи строј отворене пруге |  | 315d | 2022-07-01 | 2023-09-12 | 254SS, 252SS, 253 | 67d | 15d |
| 257 | 3.4.1.6.4.2 | 排水工程/ Drainage works / Радови на дренажи |  | 330d | 2022-07-01 | 2023-09-29 | 1, 256FF | 584d |  |
| 258 | 3.4.1.6.4.3 | 接触网基础/ Overhead contact system foundations / Темељи контактне мреже |  | 330d | 2022-07-01 | 2023-09-29 | 1, 256FF | 524d | 0d |
| 259 | 3.4.1.6.4.4 | 路基通信、信号过轨管/ Subgrade TK and SS pipes passing through track / ТК и СС продори доњег строја |  | 220d | 2022-07-01 | 2023-05-24 | 1, 256SF+120d | 694d |  |

| ID | WBS | Task | Duration | Start | Finish | Predecessors | Total slack | Free slack | Constraint |
| --- | --- | --- | --- | --- | --- | --- | --- | --- | --- |
| 260 | 3.4.2 | **电力电气化工程/Electric power Electrification Engineering/Elektrifikacija i elektroenergetski radoviElectric power Electrification Engineering / Elektrifikacija i elektroenergetski radovi** | 307d | 2023-09-01 | 2024-11-02 |  | 302d |  |  |
| 261 | 3.4.2.1 | 接触网立柱、腕臂安装/OCS pole and cantilever installation/Postavljanje stubova kontaktne mreže, montaža konzola | 60d | 2023-09-30 | 2024-02-09 | 258 | 524d |  |  |
| 262 | 3.4.2.2 | 接触网承导线架设/OCS catenary stretching/Razvlačenje kontaktne mreže | 40d | 2024-02-01 | 2024-03-20 | 1872 | 437d | 135d |  |
| 263 | 3.4.2.3 | 接触网悬挂精调/Fine adjustment of catenary suspension/Fina regulacija voznog voda | 55d | 2024-08-31 | 2024-11-02 | 1935, 262 | 302d |  |  |
| 264 | 3.4.2.4 | 电力迁改110kv/Electricity relocation 110kv/Izmeštanje kablova 110kV | 48d | 2023-09-01 | 2023-10-26 |  | 561d |  | finish no earlier than 2023-10-26 |
| 265 | 3.4.3 | **通信信号工程/Telecommunication and Signaling works / ТК и СС радови** | 180d | 2024-03-30 | 2024-10-31 |  | 304d |  |  |
| 266 | 3.4.3.1 | **SS工程/ Signaling works/ СС радови** | 180d | 2024-03-30 | 2024-10-31 |  | 304d |  |  |
| 267 | 3.4.3.1.1 | 光电缆敷设/ Optical cable laying / Полагање оптичких каблова | 90d | 2024-03-30 | 2024-07-19 | 268SF | 394d | 0d | start no earlier than 2023-05-10 |
| 268 | 3.4.3.1.2 | 轨旁设备安装/ Trackside equipment mounting / Уградња пружних уређаја | 60d | 2024-07-19 | 2024-09-26 | 1934 | 304d | 0d |  |
| 269 | 3.4.3.1.3 | 信号设备调试/ Testing of the station SS equipment/ Тестирање станичне СС опреме | 60d | 2024-08-23 | 2024-10-31 | 268FS-30d | 304d |  |  |
| 270 | 3.4.3.2 | **TT工程/ Telecommunication works / ТТ радови** | 180d | 2024-03-30 | 2024-10-31 |  | 304d |  |  |
| 271 | 3.4.3.2.1 | 光电缆敷设/ Optical cable laying / Полагање оптичких каблова | 90d | 2024-03-30 | 2024-07-18 | 267SS | 394d | 0d |  |
| 272 | 3.4.3.2.2 | 轨旁设备安装/ Trackside equipment mounting / Уградња пружних уређаја | 60d | 2024-07-19 | 2024-09-26 | 268SS | 334d |  |  |
| 273 | 3.4.3.2.3 | 室内设备安装/ Indoor equipment mounting (at station) / Монтажа унутрашње опреме (у станици) | 90d | 2024-03-30 | 2024-07-18 | 271FF | 394d |  |  |
| 274 | 3.4.3.2.4 | TK设备调试/ Testing of the station TK equipment/ Тестирање станичне TK опреме | 60d | 2024-08-23 | 2024-10-31 | 268FS-30d | 304d |  |  |
| 275 | 3.5 | **鲁门卡站（Km84+043.75）/ Rumenka station（Km84+043.75）/ Станица Руменка（Km84+043.75）** | 680d | 2022-07-01 | 2025-03-26 |  | 127d |  |  |
| 276 | 3.5.1 | **土建工程/ Civil engineering works / Грађевински радови** | 262d | 2022-07-01 | 2023-07-12 |  | 127d |  |  |
| 277 | 3.5.1.1 | 征地和房屋拆除，见附件Land expropriation and house dismantle, refer to Attachment / Експропријација земљишта и демонтажа куће, види Прилог | 30d | 2022-07-01 | 2022-08-04 | 1 | 243d | 0d |  |
| 278 | 3.5.1.2 | 图纸批复Approval of drawings | 30d | 2022-07-01 | 2022-08-04 | 1 | 127d | 0d |  |
| 279 | 3.5.1.3 | 管线迁改，见附件2Pipeline relocation, refer to Attachment 2 / Премештање цевовода, погледајте Прилог 2 | 30d | 2022-07-01 | 2022-08-04 | 1 | 243d | 0d |  |
| 280 | 3.5.1.4 | **车站施工Station** | 232d | 2022-08-05 | 2023-07-12 |  | 228d |  |  |
| 281 | 3.5.1.4.1 | 进站道路/ Access roads / Приступни путеви | 45d | 2022-08-05 | 2022-09-26 | 277, 278, 279 | 749d | 0d |  |
| 282 | 3.5.1.4.2 | 房屋建筑/ Building construction / Високоградња | 60d | 2022-09-27 | 2023-02-06 | 281 | 749d | 0d |  |
| 283 | 3.5.1.4.3 | 车站标志/ Station signs / Знакови у станици | 30d | 2022-11-01 | 2023-02-06 | 282FF | 779d |  |  |
| 284 | 3.5.1.4.4 | 排水工程/ Drainage works / Радови на дренажи | 100d | 2023-02-08 | 2023-06-12 | 287SS+5d | 678d |  |  |
| 285 | 3.5.1.4.5 | 接触网基础/ Overhead contact system foundations / Темељи контактне мреже | 80d | 2023-04-05 | 2023-07-12 | 287FF+9d | 234d | 0d | start no earlier than 2022-06-01 |
| 286 | 3.5.1.4.6 | 路基通信、信号过轨管/ Subgrade TK and SS pipes passing through track / ТК и СС продори доњег строја | 100d | 2023-02-08 | 2023-06-12 | 287SS+5d | 678d |  |  |
| 287 | 3.5.1.4.7 | 路基/ Subgrade / Доњи строј | 150ed | 2023-02-01 | 2023-07-01 | 277SS+15d, 278SS+131d, 279SS+15d | 468d | 1.88d |  |

| ID | WBS | Task | Type | Duration | Start | Finish | Predecessors | Total slack | Free slack | Constraint |
| --- | --- | --- | --- | --- | --- | --- | --- | --- | --- | --- |
| 288 | 3.5.2 | **电力电气化工程/Electric power Electrification Engineering/Elektrifikacija i elektroenergetski radoviElectric power Electrification Engineering / Elektrifikacija i elektroenergetski radovi** |  | 443d | 2023-06-14 | 2025-03-26 |  | 82d |  |  |
| 289 | 3.5.2.1 | 接触网立柱、腕臂安装/OCS pole and cantilever installation/Postavljanje stubova kontaktne mreže, montaža konzola |  | 60d | 2023-07-13 | 2023-09-20 | 285 | 234d | 0d |  |
| 290 | 3.5.2.2 | 接触网承导线架设/OCS catenary stretching/Razvlačenje kontaktne mreže |  | 40d | 2024-03-02 | 2024-04-17 | 1873 | 418d | 111d |  |
| 291 | 3.5.2.3 | 接触网悬挂精调/Fine adjustment of catenary suspension/Fina regulacija voznog voda |  | 50d | 2024-08-31 | 2024-10-28 | 1935, 290 | 307d |  |  |
| 292 | 3.5.2.4 | 配电室改造/Transformation of distribution room/Rekonstrukcija distributivno transformatorske stanice |  | 52d | 2023-06-14 | 2023-08-12 |  | 625d |  | start no earlier than 2023-06-14 |
| 293 | 3.5.2.5 | 室内电气安装 /Indoor electrical installation/Unutrašnja elektroinstalacija | manual | 90d | 2023-09-18 | 2024-03-05 | 282SS |  |  | start no earlier than 2023-09-18 |
| 294 | 3.5.2.6 | 车站照明设备安装/Installation of station lighting equipment /Montaža stanične rasvete |  | 30d | 2023-08-23 | 2023-09-26 |  | 587d |  | finish no earlier than 2023-09-26 |
| 295 | 3.5.2.7 | 变电室外设备安装/Installation of outdoor equipment of Substation/Montaža spoljašnje opreme distributivno transformatorske stanice |  | 358d | 2023-09-21 | 2025-03-26 | 289 | 234d |  | finish no earlier than 2024-10-01 |
| 296 | 3.5.3 | **通信信号工程/Telecommunication and Signaling works / ТК и СС радови** |  | 517d | 2023-02-01 | 2025-02-14 |  | 267d |  |  |
| 297 | 3.5.3.1 | 房建工程/Construction & renovation for Equipment house / Радови изградње и реновирању зграда |  | 273d | 2023-02-01 | 2024-02-27 | 301SF-90d | 511d | 0d | start no earlier than 2023-02-01 |
| 298 | 3.5.3.2 | **SS工程/ Signaling works/ СС радови** |  | 180d | 2024-05-18 | 2025-02-14 |  | 267d |  |  |
| 299 | 3.5.3.2.1 | 光电缆敷设/ Optical cable laying / Полагање оптичких каблова |  | 90d | 2024-05-18 | 2024-08-31 | 300SF | 357d | 0d |  |
| 300 | 3.5.3.2.2 | 轨旁设备安装/ Trackside equipment mounting / Уградња пружних уређаја |  | 60d | 2024-08-31 | 2024-11-08 | 1935 | 267d | 0d |  |
| 301 | 3.5.3.2.3 | 室内设备安装/ Indoor equipment mounting (at station) / Монтажа унутрашње опреме (у станици) |  | 90d | 2024-05-18 | 2024-08-31 | 299FF | 357d | 0d | start no earlier than 2022-10-08 |
| 302 | 3.5.3.2.4 | 信号设备调试/ Testing of the station SS equipment/ Тестирање станичне СС опреме |  | 60d | 2024-10-05 | 2025-02-14 | 300FS-30d | 267d |  |  |
| 303 | 3.5.3.3 | **TT工程/ Telecommunication works / ТТ радови** |  | 444d | 2023-05-05 | 2025-02-14 |  | 267d |  |  |
| 304 | 3.5.3.3.1 | 光电缆敷设/ Optical cable laying / Полагање оптичких каблова |  | 90d | 2024-05-18 | 2024-08-30 | 299SS | 357d |  |  |
| 305 | 3.5.3.3.2 | 综合布线/ Integrated cabling system / структурно каблирање |  | 90d | 2023-09-11 | 2024-02-27 | 297FF | 511d |  | start no earlier than 2022-09-08 |
| 306 | 3.5.3.3.3 | 站内通信信息设备安装/Installation of telecommunication and information equipment in the station / Уградња телекомуникационе и информационе опреме у станици |  | 90d | 2024-05-18 | 2024-08-31 | 301FF | 357d |  | finish no earlier than 2023-07-24 |
| 307 | 3.5.3.3.4 | 铁塔工程/Communication tower works/ Радови на ТК стубовима |  | 200d | 2023-05-05 | 2024-02-27 | 297FF | 511d |  | finish no earlier than 2023-07-24 |
| 308 | 3.5.3.3.5 | TK设备调试/ Testing of the station TK equipment/ Тестирање станичне TK опреме |  | 60d | 2024-10-05 | 2025-02-14 | 300FS-30d | 267d |  |  |
| 309 | 3.6 | **鲁门卡站（Km84+043.75） ~克萨彻站（Km90+407,不含）2023.8.31/ Rumenka station（Km84+043.75）~Kisač station（Km90+407, not including）/ Станица Руменка（Km84+043.75） ~ Станица Кисач（Km90+407, не укључујући）** |  | 736d | 2022-07-01 | 2025-06-05 |  | 177d |  |  |
| 310 | 3.6.1 | **土建工程/ Civil engineering works / Грађевински радови** |  | 559d | 2022-07-01 | 2024-09-02 |  | 177d |  |  |
| 311 | 3.6.1.1 | 既有轨道拆除/ Dismantling of existing track / Демонтажа постојећег колосека | milestone | 0d | 2022-07-01 | 2022-07-01 | 1 | 188d | 0d |  |

| ID | WBS | Task | Duration | Start | Finish | Predecessors | Total slack | Free slack | Constraint |
| --- | --- | --- | --- | --- | --- | --- | --- | --- | --- |
| 312 | 3.6.1.2 | **Km84+809公路上跨铁路立交桥/ Km84+809 overpass bridge / Надвожњак на Km84+809** | 251d | 2022-11-01 | 2023-10-30 |  | 503d |  |  |
| 313 | 3.6.1.2.1 | 征地，见附件Land expropriation, refer to Attachment / Експропријација земљишта, погледајте Прилог | 30d | 2022-11-01 | 2023-02-06 | 1FS+105d, 311 | 503d | 0d |  |
| 314 | 3.6.1.2.2 | 图纸批复Approval of drawings | 30d | 2022-11-01 | 2023-02-06 | 1FS+105d | 503d | 0d |  |
| 315 | 3.6.1.2.3 | 管线迁改，见附件2Pipeline relocation, refer to Attachment 2 / Премештање цевовода, погледајте Прилог 2 | 30d | 2022-11-01 | 2023-02-06 | 1FS+105d | 503d | 0d |  |
| 316 | 3.6.1.2.4 | **桥梁施工Bridges** | 221d | 2023-02-07 | 2023-10-30 |  | 503d |  |  |
| 317 | 3.6.1.2.4.1 | 试桩/ Test pile / Пробни шип | 21d | 2023-02-07 | 2023-03-04 | 313, 314, 315, 242FS+5d | 503d | 0d |  |
| 318 | 3.6.1.2.4.2 | 桩基施工/ Pile foundations construction / Извођење шипова | 20d | 2023-03-06 | 2023-03-28 | 317 | 503d | 0d |  |
| 319 | 3.6.1.2.4.3 | 承台施工/ Pile caps construction / Извођење наглавних греда | 45d | 2023-03-29 | 2023-05-25 | 318 | 557d | 0d |  |
| 320 | 3.6.1.2.4.4 | 墩身施工/ Pier shafts construction / Извођење тела средњих стубова | 60d | 2023-05-09 | 2023-07-17 | 319SS+30d | 557d | 0d |  |
| 321 | 3.6.1.2.4.5 | 盖梁、桥台施工/ Pier caps, abutments construction / Извођење клупи за лежишта, крајњих стубова | 80d | 2023-06-13 | 2023-09-13 | 320SS+30d | 557d | 0d |  |
| 322 | 3.6.1.2.4.6 | 预制梁安装/ Precast beam installation / Монтажа префабриковане греде | 15d | 2023-09-14 | 2023-09-30 | 321 | 557d | 0d |  |
| 323 | 3.6.1.2.4.7 | 桥面系施工/ Bridge deck system construction / Извођење система коловозне плоче | 30ed | 2023-09-30 | 2023-10-30 | 322 | 2379d | 0d |  |
| 324 | 3.6.1.2.4.8 | **Km84+809铁路立交桥顺接地方公路/ Connection of Km84+809 railway overpass with a local road / Спајање железничког надвожњака на Km84+809 са локалним путем** | 40d | 2023-09-13 | 2023-10-30 |  | 558d |  |  |
| 325 | 3.6.1.2.4.8.1 | 路基施工（开挖、填筑）/ Subgrade construction (excavation, filling) / Радови на доњем строју (ископавање, насипање) | 20ed | 2023-09-13 | 2023-10-03 | 321 | 2382d | 0d |  |
| 326 | 3.6.1.2.4.8.2 | 路面施工（含标线）/ Pavement construction (including marking lines) / Извођење коловоза (укључујући ознаке) | 10ed | 2023-10-03 | 2023-10-13 | 325 | 2382d | 3d |  |
| 327 | 3.6.1.2.4.8.3 | 路灯、边坡腐殖土、水沟等附属工程施工/ Construction of auxiliary projects such as street lamps, slope topsoiling, ditches etc. / Извођење помоћних пројеката попут уличних лампи, хумузирања косина, јаркова, итд. | 16ed | 2023-10-14 | 2023-10-30 | 326, 323FF | 2379d |  |  |
| 328 | 3.6.1.3 | **Km89+315.15公路上跨铁路立交桥/ Km89+315.15 overpass bridge / Надвожњак на Km89+315.15** | 413d | 2023-02-22 | 2024-09-02 |  | 355d |  |  |
| 329 | 3.6.1.3.1 | 征地，见附件Land expropriation, refer to Attachment / Експропријација земљишта, погледајте Прилог | 30d | 2023-02-22 | 2023-03-28 | 1FS+146d | 503d | 0d |  |
| 330 | 3.6.1.3.2 | 图纸批复Approval of drawings | 30d | 2023-02-22 | 2023-03-28 | 1FS+146d | 503d | 0d |  |
| 331 | 3.6.1.3.3 | 管线迁改，见附件2Pipeline relocation, refer to Attachment 2 / Премештање цевовода, погледајте Прилог 2 | 30d | 2023-02-22 | 2023-03-28 | 1FS+146d | 503d | 0d |  |
| 332 | 3.6.1.3.4 | **桥梁施工Bridges** | 383d | 2023-03-29 | 2024-09-02 |  | 355d |  |  |
| 333 | 3.6.1.3.4.1 | 试桩/ Test pile / Пробни шип | 21d | 2023-03-29 | 2023-04-25 | 318, 329, 330, 331 | 503d | 0d | start no earlier than 2022-06-01 |
| 334 | 3.6.1.3.4.2 | 桩基施工/ Pile foundations construction / Извођење шипова | 20d | 2023-04-26 | 2023-05-20 | 333 | 503d | 0d |  |
| 335 | 3.6.1.3.4.3 | 承台施工/ Pile caps construction / Извођење наглавних греда | 45d | 2023-11-22 | 2024-03-16 | 334, 209FS+5d | 355d | 0d |  |
| 336 | 3.6.1.3.4.4 | 墩身施工/ Pier shafts construction / Извођење тела средњих стубова | 60d | 2024-02-29 | 2024-05-14 | 335SS+30d | 355d | 0d | start no earlier than 2022-06-01 |
| 337 | 3.6.1.3.4.5 | 盖梁、桥台施工/ Pier caps, abutments construction / Извођење клупи за лежишта, крајњих стубова | 80d | 2024-04-04 | 2024-07-11 | 336SS+30d | 355d | 0d |  |
| 338 | 3.6.1.3.4.6 | 预制梁安装/ Precast beam installation / Монтажа префабриковане греде | 15d | 2024-07-12 | 2024-07-29 | 337 | 355d | 0d |  |
| 339 | 3.6.1.3.4.7 | 桥面系施工/ Bridge deck system construction / Извођење система коловозне плоче | 30d | 2024-07-30 | 2024-09-02 | 338 | 355d | 0d |  |

| ID | WBS | Task | Duration | Start | Finish | Predecessors | Total slack | Free slack |
| --- | --- | --- | --- | --- | --- | --- | --- | --- |
| 340 | 3.6.1.3.4.8 | **Km89+315.15铁路立交桥顺接地方公路/ Connection of Km89+315.15 railway overpass with a local road / Спајање железничког надвожњака на Km89+315.15 са локалним путем** | 95d | 2024-05-15 | 2024-09-02 |  | 355d |  |
| 341 | 3.6.1.3.4.8.1 | 路基施工（开挖、填筑）/ Subgrade construction (excavation, filling) / Радови на доњем строју (ископавање, насипање) | 30d | 2024-05-15 | 2024-06-18 | 337SS+30d | 385d | 0d |
| 342 | 3.6.1.3.4.8.2 | 路面施工（含标线）/ Pavement construction (including marking lines) / Извођење коловоза (укључујући ознаке) | 10d | 2024-06-19 | 2024-06-29 | 341 | 385d | 30d |
| 343 | 3.6.1.3.4.8.3 | 路灯、边坡腐殖土、水沟等附属工程施工/ Construction of auxiliary projects such as street lamps, slope topsoiling, ditches etc. / Извођење помоћних пројеката попут уличних лампи, хумузирања косина, јаркова, итд. | 25d | 2024-08-05 | 2024-09-02 | 342, 339FF | 355d |  |
| 344 | 3.6.1.4 | **Km89+984.34公路下穿铁路立交桥 (Km89+981.59～Km89+987.09)/ Km89+984.34 railway bridge with a higway passing beneath (Km89+981.59～Km89+987.09) / Подвожњак на Km89+984.34 (Km89+981.59～Km89+987.09)** | 267d | 2022-08-23 | 2023-09-08 |  | 132d |  |
| 345 | 3.6.1.4.1 | 征地，见附件Land expropriation, refer to Attachment / Експропријација земљишта, погледајте Прилог | 30d | 2022-08-23 | 2022-09-26 | 1FS+45d | 174d | 42d |
| 346 | 3.6.1.4.2 | 图纸批复Approval of drawings | 30d | 2022-08-23 | 2022-09-26 | 1FS+45d | 132d | 31d |
| 347 | 3.6.1.4.3 | 管线迁改，见附件2Pipeline relocation, refer to Attachment 2 / Премештање цевовода, погледајте Прилог 2 | 30d | 2022-08-23 | 2022-09-26 | 1FS+45d | 174d | 42d |
| 348 | 3.6.1.4.4 | **桥梁施工Bridges** | 195d | 2022-11-15 | 2023-09-08 |  | 132d |  |
| 349 | 3.6.1.4.4.1 | 钢板桩施工/ Sheet piling construction / Подграђивање талпама | 30ed | 2022-11-15 | 2022-12-15 | 345, 346FS+42d, 347 | 673.88d | 0d |
| 350 | 3.6.1.4.4.2 | 框架桥及公路通道土石方开挖（承载力检测）/ Excavation of earth and stone for the frame bridge and highway passage (bearing capacity test) / Ископавање земље и камена за рамовски мост и путни пролаз (испитивање носивости) | 20ed | 2022-12-15 | 2023-01-04 | 349 | 673.88d | 0d |
| 351 | 3.6.1.4.4.3 | **框架桥施工/ Frame bridge construction / Извођење рамовског моста** | 52d | 2023-01-04 | 2023-04-04 |  | 162d |  |
| 352 | 3.6.1.4.4.3.1 | 框架桥基础施工（含垫层）/ Frame bridge foundation construction (including the bedding) / Извођење темеља рамовског моста (укључујући подлогу од мршавог бетона) | 10ed | 2023-01-04 | 2023-01-14 | 350 | 673.88d | 0d |
| 353 | 3.6.1.4.4.3.2 | 框架桥底板施工/ Frame bridge bottom slab construction / Извођење доње плоче рамовског моста | 15ed | 2023-01-14 | 2023-01-29 | 352 | 673.88d | 0d |
| 354 | 3.6.1.4.4.3.3 | 框架桥墙身施工/ Frame bridge wall bodies construction / Извођење тела зидова рамовског моста | 20ed | 2023-01-29 | 2023-02-18 | 353 | 673.88d | 0d |
| 355 | 3.6.1.4.4.3.4 | 框架桥顶板施工/ Frame bridge top slab construction / Извођење горње плоче рамовског моста | 45ed | 2023-02-18 | 2023-04-04 | 354 | 673.88d | 1.88d |
| 356 | 3.6.1.4.4.4 | **公路通道/ Highway passage / Путни пролаз** | 100d | 2023-04-05 | 2023-08-04 |  | 186d |  |
| 357 | 3.6.1.4.4.4.1 | 公路通道基础施工/ Highway passage foundation construction / Извођење темеља путног пролаза | 20d | 2023-04-05 | 2023-05-03 | 355 | 186d | 0d |
| 358 | 3.6.1.4.4.4.2 | 公路通道底板施工/ Highway passage bottom slab construction / Извођење доње плоче путног пролаза | 25d | 2023-05-04 | 2023-06-01 | 357 | 186d | 0d |
| 359 | 3.6.1.4.4.4.3 | 公路通道墙身施工/ Highway passage wall bodies construction / Извођење тела зидова путног пролаза | 55d | 2023-06-02 | 2023-08-04 | 358 | 186d | 0d |
| 360 | 3.6.1.4.4.5 | 公路通道调平层施工/ Construction of concrete layer for protection of waterproofing of highway passage / Извођење слоја бетона за заштиту хидроизолације путног пролаза | 20d | 2023-08-05 | 2023-08-28 | 359 | 186d | 0d |
| 361 | 3.6.1.4.4.6 | 沥青路面施工/ Pavement waterproofing works / Извођење хидроизолације коловоза | 10d | 2023-08-29 | 2023-09-08 | 360 | 186d | 0d |
| 362 | 3.6.1.4.4.7 | 钢栏杆及保护屏障施工/ Steel railing and protective barrier construction / Извођење челичне ограде и заштитне баријере | 30d | 2023-08-05 | 2023-09-08 | 359 | 186d | 0d |
| 363 | 3.6.1.4.4.8 | 回填/ Backfilling / Насипање | 9d | 2023-08-05 | 2023-08-15 | 359 | 207d | 21d |

| ID | WBS | Task | Type | Duration | Start | Finish | Predecessors | Total slack | Free slack | Constraint |
| --- | --- | --- | --- | --- | --- | --- | --- | --- | --- | --- |
| 364 | 3.6.1.4.4.9 | **Km89+984.34铁路立交桥顺接地方公路/ Connection of Km89+984.34 railway underpass with a local road / Спајање железничког подвожњака на Km89+984.34 са локалним путем** |  | 75d | 2023-06-14 | 2023-09-08 |  | 186d |  |  |
| 365 | 3.6.1.4.4.9.1 | 路基施工（开挖、填筑）/ Subgrade construction (excavation, filling) / Радови на доњем строју (ископавање, насипање) |  | 20d | 2023-06-14 | 2023-07-06 | 359SS+10d | 221d | 0d |  |
| 366 | 3.6.1.4.4.9.2 | 路面施工（含标线）/ Pavement construction (including marking lines) / Извођење коловоза (укључујући ознаке) |  | 10d | 2023-07-07 | 2023-07-18 | 365 | 221d | 35d |  |
| 367 | 3.6.1.4.4.9.3 | 路灯、边坡腐殖土、水沟等附属工程施工/ Construction of auxiliary projects such as street lamps, slope topsoiling, ditches etc. / Извођење помоћних пројеката попут уличних лампи, хумузирања косина, јаркова, итд. |  | 10d | 2023-08-29 | 2023-09-08 | 366, 363FF, 361FF, 362FF | 186d | 65d |  |
| 368 | 3.6.1.5 | **涵洞culvert / Пропуст** |  | 180d | 2023-02-01 | 2023-09-06 |  | 188d | 67d |  |
| 369 | 3.6.1.5.1 | 86+748.33涵洞/ Km86+748.33 culvert / Пропуст на Km86+748.33 |  | 90d | 2023-02-01 | 2023-05-24 | 311FS+130d | 188d | 0d |  |
| 370 | 3.6.1.5.2 | 89+790.89涵洞/ Km89+790.89 culvert / Пропуст на Km89+790.89 |  | 90d | 2023-05-25 | 2023-09-06 | 369 | 188d | 0d |  |
| 371 | 3.6.1.6 | **新建路基/ Subgrade construction / Радови на доњем строју** |  | 320d | 2022-07-01 | 2023-09-18 |  | 198d |  |  |
| 372 | 3.6.1.6.1 | 征地及房屋拆迁，见附件Land expropriation and house dismantle, refer to Attachment / Експропријација земљишта и демонтажа куће, види Прилог |  | 30d | 2022-07-01 | 2022-08-04 | 1 | 198d | 10d |  |
| 373 | 3.6.1.6.2 | 图纸批复Approval of drawings |  | 30d | 2022-07-01 | 2022-08-04 | 1 | 198d | 10d |  |
| 374 | 3.6.1.6.3 | 管线迁改，见附件2Pipeline relocation, refer to Attachment 2 / Премештање цевовода, погледајте Прилог 2 |  | 30d | 2022-07-01 | 2022-08-04 | 1 | 198d | 10d |  |
| 375 | 3.6.1.6.4 | **路基施工/ Subgrade construction / Радови на доњем строју** |  | 320d | 2022-07-01 | 2023-09-18 |  | 198d |  |  |
| 376 | 3.6.1.6.4.1 | 区间路基/ Open track subgrade / Доњи строј отворене пруге |  | 300d | 2022-07-13 | 2023-09-06 | 370FF, 372SS, 373SS, 374SS, 369FF | 188d | 0d |  |
| 377 | 3.6.1.6.4.2 | 排水工程/ Drainage works / Радови на дренажи |  | 250d | 2022-09-09 | 2023-09-06 | 376FF | 604d |  |  |
| 378 | 3.6.1.6.4.3 | 接触网基础/ Overhead contact system foundations / Темељи контактне мреже |  | 250d | 2022-09-21 | 2023-09-18 | 376FF+10d | 544d | 0d |  |
| 379 | 3.6.1.6.4.4 | 声屏障/ Sound barrier / Звучна баријера |  | 90d | 2023-02-13 | 2023-06-05 | 376FF-80d | 684d |  |  |
| 380 | 3.6.1.6.4.5 | 路基通信、信号过轨管/ Subgrade TK and SS pipes passing through track / ТК и СС продори доњег строја |  | 100d | 2022-07-13 | 2022-11-05 | 1, 376SF+100d | 804d |  |  |
| 381 | 3.6.1.6.4.6 | 鲁门卡站牵引变电工程/ Rumenka station traction substation project / Пројекат вучне подстанице станице Руменка |  | 45d | 2022-07-01 | 2022-08-22 | 1 | 869d |  |  |
| 382 | 3.6.2 | **电力电气化工程/Electric power Electrification Engineering/Elektrifikacija i elektroenergetski radoviElectric power Electrification Engineering / Elektrifikacija i elektroenergetski radovi** |  | 588d | 2023-02-24 | 2025-06-05 |  | 178d |  |  |
| 383 | 3.6.2.1 | 接触网立柱、腕臂安装/OCS pole and cantilever installation/Postavljanje stubova kontaktne mreže, montaža konzola |  | 50d | 2023-09-19 | 2023-11-16 | 378 | 544d |  |  |
| 384 | 3.6.2.2 | 接触网承导线架设/OCS catenary stretching/Razvlačenje kontaktne mreže |  | 40d | 2024-03-02 | 2024-04-17 | 1873 | 423d | 111d |  |
| 385 | 3.6.2.3 | 接触网悬挂精调/Fine adjustment of catenary suspension/Fina regulacija voznog voda |  | 45d | 2024-08-31 | 2024-10-22 | 1935, 384 | 312d |  |  |
| 386 | 3.6.2.4 | 克萨彻分区所房建主体工程/Main building works of Kisač TSPn/Strukturalni radovi na objektu PSN Kisač |  | 234d | 2023-02-24 | 2023-11-30 |  | 178d | 0d | finish no earlier than 2023-11-30 |
| 387 | 3.6.2.5 | 克萨彻分区所房建装饰工程/Building decoration works of Kisač TSPn/Dekoraterski radovi na objektu PSN Kisač |  | 122d | 2024-02-01 | 2024-06-29 | 386 | 410d | 0d | finish no earlier than 2024-06-29 |
| 388 | 3.6.2.6 | 室内电气安装 /Indoor electrical installation/Unutrašnja elektroinstalacija |  | 150d | 2024-02-01 | 2024-08-01 | 387SS | 382d |  | finish no earlier than 2023-12-31 |
| 389 | 3.6.2.7 | 变电所亭设备安装/Installation of ETS equipment/Montaža opreme u EVP | manual | 354d | 2024-02-01 | 2025-06-05 | 386 |  |  | start no earlier than 2024-06-06 |
| 390 | 3.6.2.8 | 电力迁改110kv/Electricity relocation 110kv/Izmeštanje kablova 110kV |  | 27d | 2023-10-02 | 2023-11-01 |  | 556d |  | finish no earlier than 2023-11-01 |

| ID | WBS | Task | Duration | Start | Finish | Predecessors | Total slack | Free slack | Constraint |
| --- | --- | --- | --- | --- | --- | --- | --- | --- | --- |
| 391 | 3.6.3 | **通信信号工程/Telecommunication and Signaling works / ТК и СС радови** | 180d | 2024-05-18 | 2025-02-14 |  | 267d |  |  |
| 392 | 3.6.3.1 | **SS工程/ Signaling works/ СС радови** | 180d | 2024-05-18 | 2025-02-14 |  | 267d |  |  |
| 393 | 3.6.3.1.1 | 光电缆敷设/ Optical cable laying / Полагање оптичких каблова | 90d | 2024-05-18 | 2024-08-31 | 394SF | 357d | 0d |  |
| 394 | 3.6.3.1.2 | 轨旁设备安装/ Trackside equipment mounting / Уградња пружних уређаја | 60d | 2024-08-31 | 2024-11-08 | 1935 | 267d | 0d |  |
| 395 | 3.6.3.1.3 | 信号设备调试/ Testing of the station SS equipment/ Тестирање станичне СС опреме | 60d | 2024-10-05 | 2025-02-14 | 394FS-30d | 267d |  |  |
| 396 | 3.6.3.2 | **TT工程/ Telecommunication works / ТТ радови** | 180d | 2024-05-18 | 2025-02-14 |  | 267d |  |  |
| 397 | 3.6.3.2.1 | 光电缆敷设/ Optical cable laying / Полагање оптичких каблова | 90d | 2024-05-18 | 2024-08-30 | 393SS | 357d | 0d |  |
| 398 | 3.6.3.2.2 | 轨旁设备安装/ Trackside equipment mounting / Уградња пружних уређаја | 60d | 2024-08-31 | 2024-11-08 | 394SS | 297d |  |  |
| 399 | 3.6.3.2.3 | 室内设备安装/ Indoor equipment mounting (at station) / Монтажа унутрашње опреме (у станици) | 90d | 2024-05-18 | 2024-08-30 | 397FF | 357d |  |  |
| 400 | 3.6.3.2.4 | TK设备调试/ Testing of the station TK equipment/ Тестирање станичне TK опреме | 60d | 2024-10-05 | 2025-02-14 | 394FS-30d | 267d |  |  |
| 401 | 3.7 | **克萨彻站（Km90+407） 2023.7.30Kisač station (Km90+407) / Станица Кисач (Km90+407)** | 744d | 2022-07-01 | 2025-06-14 |  | 170d |  |  |
| 402 | 3.7.1 | **土建工程/ Civil engineering works / Грађевински радови** | 260d | 2022-07-01 | 2023-07-10 |  | 243d |  |  |
| 403 | 3.7.1.1 | 征地及房屋拆迁，见附件Land expropriation and house dismantle, refer to Attachment / Експропријација земљишта и демонтажа куће, види Прилог | 30d | 2022-07-01 | 2022-08-04 | 1 | 314d | 0d |  |
| 404 | 3.7.1.2 | 图纸批复Approval of drawings | 30d | 2022-07-01 | 2022-08-04 | 1 | 243d | 0d |  |
| 405 | 3.7.1.3 | 管线迁改，见附件2Pipeline relocation, refer to Attachment 2 / Премештање цевовода, погледајте Прилог 2 | 30d | 2022-07-01 | 2022-08-04 | 1 | 314d | 0d |  |
| 406 | 3.7.1.4 | **车站施工Station** | 245d | 2022-07-19 | 2023-07-10 |  | 309d |  |  |
| 407 | 3.7.1.4.1 | 房屋建筑/ Building construction / Високоградња | 130d | 2023-02-01 | 2023-07-10 | 403FS+100d, 404FS+100d, 405FS+100d | 452d | 0d |  |
| 408 | 3.7.1.4.2 | 车站标志/ Station signs / Знакови у станици | 30d | 2023-06-06 | 2023-07-10 | 1, 407FF | 654d |  |  |
| 409 | 3.7.1.4.3 | 电梯/ Elevators / Лифтови | 60d | 2023-04-29 | 2023-07-10 | 1, 407FF | 654d |  |  |
| 410 | 3.7.1.4.4 | 旅客通道/ Passenger underpass / Путнички потходник | 110d | 2022-07-19 | 2022-11-24 | 404SS+15d | 789d |  |  |
| 411 | 3.7.1.4.5 | 雨蓬/ Canopies / Надстрешнице | 115d | 2022-07-19 | 2022-11-30 | 412FF | 784d |  |  |
| 412 | 3.7.1.4.6 | 站台/ Platforms / Перони | 115d | 2022-07-19 | 2022-11-30 | 403SS+15d, 404SS+15d, 405SS+15d | 784d | 0d |  |
| 413 | 3.7.1.4.7 | 排水工程/ Drainage works / Радови на дренажи | 30d | 2022-10-10 | 2022-11-14 | 416SS+5d | 798d |  | start no earlier than 2022-06-01 |
| 414 | 3.7.1.4.8 | 接触网基础/ Overhead contact system foundations / Темељи контактне мреже | 30d | 2022-11-07 | 2023-02-11 | 416FF+10d | 430d | 0d |  |
| 415 | 3.7.1.4.9 | 路基通信、信号过轨管/ Subgrade TK and SS pipes passing through track / ТК и СС продори доњег строја | 30d | 2022-10-10 | 2022-11-14 | 416SS+5d | 798d |  |  |
| 416 | 3.7.1.4.10 | 路基/ Subgrade / Доњи строј | 120ed | 2022-10-03 | 2023-01-31 | 403SS+10d, 404SS+81d, 405SS+10d | 1062d | 1.88d |  |

| ID | WBS | Task | Type | Duration | Start | Finish | Predecessors | Total slack | Free slack | Constraint |
| --- | --- | --- | --- | --- | --- | --- | --- | --- | --- | --- |
| 417 | 3.7.2 | **电力电气化工程/Electric power Electrification Engineering/Elektrifikacija i elektroenergetski radoviElectric power Electrification Engineering / Elektrifikacija i elektroenergetski radovi** |  | 614d | 2023-02-01 | 2025-06-14 |  | 170d |  |  |
| 418 | 3.7.2.1 | 接触网立柱、腕臂安装/OCS pole and cantilever installation/Postavljanje stubova kontaktne mreže, montaža konzola |  | 50d | 2023-02-13 | 2023-04-13 | 414 | 430d | 260d |  |
| 419 | 3.7.2.2 | 接触网承导线架设/OCS catenary stretching/Razvlačenje kontaktne mreže |  | 30d | 2024-04-02 | 2024-05-11 | 1874 | 407d | 121d |  |
| 420 | 3.7.2.3 | 接触网悬挂精调/Fine adjustment of catenary suspension/Fina regulacija voznog voda |  | 45d | 2024-10-01 | 2024-11-22 | 1936, 419 | 286d |  |  |
| 421 | 3.7.2.4 | 配电室改造/Transformation of distribution room/Rekonstrukcija distributivno transformatorske stanice |  | 31d | 2023-05-31 | 2023-07-05 |  | 658d |  | start no earlier than 2023-05-31 |
| 422 | 3.7.2.5 | 室内电气安装 /Indoor electrical installation/Unutrašnja elektroinstalacija |  | 94d | 2023-02-01 | 2023-05-29 | 407SF | 690d |  | start no earlier than 2023-02-01 |
| 423 | 3.7.2.6 | 车站照明设备安装/Installation of station lighting equipment /Montaža stanične rasvete |  | 150d | 2023-03-03 | 2023-08-30 |  | 610d |  | start no earlier than 2023-03-03 |
| 424 | 3.7.2.7 | 变电室外设备安装/Installation of outdoor equipment of Substation/Montaža spoljašnje opreme distributivno transformatorske stanice | manual | 294d | 2024-04-23 | 2025-06-14 | 418 |  |  | start no earlier than 2024-04-23 |
| 425 | 3.7.3 | **通信信号工程/Telecommunication and Signaling works / ТК и СС радови** |  | 552d | 2022-11-21 | 2025-03-18 |  | 241d |  |  |
| 426 | 3.7.3.1 | 房建工程/Construction & renovation for Equipment house / Радови изградње и реновирању зграда |  | 272d | 2022-11-21 | 2024-02-14 | 430SF-100d | 521d | 0d |  |
| 427 | 3.7.3.2 | **SS工程/ Signaling works/ СС радови** |  | 180d | 2024-06-18 | 2025-03-18 |  | 241d |  |  |
| 428 | 3.7.3.2.1 | 光电缆敷设/ Optical cable laying / Полагање оптичких каблова |  | 90d | 2024-06-18 | 2024-10-01 | 429SF | 331d | 0d | start no earlier than 2023-05-10 |
| 429 | 3.7.3.2.2 | 轨旁设备安装/ Trackside equipment mounting / Уградња пружних уређаја |  | 60d | 2024-10-01 | 2025-02-10 | 1936 | 241d | 0d |  |
| 430 | 3.7.3.2.3 | 室内设备安装/ Indoor equipment mounting (at station) / Монтажа унутрашње опреме (у станици) |  | 90d | 2024-06-18 | 2024-10-01 | 428FF | 331d | 0d | start no earlier than 2022-10-08 |
| 431 | 3.7.3.2.4 | 信号设备调试/ Testing of the station SS equipment/ Тестирање станичне СС опреме |  | 60d | 2024-11-05 | 2025-03-18 | 429FS-30d | 241d |  |  |
| 432 | 3.7.3.3 | **TT工程/ Telecommunication works / ТТ радови** |  | 480d | 2023-04-21 | 2025-03-18 |  | 241d |  |  |
| 433 | 3.7.3.3.1 | 光电缆敷设/ Optical cable laying / Полагање оптичких каблова |  | 90d | 2024-06-18 | 2024-09-30 | 428SS | 331d |  |  |
| 434 | 3.7.3.3.2 | 综合布线/ Integrated cabling system / структурно каблирање |  | 90d | 2024-04-03 | 2024-07-22 | 430SS-60d | 391d |  | start no earlier than 2022-09-08 |
| 435 | 3.7.3.3.3 | 站内通信信息设备安装/Installation of telecommunication and information equipment in the station / Уградња телекомуникационе и информационе опреме у станици |  | 90d | 2024-06-18 | 2024-10-01 | 430FF | 331d |  | finish no earlier than 2023-07-24 |
| 436 | 3.7.3.3.4 | 铁塔工程/Communication tower works/ Радови на ТК стубовима |  | 200d | 2023-04-21 | 2024-02-14 | 426FF | 521d |  | finish no earlier than 2023-07-24 |
| 437 | 3.7.3.3.5 | TK设备调试/ Testing of the station TK equipment/ Тестирање станичне TK опреме |  | 60d | 2024-11-05 | 2025-03-18 | 429FS-30d | 241d |  |  |
| 438 | 3.8 | **克萨彻站（Km90+407）~斯帕诺维切沃站（Km97+300）/ Kisač station (Km90+407) ~ Stepanovićevo station (Km97+300) / Станица Кисач (Km90+407) ~ Станица Степановићево (Km97+300)** |  | 673d | 2022-07-01 | 2025-03-18 |  | 77d |  |  |
| 439 | 3.8.1 | **土建工程/ Civil engineering works / Грађевински радови** |  | 488d | 2022-07-01 | 2024-06-11 |  | 77d |  |  |
| 440 | 3.8.1.1 | 既有轨道拆除/ Dismantling of existing track / Демонтажа постојећег колосека | milestone | 0d | 2022-07-01 | 2022-07-01 | 1 | 914d |  |  |

| ID | WBS | Task | Duration | Start | Finish | Predecessors | Total slack | Free slack | Constraint |
| --- | --- | --- | --- | --- | --- | --- | --- | --- | --- |
| 441 | 3.8.1.2 | **Km92+768.08公路上跨铁路立交桥/ Km92+768.08 highway over railway overpass bridge / Надвожњак на Km92+768.08** | 316d | 2022-10-26 | 2024-03-13 |  | 498d |  |  |
| 442 | 3.8.1.2.1 | 征地，见附件Land expropriation, refer to Attachment / Експропријација земљишта, погледајте Прилог | 30d | 2022-10-26 | 2022-11-30 | 1FS+100d | 784d |  |  |
| 443 | 3.8.1.2.2 | 图纸批复Approval of drawings | 30d | 2022-10-26 | 2022-11-30 | 1FS+100d | 784d |  |  |
| 444 | 3.8.1.2.3 | 管线迁改，见附件2Pipeline relocation, refer to Attachment 2 / Премештање цевовода, погледајте Прилог 2 | 30d | 2022-10-26 | 2022-11-30 | 1FS+100d | 784d |  |  |
| 445 | 3.8.1.2.4 | **桥梁施工Bridges** | 276d | 2023-02-13 | 2024-03-13 |  | 498d |  |  |
| 446 | 3.8.1.2.4.1 | 试桩/ Test pile / Пробни шип | 21d | 2023-02-13 | 2023-03-10 | 463 | 498d | 0d |  |
| 447 | 3.8.1.2.4.2 | 桩基施工/ Pile foundations construction / Извођење шипова | 30d | 2023-03-11 | 2023-04-18 | 446 | 498d | 0d |  |
| 448 | 3.8.1.2.4.3 | 承台施工/ Pile caps construction / Извођење наглавних греда | 45d | 2023-04-19 | 2023-06-12 | 447 | 498d | 0d |  |
| 449 | 3.8.1.2.4.4 | 墩身施工/ Pier shafts construction / Извођење тела средњих стубова | 60d | 2023-05-26 | 2023-08-03 | 448SS+30d | 498d | 0d |  |
| 450 | 3.8.1.2.4.5 | 盖梁、桥台施工/ Pier caps, abutments construction / Извођење клупи за лежишта, крајњих стубова | 60d | 2023-06-30 | 2023-09-07 | 449SS+30d | 498d | 0d |  |
| 451 | 3.8.1.2.4.6 | 预制梁安装/ Precast beam installation / Монтажа префабриковане греде | 15d | 2023-09-08 | 2023-09-25 | 450 | 498d | 0d |  |
| 452 | 3.8.1.2.4.7 | 桥面系施工/ Bridge deck system construction / Извођење система коловозне плоче | 30d | 2023-09-26 | 2023-10-30 | 451 | 498d | 0d | start no earlier than 2022-06-01 |
| 453 | 3.8.1.2.4.8 | **Km92+768.08铁路立交桥顺接地方公路/ Connection of Km92+768.08 railway overpass with a local road / Спајање железничког надвожњака на Km92+768.08 са локалним путем** | 60d | 2023-10-31 | 2024-03-13 |  | 498d |  |  |
| 454 | 3.8.1.2.4.8.1 | 路基施工（开挖、填筑）/ Subgrade construction (excavation, filling) / Радови на доњем строју (ископавање, насипање) | 30d | 2023-10-31 | 2024-02-05 | 452 | 498d | 0d |  |
| 455 | 3.8.1.2.4.8.2 | 路面施工（含标线）/ Pavement construction (including marking lines) / Извођење коловоза (укључујући ознаке) | 10d | 2024-02-06 | 2024-02-19 | 454 | 498d | 0d |  |
| 456 | 3.8.1.2.4.8.3 | 路灯、边坡腐殖土、水沟等附属工程施工/ Construction of auxiliary projects such as street lamps, slope topsoiling, ditches etc. / Извођење помоћних пројеката попут уличних лампи, хумузирања косина, јаркова, итд. | 20d | 2024-02-20 | 2024-03-13 | 455 | 498d |  |  |
| 457 | 3.8.1.3 | **Km95+739.56公路上跨铁路立交桥/ Km95+739.56 highway over railway overpass bridge /Надвожњак на Km95+739.56** | 423d | 2022-09-15 | 2024-06-11 |  | 426d |  |  |
| 458 | 3.8.1.3.1 | 征地，见附件Land expropriation, refer to Attachment / Експропријација земљишта, погледајте Прилог | 30d | 2022-09-15 | 2022-10-19 | 1FS+65d | 502d | 4d |  |
| 459 | 3.8.1.3.2 | 图纸批复Approval of drawings | 30d | 2022-09-15 | 2022-10-19 | 1FS+65d | 498d | 0d |  |
| 460 | 3.8.1.3.3 | 管线迁改，见附件2Pipeline relocation, refer to Attachment 2 / Премештање цевовода, погледајте Прилог 2 | 30d | 2022-09-15 | 2022-10-19 | 1FS+65d | 502d | 4d |  |
| 461 | 3.8.1.3.4 | **桥梁施工Bridges** | 389d | 2022-10-25 | 2024-06-11 |  | 426d |  |  |
| 462 | 3.8.1.3.4.1 | 试桩/ Test pile / Пробни шип | 21d | 2022-10-25 | 2022-11-18 | 458, 459FS+4d, 460 | 498d | 0d |  |
| 463 | 3.8.1.3.4.2 | 桩基施工/ Pile foundations construction / Извођење шипова | 20d | 2022-11-19 | 2023-02-11 | 462 | 498d | 0d |  |
| 464 | 3.8.1.3.4.3 | 承台施工/ Pile caps construction / Извођење наглавних греда | 60d | 2023-09-15 | 2023-11-24 | 463, 362FS+5d | 426d | 0d |  |
| 465 | 3.8.1.3.4.4 | 墩身施工/ Pier shafts construction / Извођење тела средњих стубова | 60d | 2023-10-20 | 2024-03-02 | 464SS+30d | 426d | 0d |  |
| 466 | 3.8.1.3.4.5 | 墩身、盖梁施工/ Pier shafts, pier caps construction / Извођење тела средњих стубова, клупи за лежишта | 60d | 2023-11-25 | 2024-04-06 | 465SS+30d | 426d | 0d |  |
| 467 | 3.8.1.3.4.6 | 预制梁安装/ Precast beam installation / Монтажа префабриковане греде | 21d | 2024-04-08 | 2024-05-07 | 466 | 426d | 0d | start no earlier than 2022-06-01 |
| 468 | 3.8.1.3.4.7 | 桥面系施工/ Bridge deck system construction / Извођење система коловозне плоче | 30d | 2024-05-08 | 2024-06-11 | 467 | 426d | 0d |  |

| ID | WBS | Task | Duration | Start | Finish | Predecessors | Total slack | Free slack | Constraint |
| --- | --- | --- | --- | --- | --- | --- | --- | --- | --- |
| 469 | 3.8.1.3.4.8 | **Km95+739.56铁路立交桥顺接地方公路/ Connection of Km95+739.56 railway overpass with a local road / Спајање железничког надвожњака на Km95+739.56 са локалним путем** | 51d | 2024-04-06 | 2024-06-11 |  | 426d |  |  |
| 470 | 3.8.1.3.4.8.1 | 路基施工（开挖、填筑）/ Subgrade construction (excavation, filling) / Радови на доњем строју (ископавање, насипање) | 30ed | 2024-04-06 | 2024-05-06 | 466 | 1722d | 0d |  |
| 471 | 3.8.1.3.4.8.2 | 路面施工（含标线）/ Pavement construction (including marking lines) / Извођење коловоза (укључујући ознаке) | 10ed | 2024-05-06 | 2024-05-16 | 470 | 1722d | 18d |  |
| 472 | 3.8.1.3.4.8.3 | 路灯、边坡腐殖土、水沟等附属工程施工/ Construction of auxiliary projects such as street lamps, slope topsoiling, ditches etc. / Извођење помоћних пројеката попут уличних лампи, хумузирања косина, јаркова, итд. | 20ed | 2024-05-22 | 2024-06-11 | 468FF, 471 | 1704d |  |  |
| 473 | 3.8.1.4 | **Km97+027.31公路下穿铁路立交桥/ Km97+027.31 underpass / Подвожњак на Km97+027.31** | 436d | 2022-07-01 | 2024-04-05 |  | 77d |  |  |
| 474 | 3.8.1.4.1 | 征地及房屋拆迁，见附件Land expropriation and house dismantle, refer to Attachment / Експропријација земљишта и демонтажа куће, види Прилог | 53d | 2022-07-01 | 2022-08-31 | 1 | 140d | 63d |  |
| 475 | 3.8.1.4.2 | 图纸批复Approval of drawings | 53d | 2022-07-01 | 2022-08-31 | 1 | 77d | 0d |  |
| 476 | 3.8.1.4.3 | 管线迁改，见附件2Pipeline relocation, refer to Attachment 2 / Премештање цевовода, погледајте Прилог 2 | 53d | 2022-07-01 | 2022-08-31 | 1 | 140d | 63d | start no earlier than 2022-06-01 |
| 477 | 3.8.1.4.4 | **桥梁施工Bridges** | 320d | 2022-11-15 | 2024-04-05 |  | 77d |  |  |
| 478 | 3.8.1.4.4.1 | 钢板桩施工/ Sheet piling construction / Подграђивање талпама | 30d | 2022-11-15 | 2023-02-21 | 474, 475FS+63d, 476 | 77d | 0d |  |
| 479 | 3.8.1.4.4.2 | 框架桥及公路通道土石方开挖（承载力检测）/ Excavation of earth and stone for the frame bridge and highway passage (bearing capacity test) / Ископавање земље и камена за рамовски мост и путни пролаз (испитивање носивости) | 15d | 2023-02-22 | 2023-03-10 | 478 | 77d | 0d |  |
| 480 | 3.8.1.4.4.3 | **框架桥施工/ Frame bridge construction / Извођење рамовског моста** | 112d | 2023-03-11 | 2023-07-25 |  | 77d |  |  |
| 481 | 3.8.1.4.4.3.1 | 框架桥基础施工（含垫层）/ Frame bridge foundation construction (including the bedding) / Извођење темеља рамовског моста (укључујући подлогу од мршавог бетона) | 10d | 2023-03-11 | 2023-03-22 | 479 | 77d | 0d |  |
| 482 | 3.8.1.4.4.3.2 | 框架桥底板施工/ Frame bridge bottom slab construction / Извођење доње плоче рамовског моста | 15d | 2023-03-23 | 2023-04-08 | 481 | 77d | 0d |  |
| 483 | 3.8.1.4.4.3.3 | 框架桥墙身施工/ Frame bridge wall bodies construction / Извођење тела зидова рамовског моста | 38ed | 2023-04-08 | 2023-05-16 | 482 | 289.88d | 1.88d |  |
| 484 | 3.8.1.4.4.3.4 | 框架桥顶板施工/ Frame bridge top slab construction / Извођење горње плоче рамовског моста | 60d | 2023-05-17 | 2023-07-25 | 483 | 82d | 0d |  |
| 485 | 3.8.1.4.4.4 | **公路通道/ Highway passage / Путни пролаз** | 100d | 2023-07-26 | 2023-11-20 |  | 82d |  |  |
| 486 | 3.8.1.4.4.4.1 | 公路通道基础施工/ Highway passage foundation construction / Извођење темеља путног пролаза | 15d | 2023-07-26 | 2023-08-11 | 484 | 82d | 0d |  |
| 487 | 3.8.1.4.4.4.2 | 公路通道底板施工/ Highway passage bottom slab construction / Извођење доње плоче путног пролаза | 25d | 2023-08-12 | 2023-09-09 | 486 | 82d | 0d |  |
| 488 | 3.8.1.4.4.4.3 | 公路通道墙身施工/ Highway passage wall bodies construction / Извођење тела зидова путног пролаза | 60d | 2023-09-11 | 2023-11-20 | 487 | 82d | 0d |  |
| 489 | 3.8.1.4.4.5 | 公路通道调平层施工/ Construction of concrete layer for protection of waterproofing of highway passage / Извођење слоја бетона за заштиту хидроизолације путног пролаза | 15d | 2023-11-21 | 2024-02-07 | 488 | 82d | 0d |  |
| 490 | 3.8.1.4.4.6 | 沥青路面施工/ Pavement waterproofing works / Извођење хидроизолације коловоза | 10d | 2024-02-08 | 2024-02-21 | 489 | 82d | 0d |  |
| 491 | 3.8.1.4.4.7 | 钢栏杆及保护屏障施工/ Steel railing and protective barrier construction / Извођење челичне ограде и заштитне баријере | 30ed | 2024-02-21 | 2024-03-22 | 490 | 303d | 0d |  |
| 492 | 3.8.1.4.4.8 | 回填/ Backfilling / Насипање | 14ed | 2024-03-22 | 2024-04-05 | 491 | 303d | 0d |  |

| ID | WBS | Task | Duration | Start | Finish | Predecessors | Total slack | Free slack | Constraint |
| --- | --- | --- | --- | --- | --- | --- | --- | --- | --- |
| 493 | 3.8.1.4.4.9 | **Km97+027.31铁路立交桥顺接地方公路/ Connection of Km97+027.31 railway underpass with a local road / Спајање железничког подвожњака на Km97+027.31 са локалним путем** | 63d | 2023-11-21 | 2024-04-05 |  | 81d |  |  |
| 494 | 3.8.1.4.4.9.1 | 路基施工（开挖、填筑）/ Subgrade construction (excavation, filling) / Радови на доњем строју (ископавање, насипање) | 30d | 2023-11-21 | 2024-02-27 | 488 | 82d | 0d |  |
| 495 | 3.8.1.4.4.9.2 | 路面施工（含标线）/ Pavement construction (including marking lines) / Извођење коловоза (укључујући ознаке) | 10d | 2024-02-28 | 2024-03-09 | 494 | 82d | 1d |  |
| 496 | 3.8.1.4.4.9.3 | 路灯、边坡腐殖土、水沟等附属工程施工/ Construction of auxiliary projects such as street lamps, slope topsoiling, ditches etc. / Извођење помоћних пројеката попут уличних лампи, хумузирања косина, јаркова, итд. | 22d | 2024-03-12 | 2024-04-05 | 495, 492FF | 81d | 0d |  |
| 497 | 3.8.1.5 | **涵洞culvert / Пропуст** | 90d | 2023-02-01 | 2023-05-24 |  | 297d | 216d |  |
| 498 | 3.8.1.5.1 | Km92+266.63涵洞/ Km92+266.63 culvert/ Пропуст на Km92+266.63 | 60d | 2023-02-01 | 2023-04-13 | 1FS+130d | 327d |  |  |
| 499 | 3.8.1.5.2 | Km95+376.44涵洞/ Km95+376.44 culvert/ Пропуст наKm95+376.44 | 60d | 2023-03-10 | 2023-05-24 | 1FS+160d | 297d | 30d |  |
| 500 | 3.8.1.6 | **路基/ Subgrade / Доњи строј** | 280d | 2022-07-01 | 2023-08-02 |  | 267d |  |  |
| 501 | 3.8.1.6.1 | 征地及房屋拆迁，见附件Land expropriation and house dismantle, refer to Attachment / Експропријација земљишта и демонтажа куће, види Прилог | 30d | 2022-07-01 | 2022-08-04 | 1 | 267d | 0d |  |
| 502 | 3.8.1.6.2 | 图纸批复Approval of drawings | 10d | 2022-07-01 | 2022-07-12 | 1 | 287d | 20d |  |
| 503 | 3.8.1.6.3 | 管线迁改，见附件2Pipeline relocation, refer to Attachment 2 / Премештање цевовода, погледајте Прилог 2 | 30d | 2022-07-01 | 2022-08-04 | 1 | 267d | 0d |  |
| 504 | 3.8.1.6.4 | **路基施工/ Subgrade construction / Радови на доњем строју** | 280d | 2022-07-01 | 2023-08-02 |  | 297d |  |  |
| 505 | 3.8.1.6.4.1 | 区间路基/ Open track subgrade / Доњи строј отворене пруге | 220d | 2022-08-05 | 2023-06-28 | 501, 502, 503, 499FF | 267d | 0d |  |
| 506 | 3.8.1.6.4.2 | 声屏障/ Sound barrier / Звучна баријера | 90d | 2023-04-18 | 2023-08-02 | 505FF+30d | 634d |  |  |
| 507 | 3.8.1.6.4.3 | 排水工程/ Drainage works / Радови на дренажи | 200d | 2022-08-29 | 2023-06-28 | 1, 505FF | 664d |  | start no earlier than 2022-06-01 |
| 508 | 3.8.1.6.4.4 | 接触网基础/ Overhead contact system foundations / Темељи контактне мреже | 278d | 2022-07-01 | 2023-07-31 | 1, 505FF+20d | 576d | 0d |  |
| 509 | 3.8.1.6.4.5 | 路基通信、信号过轨管/ Subgrade TK and SS pipes passing through track / ТК и СС продори доњег строја | 130d | 2022-09-21 | 2023-04-28 | 505FF-50d | 714d |  |  |
| 510 | 3.8.1.6.4.6 | 克萨彻站牵引变电工程Kisač station traction substation Станица Кисач вучна трафостаница | 45d | 2023-05-08 | 2023-06-28 | 505FF | 664d |  |  |
| 511 | 3.8.2 | **电力电气化工程/Electric power Electrification Engineering/Elektrifikacija i elektroenergetski radoviElectric power Electrification Engineering / Elektrifikacija i elektroenergetski radovi** | 433d | 2023-05-08 | 2025-02-04 |  | 276d |  |  |
| 512 | 3.8.2.1 | 接触网立柱、腕臂安装/OCS pole and cantilever installation/Postavljanje stubova kontaktne mreže, montaža konzola | 60d | 2023-08-01 | 2023-10-09 | 508 | 576d |  |  |
| 513 | 3.8.2.2 | 接触网承导线架设/OCS catenary stretching/Razvlačenje kontaktne mreže | 40d | 2024-04-02 | 2024-05-23 | 1874 | 387d | 111d |  |
| 514 | 3.8.2.3 | 接触网悬挂精调/Fine adjustment of catenary suspension/Fina regulacija voznog voda | 55d | 2024-10-01 | 2025-02-04 | 1936, 513 | 276d |  |  |
| 515 | 3.8.2.4 | 室内电气安装 /Indoor electrical installation/Unutrašnja elektroinstalacija | 116d | 2023-05-08 | 2023-09-19 |  | 593d |  | start no earlier than 2023-05-08 |
| 516 | 3.8.3 | **通信信号工程/Telecommunication and Signaling works / ТК и СС радови** | 180d | 2024-06-18 | 2025-03-18 |  | 241d |  |  |
| 517 | 3.8.3.1 | **SS工程/ Signaling works/ СС радови** | 180d | 2024-06-18 | 2025-03-18 |  | 241d |  |  |
| 518 | 3.8.3.1.1 | 光电缆敷设/ Optical cable laying / Полагање оптичких каблова | 90d | 2024-06-18 | 2024-10-01 | 519SF | 331d | 0d |  |
| 519 | 3.8.3.1.2 | 轨旁设备安装/ Trackside equipment mounting / Уградња пружних уређаја | 60d | 2024-10-01 | 2025-02-10 | 1936 | 241d | 0d |  |
| 520 | 3.8.3.1.3 | 信号设备调试/ Testing of the station SS equipment/ Тестирање станичне СС опреме | 60d | 2024-11-05 | 2025-03-18 | 519FS-30d | 241d |  |  |

| ID | WBS | Task | Type | Duration | Start | Finish | Predecessors | Total slack | Free slack | Constraint |
| --- | --- | --- | --- | --- | --- | --- | --- | --- | --- | --- |
| 521 | 3.8.3.2 | **TT工程/ Telecommunication works / ТТ радови** |  | 180d | 2024-06-18 | 2025-03-18 |  | 241d |  |  |
| 522 | 3.8.3.2.1 | 光电缆敷设/ Optical cable laying / Полагање оптичких каблова |  | 90d | 2024-06-18 | 2024-09-30 | 518SS | 331d | 0d |  |
| 523 | 3.8.3.2.2 | 轨旁设备安装/ Trackside equipment mounting / Уградња пружних уређаја |  | 60d | 2024-10-01 | 2025-02-10 | 519FF | 271d |  |  |
| 524 | 3.8.3.2.3 | 室内设备安装/ Indoor equipment mounting (at station) / Монтажа унутрашње опреме (у станици) |  | 90d | 2024-06-18 | 2024-09-30 | 522FF | 331d |  |  |
| 525 | 3.8.3.2.4 | TK设备调试/ Testing of the station TK equipment/ Тестирање станичне TK опреме |  | 60d | 2024-11-05 | 2025-03-18 | 519FS-30d | 241d |  |  |
| 526 | 3.9 | **斯帕诺维切沃站（Km97+300）Stepanovićevo station / Станица Степановићево** |  | 757d | 2022-07-01 | 2025-06-30 |  | 157d |  |  |
| 527 | 3.9.1 | **土建工程/ Civil engineering works / Грађевински радови** |  | 410d | 2022-07-01 | 2024-03-06 |  | 210d |  |  |
| 528 | 3.9.1.1 | 征地，见附件Land expropriation, refer to Attachment / Експропријација земљишта, погледајте Прилог |  | 30d | 2022-07-01 | 2022-08-04 | 1 | 350d | 0d |  |
| 529 | 3.9.1.2 | 图纸批复Approval of drawings |  | 30d | 2022-07-01 | 2022-08-04 | 1 | 210d | 0d |  |
| 530 | 3.9.1.3 | 管线迁改，见附件2Pipeline relocation, refer to Attachment 2 / Премештање цевовода, погледајте Прилог 2 |  | 30d | 2022-07-01 | 2022-08-04 | 1 | 350d | 0d |  |
| 531 | 3.9.1.4 | **车站施工Station** |  | 395d | 2022-07-19 | 2024-03-06 |  | 345d |  |  |
| 532 | 3.9.1.4.1 | 房屋建筑/ Building construction / Високоградња |  | 150d | 2023-07-11 | 2024-03-06 | 528, 529, 530, 407 | 452d | 0d | start no earlier than 2022-06-01 |
| 533 | 3.9.1.4.2 | 车站标志/ Station signs / Знакови у станици |  | 30d | 2023-11-29 | 2024-03-06 | 1, 532FF | 504d |  |  |
| 534 | 3.9.1.4.3 | 电梯/ Elevators / Лифтови |  | 60d | 2023-10-24 | 2024-03-06 | 1, 532FF | 504d |  |  |
| 535 | 3.9.1.4.4 | 排水工程/ Drainage works / Радови на дренажи |  | 30d | 2023-03-04 | 2023-04-07 | 541SS+5d | 729d |  | start no earlier than 2022-06-01 |
| 536 | 3.9.1.4.5 | 接触网基础/ Overhead contact system foundations / Темељи контактне мреже |  | 35d | 2023-03-28 | 2023-05-12 | 541FF+15d | 383d | 0d |  |
| 537 | 3.9.1.4.6 | 路基通信、信号过轨管/ Subgrade TK and SS pipes passing through track / ТК и СС продори доњег строја |  | 30d | 2023-03-04 | 2023-04-07 | 541SS+5d | 729d |  | start no earlier than 2022-06-01 |
| 538 | 3.9.1.4.7 | 旅客通道/ Passenger underpass / Путнички потходник |  | 110d | 2022-07-19 | 2022-11-24 | 528SS+15d, 529SS+15d, 530SS+15d | 789d |  |  |
| 539 | 3.9.1.4.8 | 雨蓬/ Canopies / Надстрешнице |  | 90ed | 2023-01-22 | 2023-04-22 | 540FF+25d, 541FF | 2952d |  |  |
| 540 | 3.9.1.4.9 | 站台/ Platforms / Перони |  | 110d | 2022-07-19 | 2022-11-24 | 528SS+15d, 529SS+15d, 530SS+15d | 764d | 65d |  |
| 541 | 3.9.1.4.10 | 路基/ Subgrade / Доњи строј |  | 45d | 2023-02-27 | 2023-04-22 | 528SS+10d, 529SS+150d, 530SS+10d | 210d | 0d | start no earlier than 2022-06-01 |
| 542 | 3.9.2 | **电力电气化工程/Electric power Electrification Engineering/Elektrifikacija i elektroenergetski radoviElectric power Electrification Engineering / Elektrifikacija i elektroenergetski radovi** |  | 547d | 2023-05-13 | 2025-06-30 |  | 157d |  |  |
| 543 | 3.9.2.1 | 接触网立柱、腕臂安装/OCS pole and cantilever installation/Postavljanje stubova kontaktne mreže, montaža konzola |  | 65d | 2023-05-13 | 2023-07-27 | 536 | 383d | 226d |  |
| 544 | 3.9.2.2 | 接触网承导线架设/OCS catenary stretching/Razvlačenje kontaktne mreže |  | 40d | 2024-05-08 | 2024-06-22 | 1875 | 361d | 103d |  |
| 545 | 3.9.2.3 | 接触网悬挂精调/Fine adjustment of catenary suspension/Fina regulacija voznog voda |  | 55d | 2024-10-22 | 2025-02-26 | 1937, 544 | 258d |  |  |
| 546 | 3.9.2.4 | 配电室改造/Transformation of distribution room/Rekonstrukcija distributivno transformatorske stanice |  | 52d | 2024-03-07 | 2024-05-11 | 532 | 452d |  | finish no earlier than 2023-05-05 |
| 547 | 3.9.2.5 | 室内电气安装 /Indoor electrical installation/Unutrašnja elektroinstalacija |  | 116d | 2023-07-11 | 2023-11-23 | 532SF | 538d |  | start no earlier than 2023-07-11 |
| 548 | 3.9.2.6 | 车站照明设备安装/Installation of station lighting equipment /Montaža stanične rasvete |  | 90d | 2023-08-31 | 2024-02-14 |  | 520d |  | finish no earlier than 2024-02-14 |
| 549 | 3.9.2.7 | 变电室外设备安装/Installation of outdoor equipment of Substation/Montaža spoljašnje opreme distributivno transformatorske stanice | manual | 256d | 2024-06-27 | 2025-06-30 | 543 |  |  |  |

| ID | WBS | Task | Type | Duration | Start | Finish | Predecessors | Total slack | Free slack | Constraint |
| --- | --- | --- | --- | --- | --- | --- | --- | --- | --- | --- |
| 550 | 3.9.3 | **通信信号工程/Telecommunication and Signaling works / ТК и СС радови** |  | 566d | 2022-11-25 | 2025-04-08 |  | 223d |  |  |
| 551 | 3.9.3.1 | 房建工程/Construction & renovation for Equipment house / Радови изградње и реновирању зграда |  | 306d | 2022-11-25 | 2024-04-01 | 555SF-80d | 483d | 0d |  |
| 552 | 3.9.3.2 | **SS工程/ Signaling works/ СС радови** |  | 180d | 2024-07-09 | 2025-04-08 |  | 223d |  |  |
| 553 | 3.9.3.2.1 | 光电缆敷设/ Optical cable laying / Полагање оптичких каблова |  | 90d | 2024-07-09 | 2024-10-22 | 554SF | 313d | 0d |  |
| 554 | 3.9.3.2.2 | 轨旁设备安装/ Trackside equipment mounting / Уградња пружних уређаја |  | 60d | 2024-10-22 | 2025-03-04 | 1937 | 223d | 0d |  |
| 555 | 3.9.3.2.3 | 室内设备安装/ Indoor equipment mounting (at station) / Монтажа унутрашње опреме (у станици) |  | 90d | 2024-07-09 | 2024-10-22 | 554SF | 313d | 0d | start no earlier than 2022-10-08 |
| 556 | 3.9.3.2.4 | 信号设备调试/ Testing of the station SS equipment/ Тестирање станичне СС опреме |  | 60d | 2024-11-27 | 2025-04-08 | 554FS-30d | 223d |  |  |
| 557 | 3.9.3.3 | **TT工程/ Telecommunication works / ТТ радови** |  | 460d | 2023-06-07 | 2025-04-08 |  | 223d |  |  |
| 558 | 3.9.3.3.1 | 光电缆敷设/ Optical cable laying / Полагање оптичких каблова |  | 90d | 2024-07-09 | 2024-10-21 | 553SS | 313d |  |  |
| 559 | 3.9.3.3.2 | 综合布线/ Integrated cabling system / структурно каблирање |  | 90d | 2023-10-13 | 2024-04-01 | 551FF | 483d |  | start no earlier than 2022-09-08 |
| 560 | 3.9.3.3.3 | 站内通信信息设备安装/Installation of telecommunication and information equipment in the station / Уградња телекомуникационе и информационе опреме у станици |  | 90d | 2024-07-09 | 2024-10-22 | 555FF | 313d |  | finish no earlier than 2023-07-24 |
| 561 | 3.9.3.3.4 | 铁塔工程/Communication tower works/ Радови на ТК стубовима |  | 200d | 2023-06-07 | 2024-04-01 | 551FF | 483d |  | finish no earlier than 2023-07-24 |
| 562 | 3.9.3.3.5 | TK设备调试/ Testing of the station TK equipment/ Тестирање станичне TK опреме |  | 60d | 2024-11-27 | 2025-04-08 | 554FS-30d | 223d |  |  |
| 563 | 3.10 | **斯帕诺维切沃站（Km97+300）~热麻耶沃站（Km102+514，不含）2023.10.15Stepanovićevo station~Zmajevo station / Станица Степановићево~Станица Змајево** |  | 691d | 2022-07-01 | 2025-04-08 |  | 223d |  |  |
| 564 | 3.10.1 | **土建工程/ Civil engineering works / Грађевински радови** |  | 635d | 2022-07-01 | 2024-11-30 |  | 242d |  |  |
| 565 | 3.10.1.1 | 既有轨道拆除/ Dismantling of existing track / Демонтажа постојећег колосека | milestone | 0d | 2022-07-01 | 2022-07-01 | 1 | 437d | 0d |  |
| 566 | 3.10.1.2 | **Km98+149公路上跨铁路立交桥 （公跨铁）Km98+149 bridge / Мост наKm98+149** |  | 461d | 2022-09-09 | 2024-07-19 |  | 338d |  |  |
| 567 | 3.10.1.2.1 | 征地，见附件Land expropriation, refer to Attachment / Експропријација земљишта, погледајте Прилог |  | 31d | 2022-09-09 | 2022-10-14 | 1FS+60d, 565 | 377d | 39d |  |
| 568 | 3.10.1.2.2 | 图纸批复Approval of drawings |  | 31d | 2022-09-09 | 2022-10-14 | 1FS+60d | 338d | 28d |  |
| 569 | 3.10.1.2.3 | 管线迁改，见附件2Pipeline relocation, refer to Attachment 2 / Премештање цевовода, погледајте Прилог 2 |  | 31d | 2022-09-09 | 2022-10-14 | 1FS+60d | 377d | 39d |  |
| 570 | 3.10.1.2.4 | **桥梁施工Bridges** |  | 391d | 2022-11-30 | 2024-07-19 |  | 338d |  |  |
| 571 | 3.10.1.2.4.1 | 试桩/ Test pile / Пробни шип |  | 21ed | 2022-11-30 | 2022-12-21 | 567, 568FS+39d, 569 | 1606.88d | 0d |  |
| 572 | 3.10.1.2.4.2 | 桩基施工/ Pile foundations construction / Извођење шипова |  | 60ed | 2022-12-21 | 2023-02-19 | 571 | 1606.88d | 0d |  |
| 573 | 3.10.1.2.4.3 | 承台施工/ Pile caps construction / Извођење наглавних греда |  | 135ed | 2023-02-19 | 2023-07-04 | 572 | 1606.88d | 72d |  |
| 574 | 3.10.1.2.4.4 | 墩身、桥台施工Pier body, abutment works Радови на телу средњег стуба, упорцу |  | 135ed | 2023-03-25 | 2023-08-07 | 573SS+30d | 1609.88d | 132d |  |
| 575 | 3.10.1.2.4.5 | 现浇梁支架搭设及浇筑Cast in situ beam, scaffolding erection and concrete works Бетонирање греде на лицу места, постављање скеле и бетонирање |  | 388ed | 2023-05-23 | 2024-06-14 | 574SS+45d | 1591.88d | 1.88d |  |
| 576 | 3.10.1.2.4.6 | 桥面系施工/ Bridge deck system construction / Извођење система коловозне плоче |  | 30d | 2024-06-15 | 2024-07-19 | 575 | 393d | 0d |  |

| ID | WBS | Task | Duration | Start | Finish | Predecessors | Total slack | Free slack | Constraint |
| --- | --- | --- | --- | --- | --- | --- | --- | --- | --- |
| 577 | 3.10.1.2.4.7 | **Km98+149铁路立交桥顺接地方公路Km98+149 railway overpass conncetion with local road Повезивање железничког надвожњака са локалним путем у Km98+149** | 62d | 2024-05-09 | 2024-07-19 |  | 393d |  |  |
| 578 | 3.10.1.2.4.7.1 | 路基施工（开挖、填筑）/ Subgrade construction (excavation, filling) / Радови на доњем строју (ископавање, насипање) | 30d | 2024-05-09 | 2024-06-12 | 575SS+240d | 395d | 0d |  |
| 579 | 3.10.1.2.4.7.2 | 路面施工（含标线）/ Pavement construction (including marking lines) / Извођење коловоза (укључујући ознаке) | 10d | 2024-06-13 | 2024-06-24 | 578 | 395d | 2d |  |
| 580 | 3.10.1.2.4.7.3 | 路灯、边坡腐殖土、水沟等附属工程施工/ Construction of auxiliary projects such as street lamps, slope topsoiling, ditches etc. / Извођење помоћних пројеката попут уличних лампи, хумузирања косина, јаркова, итд. | 20d | 2024-06-27 | 2024-07-19 | 579, 576FF | 393d |  |  |
| 581 | 3.10.1.3 | **Km101+132.33公路上跨铁路立交桥（公跨铁）/Km101+132.33 bridge / Мост Km101+132.33** | 297d | 2022-09-28 | 2023-11-20 |  | 541d |  |  |
| 582 | 3.10.1.3.1 | 征地及房屋拆迁，见附件Land expropriation and house dismantle, refer to Attachment / Експропријација земљишта и демонтажа куће, види Прилог | 30d | 2022-09-28 | 2022-11-01 | 1FS+76d | 556d | 38d |  |
| 583 | 3.10.1.3.2 | 图纸批复Approval of drawings | 30d | 2022-09-28 | 2022-11-01 | 1FS+76d | 556d | 38d |  |
| 584 | 3.10.1.3.3 | **桥梁施工Bridges** | 229d | 2023-02-19 | 2023-11-20 |  | 518d |  |  |
| 585 | 3.10.1.3.3.1 | 试桩/ Test pile / Пробни шип | 21ed | 2023-02-19 | 2023-03-12 | 582, 583, 572 | 2236.88d | 0d |  |
| 586 | 3.10.1.3.3.2 | 桩基施工/ Pile foundations construction / Извођење шипова | 39ed | 2023-03-12 | 2023-04-20 | 585 | 2236.88d | 1.88d |  |
| 587 | 3.10.1.3.3.3 | 承台施工/ Pile caps construction / Извођење наглавних греда | 45d | 2023-04-21 | 2023-06-14 | 586 | 541d | 0d |  |
| 588 | 3.10.1.3.3.4 | 墩身施工/ Pier shafts construction / Извођење тела средњих стубова | 45d | 2023-05-11 | 2023-07-01 | 587SS+15d | 541d | 0d |  |
| 589 | 3.10.1.3.3.5 | 盖梁、桥台施工/ Pier caps, abutments construction / Извођење клупи за лежишта, крајњих стубова | 45d | 2023-05-29 | 2023-07-19 | 588SS+15d | 541d | 0d |  |
| 590 | 3.10.1.3.3.6 | 预制梁安装/ Precast beam installation / Монтажа префабриковане греде | 15d | 2023-07-20 | 2023-08-05 | 589 | 541d | 0d |  |
| 591 | 3.10.1.3.3.7 | 桥面系施工/ Bridge deck system construction / Извођење система коловозне плоче | 30d | 2023-08-07 | 2023-09-09 | 590 | 541d | 0d |  |
| 592 | 3.10.1.3.3.8 | **Km101+132.33铁路立交桥顺接地方公路Km101+132.33 railway overpass conncetion with local road Повезивање железничког надвожњака са локалним путем у Km101+132.33** | 60d | 2023-09-11 | 2023-11-20 |  | 541d |  |  |
| 593 | 3.10.1.3.3.8.1 | 路基施工（开挖、填筑）/ Subgrade construction (excavation, filling) / Радови на доњем строју (ископавање, насипање) | 30d | 2023-09-11 | 2023-10-14 | 591 | 541d | 0d | start no earlier than 2022-06-01 |
| 594 | 3.10.1.3.3.8.2 | 路面施工（含标线）/ Pavement construction (including marking lines) / Извођење коловоза (укључујући ознаке) | 10d | 2023-10-16 | 2023-10-26 | 593 | 541d | 0d |  |
| 595 | 3.10.1.3.3.8.3 | 路灯、边坡腐殖土、水沟等附属工程施工/ Construction of auxiliary projects such as street lamps, slope topsoiling, ditches etc. / Извођење помоћних пројеката попут уличних лампи, хумузирања косина, јаркова, итд. | 20d | 2023-10-27 | 2023-11-20 | 594 | 541d |  |  |
| 596 | 3.10.1.4 | **Km101+980,62铁路跨河桥 (Km101+969.52～Km101+991.72)/ Km101+980,62 bridge(Km101+969.52～Km101+991.72) / Мост наKm101+980,62(Km101+969.52～Km101+991.72)** | 241d | 2022-08-27 | 2023-08-14 |  | 193d |  |  |
| 597 | 3.10.1.4.1 | 征地，见附件Land expropriation, refer to Attachment / Експропријација земљишта, погледајте Прилог | 30d | 2022-08-27 | 2022-09-30 | 1FS+49d | 223d | 30d |  |
| 598 | 3.10.1.4.2 | 图纸批复Approval of drawings | 30d | 2022-08-27 | 2022-09-30 | 1FS+49d | 193d | 21d |  |
| 599 | 3.10.1.4.3 | 管线迁改，见附件2Pipeline relocation, refer to Attachment 2 / Премештање цевовода, погледајте Прилог 2 | 30d | 2022-08-27 | 2022-09-30 | 1FS+49d | 223d | 30d |  |
| 600 | 3.10.1.4.4 | **桥梁施工Bridges** | 181d | 2022-11-04 | 2023-08-14 |  | 193d |  |  |
| 601 | 3.10.1.4.4.1 | 围堰筑岛、钢板桩施工/ Cofferdam island, sheet piling construction / Формирање загата, подграђивање талпама | 35ed | 2022-11-04 | 2022-12-09 | 597, 598FS+30d, 599 | 892.88d | 0d |  |
| 602 | 3.10.1.4.4.2 | 试桩/ Test pile / Пробни шип | 21ed | 2022-12-09 | 2022-12-30 | 601 | 892.88d | 0d |  |
| 603 | 3.10.1.4.4.3 | 桩基施工/ Pile foundations construction / Извођење шипова | 30ed | 2022-12-30 | 2023-01-29 | 602 | 892.88d | 0d |  |
| 604 | 3.10.1.4.4.4 | 承台施工/ Pile caps construction / Извођење наглавних греда | 40ed | 2023-01-29 | 2023-03-10 | 603 | 892.88d | 87d |  |
| 605 | 3.10.1.4.4.5 | 台身、台帽、垫石施工Abutment body, abutment top and pad stone works Радови на телу упорца, глави упорца и каменом јастуку | 50ed | 2023-03-09 | 2023-04-28 | 604SS+30d | 1072.88d | 1.88d | start no earlier than 2022-06-01 |
| 606 | 3.10.1.4.4.6 | 现浇梁板梁支架搭设及浇筑Cast in situ beam and slab, scaffolding erection and concrete works Бетонирање греде и плоче на лицу места, постављање скеле и бетонирање | 60d | 2023-04-29 | 2023-07-10 | 605 | 248d | 0d |  |
| 607 | 3.10.1.4.4.7 | 桥面系施工/ Bridge deck system construction / Извођење система коловозне плоче | 30d | 2023-07-11 | 2023-08-14 | 606 | 248d | 166d |  |

| ID | WBS | Task | Duration | Start | Finish | Predecessors | Total slack | Free slack | Constraint |
| --- | --- | --- | --- | --- | --- | --- | --- | --- | --- |
| 608 | 3.10.1.5 | **Km102+390.00公路上跨铁路立交桥/ Km102+390.00 bridge / Мост на Km102+390.00** | 535d | 2022-10-26 | 2024-11-30 |  | 279d |  |  |
| 609 | 3.10.1.5.1 | 征地及房屋拆迁，见附件Land expropriation and house dismantle, refer to Attachment / Експропријација земљишта и демонтажа куће, види Прилог | 30d | 2022-10-26 | 2022-11-30 | 1FS+100d | 784d |  |  |
| 610 | 3.10.1.5.2 | 图纸批复Approval of drawings | 30d | 2022-10-26 | 2022-11-30 | 1FS+100d | 784d |  |  |
| 611 | 3.10.1.5.3 | **桥梁施工Bridges** | 505d | 2023-02-01 | 2024-11-30 |  | 278d |  |  |
| 612 | 3.10.1.5.3.1 | 试桩/ Test pile / Пробни шип | 21d | 2023-02-01 | 2023-02-27 | 603 | 278d | 0d |  |
| 613 | 3.10.1.5.3.2 | 桩基施工/ Pile foundations construction / Извођење шипова | 40d | 2023-02-28 | 2023-04-18 | 612 | 278d | 0d |  |
| 614 | 3.10.1.5.3.3 | 承台施工/ Pile caps construction / Извођење наглавних греда | 105d | 2023-04-04 | 2023-08-09 | 613SS+30d | 278d | 0d | start no earlier than 2022-06-01 |
| 615 | 3.10.1.5.3.4 | 墩身施工/ Pier shafts construction / Извођење тела средњих стубова | 105d | 2023-05-15 | 2023-09-13 | 614SS+30d | 278d | 0d |  |
| 616 | 3.10.1.5.3.5 | 现浇梁支架搭设及浇筑Cast in situ beam, scaffolding erection and concrete works Бетонирање греде на лицу места, постављање скеле и бетонирање | 270d | 2023-07-06 | 2024-07-25 | 615SS+45d | 278d | 0d |  |
| 617 | 3.10.1.5.3.6 | 桥面系施工/ Bridge deck system construction / Извођење система коловозне плоче | 45d | 2024-07-26 | 2024-09-16 | 616 | 278d | 0d |  |
| 618 | 3.10.1.5.3.7 | **Km102+390.00铁路立交桥顺接地方公路Km102+390.00 railway overpass conncetion with local road Повезивање железничког надвожњака са локалним путем у Km102+390.00** | 64d | 2024-09-17 | 2024-11-30 |  | 278d |  |  |
| 619 | 3.10.1.5.3.7.1 | 路基施工（开挖、填筑）/ Subgrade construction (excavation, filling) / Радови на доњем строју (ископавање, насипање) | 30d | 2024-09-17 | 2024-10-21 | 617 | 278d | 0d |  |
| 620 | 3.10.1.5.3.7.2 | 路面施工（含标线）/ Pavement construction (including marking lines) / Извођење коловоза (укључујући ознаке) | 10d | 2024-10-22 | 2024-11-01 | 619 | 278d | 0d |  |
| 621 | 3.10.1.5.3.7.3 | 路灯、边坡腐殖土、水沟等附属工程施工/ Construction of auxiliary projects such as street lamps, slope topsoiling, ditches etc. / Извођење помоћних пројеката попут уличних лампи, хумузирања косина, јаркова, итд. | 29ed | 2024-11-01 | 2024-11-30 | 620 | 1188d |  |  |
| 622 | 3.10.1.6 | **涵洞culvert / Пропуст** | 72d | 2022-10-13 | 2023-03-12 |  | 324d | 294d |  |
| 623 | 3.10.1.6.1 | Km98+212.597涵洞Km98+212.597 culvert / Пропуст на Km98+212.597 | 75ed | 2022-12-27 | 2023-03-12 | 624 | 1546.88d |  |  |
| 624 | 3.10.1.6.2 | Km99+339.543涵洞Km99+339.543 culvert / Пропуст на Km99+339.543 | 75ed | 2022-10-13 | 2022-12-27 | 1FS+90d | 1546.88d | 0d |  |
| 625 | 3.10.1.7 | **路基/ Subgrade / Доњи строј** | 307d | 2022-07-01 | 2023-09-02 |  | 246d |  |  |
| 626 | 3.10.1.7.1 | 征地及房屋拆迁，见附件Land expropriation and house dismantle, refer to Attachment / Експропријација земљишта и демонтажа куће, види Прилог | 30d | 2022-07-01 | 2022-08-04 | 1 | 246d | 0d |  |
| 627 | 3.10.1.7.2 | 图纸批复Approval of drawings | 30d | 2022-07-01 | 2022-08-04 | 1 | 246d | 0d |  |
| 628 | 3.10.1.7.3 | 管线迁改，见附件2Pipeline relocation, refer to Attachment 2 / Премештање цевовода, погледајте Прилог 2 | 30d | 2022-07-01 | 2022-08-04 | 1 | 246d | 0d |  |
| 629 | 3.10.1.7.4 | **桥梁施工Bridges** | 277d | 2022-08-05 | 2023-09-02 |  | 246d |  |  |
| 630 | 3.10.1.7.4.1 | 区间路基/ Open track subgrade / Доњи строј отворене пруге | 262d | 2022-08-05 | 2023-08-16 | 624FF, 626, 627, 628 | 246d | 0d |  |
| 631 | 3.10.1.7.4.2 | 排水工程/ Drainage works / Радови на дренажи | 130d | 2022-08-23 | 2023-03-27 | 630SS+15d | 739d |  |  |
| 632 | 3.10.1.7.4.3 | 声屏障/ Sound barrier / Звучна баријера | 150d | 2023-02-17 | 2023-08-16 | 630FF | 622d |  |  |
| 633 | 3.10.1.7.4.4 | 接触网基础/ Overhead contact system foundations / Темељи контактне мреже | 180d | 2022-11-28 | 2023-09-02 | 630FF+15d | 522d | 0d |  |
| 634 | 3.10.1.7.4.5 | 路基通信、信号过轨管/ Subgrade TK and SS pipes passing through track / ТК и СС продори доњег строја | 130d | 2022-08-23 | 2023-03-27 | 630SS+15d | 739d |  | start no earlier than 2022-06-01 |
| 635 | 3.10.1.7.4.6 | 斯帕诺维切沃站牵引变电工程Stepanovićevo station traction substation project Пројакат тракцијске трафостанице станице Степановићево | 60d | 2023-06-08 | 2023-08-16 | 630FF | 622d |  |  |

| ID | WBS | Task | Duration | Start | Finish | Predecessors | Total slack | Free slack | Constraint |
| --- | --- | --- | --- | --- | --- | --- | --- | --- | --- |
| 636 | 3.10.2 | **电力电气化工程/Electric power Electrification Engineering/Elektrifikacija i elektroenergetski radoviElectric power Electrification Engineering / Elektrifikacija i elektroenergetski radovi** | 339d | 2023-09-04 | 2025-02-13 |  | 268d |  |  |
| 637 | 3.10.2.1 | 接触网立柱、腕臂安装/OCS pole and cantilever installation/Postavljanje stubova kontaktne mreže, montaža konzola | 50d | 2023-09-04 | 2023-10-31 | 633 | 522d | 101d |  |
| 638 | 3.10.2.2 | 接触网承导线架设/OCS catenary stretching/Razvlačenje kontaktne mreže | 35d | 2024-05-08 | 2024-06-17 | 1875, 637 | 421d |  |  |
| 639 | 3.10.2.3 | 接触网悬挂精调/Fine adjustment of catenary suspension/Fina regulacija voznog voda | 45d | 2024-10-22 | 2025-02-13 | 1937 | 268d |  |  |
| 640 | 3.10.2.4 | 室内电气安装 /Indoor electrical installation/Unutrašnja elektroinstalacija | 60d | 2023-11-20 | 2024-04-01 |  | 482d |  | start no earlier than 2023-11-20 |
| 641 | 3.10.3 | **通信信号工程/Telecommunication and Signaling works / ТК и СС радови** | 180d | 2024-07-09 | 2025-04-08 |  | 223d |  |  |
| 642 | 3.10.3.1 | **SS工程/ Signaling works/ СС радови** | 180d | 2024-07-09 | 2025-04-08 |  | 223d |  |  |
| 643 | 3.10.3.1.1 | 光电缆敷设/ Optical cable laying / Полагање оптичких каблова | 90d | 2024-07-09 | 2024-10-22 | 644SF | 313d | 0d | start no earlier than 2023-05-10 |
| 644 | 3.10.3.1.2 | 轨旁设备安装/ Trackside equipment mounting / Уградња пружних уређаја | 60d | 2024-10-22 | 2025-03-04 | 1937 | 223d | 0d |  |
| 645 | 3.10.3.1.3 | 信号设备调试/ Testing of the station SS equipment/ Тестирање станичне СС опреме | 60d | 2024-11-27 | 2025-04-08 | 644FS-30d | 223d |  |  |
| 646 | 3.10.3.2 | **TT工程/ Telecommunication works / ТТ радови** | 180d | 2024-07-09 | 2025-04-08 |  | 223d |  |  |
| 647 | 3.10.3.2.1 | 光电缆敷设/ Optical cable laying / Полагање оптичких каблова | 90d | 2024-07-09 | 2024-10-21 | 643SS | 313d | 0d |  |
| 648 | 3.10.3.2.2 | 轨旁设备安装/ Trackside equipment mounting / Уградња пружних уређаја | 60d | 2024-10-22 | 2025-03-04 | 644SS | 253d |  |  |
| 649 | 3.10.3.2.3 | 室内设备安装/ Indoor equipment mounting (at station) / Монтажа унутрашње опреме (у станици) | 90d | 2024-07-09 | 2024-10-21 | 647FF | 313d |  |  |
| 650 | 3.10.3.2.4 | TK设备调试/ Testing of the station TK equipment/ Тестирање станичне TK опреме | 60d | 2024-11-27 | 2025-04-08 | 644FS-30d | 223d |  |  |
| 651 | 3.11 | **热麻耶沃站（Km102+514）Zmajevo station / Станица Змајево** | 757d | 2022-07-01 | 2025-06-30 |  | 157d |  |  |
| 652 | 3.11.1 | **土建工程/ Civil engineering works / Грађевински радови** | 455d | 2022-07-01 | 2024-04-27 |  | 261d |  |  |
| 653 | 3.11.1.1 | 征地及房屋拆迁，见附件Land expropriation and house dismantle, refer to Attachment / Експропријација земљишта и демонтажа куће, види Прилог | 30d | 2022-07-01 | 2022-08-04 | 1 | 350d | 0d |  |
| 654 | 3.11.1.2 | 图纸批复Approval of drawings | 30d | 2022-07-01 | 2022-08-04 | 1 | 261d | 0d |  |
| 655 | 3.11.1.3 | 管线迁改，见附件2Pipeline relocation, refer to Attachment 2 / Премештање цевовода, погледајте Прилог 2 | 30d | 2022-07-01 | 2022-08-04 | 1 | 350d | 0d |  |
| 656 | 3.11.1.4 | **车站施工Station** | 440d | 2022-07-19 | 2024-04-27 |  | 365d |  |  |
| 657 | 3.11.1.4.1 | 房屋建筑/ Building construction / Високоградња | 180d | 2023-07-28 | 2024-04-27 | 662FF | 399d | 0d |  |
| 658 | 3.11.1.4.2 | 车站标志/ Station signs / Знакови у станици | 30d | 2024-03-25 | 2024-04-27 | 1, 657FF | 459d |  |  |
| 659 | 3.11.1.4.3 | 电梯/ Elevators / Лифтови | 60d | 2022-11-14 | 2023-03-27 | 1, 661 | 739d |  |  |
| 660 | 3.11.1.4.4 | 排水工程/ Drainage works / Радови на дренажи | 60d | 2023-02-06 | 2023-04-21 | 666SS+15d | 720d |  | start no earlier than 2022-06-01 |
| 661 | 3.11.1.4.5 | 旅客通道/ Passenger underpass / Путнички потходник | 100d | 2022-07-19 | 2022-11-12 | 654SS+15d, 653SS+15d, 655SS+15d | 739d | 0d |  |
| 662 | 3.11.1.4.6 | 雨蓬/ Canopies / Надстрешнице | 150d | 2023-09-01 | 2024-04-27 | 786FS+5d | 399d | 0d |  |
| 663 | 3.11.1.4.7 | 站台/ Platforms / Перони | 110d | 2022-07-25 | 2022-11-30 | 654SS+15d, 653SS+15d, 655SS+15d, 661FF+15d | 784d |  |  |
| 664 | 3.11.1.4.8 | 接触网基础/ Overhead contact system foundations / Темељи контактне мреже | 30d | 2023-04-01 | 2023-05-11 | 666FF+30d | 515d | 0d | start no earlier than 2022-06-01 |
| 665 | 3.11.1.4.9 | 路基通信、信号过轨管/ Subgrade TK and SS pipes passing through track / ТК и СС продори доњег строја | 30d | 2023-02-06 | 2023-03-14 | 666SS+15d | 750d |  |  |
| 666 | 3.11.1.4.10 | 路基/ Subgrade / Доњи строј | 60d | 2022-11-18 | 2023-03-31 | 653, 654FS+89d, 655 | 261d | 0d |  |

| ID | WBS | Task | Type | Duration | Start | Finish | Predecessors | Total slack | Free slack | Constraint |
| --- | --- | --- | --- | --- | --- | --- | --- | --- | --- | --- |
| 667 | 3.11.2 | **电力电气化工程/Electric power Electrification Engineering/Elektrifikacija i elektroenergetski radoviElectric power Electrification Engineering / Elektrifikacija i elektroenergetski radovi** |  | 587d | 2023-03-22 | 2025-06-30 |  | 157d |  |  |
| 668 | 3.11.2.1 | 接触网立柱、腕臂安装/OCS pole and cantilever installation/Postavljanje stubova kontaktne mreže, montaža konzola |  | 70d | 2023-09-29 | 2024-02-22 | 664FS+120d | 515d |  |  |
| 669 | 3.11.2.2 | 接触网承导线架设/OCS catenary stretching/Razvlačenje kontaktne mreže |  | 35d | 2024-08-14 | 2024-09-23 | 1876 | 277d | 56d |  |
| 670 | 3.11.2.3 | 接触网悬挂精调/Fine adjustment of catenary suspension/Fina regulacija voznog voda |  | 60d | 2024-11-29 | 2025-04-10 | 1938, 669 | 221d |  |  |
| 671 | 3.11.2.4 | 热麻耶沃开闭所房建主体工程/Main building works of Zmajevo TSP/Strukturalni radovi na objektu PS Zmajevo |  | 212d | 2023-03-22 | 2023-11-30 |  | 157d | 0d | start no earlier than 2023-03-22 |
| 672 | 3.11.2.5 | 热麻耶沃开闭所房建装饰工程/Building decoration works of Zmajevo TSP/Dekoraterski radovi na objektu PS Zmajevo |  | 120d | 2024-02-21 | 2024-07-15 | 671 | 397d |  | finish no earlier than 2024-07-15 |
| 673 | 3.11.2.6 | 配电室改造/Transformation of distribution room/Rekonstrukcija distributivno transformatorske stanice |  | 32d | 2023-07-26 | 2023-08-31 | 657SF | 609d |  | finish no earlier than 2023-08-31 |
| 674 | 3.11.2.7 | 室内电气安装 /Indoor electrical installation/Unutrašnja elektroinstalacija |  | 240d | 2023-07-28 | 2024-07-12 | 657SS | 399d |  | start no earlier than 2023-03-09 |
| 675 | 3.11.2.8 | 车站照明设备安装/Installation of station lighting equipment /Montaža stanične rasvete |  | 90d | 2024-02-17 | 2024-06-06 |  | 430d |  | start no earlier than 2024-02-17 |
| 676 | 3.11.2.9 | 变电所亭设备安装/Installation of ETS equipment/Montaža opreme u EVP | manual | 375d | 2024-02-01 | 2025-06-30 | 671 |  |  | start no earlier than 2024-03-05 |
| 677 | 3.11.3 | **通信信号工程/Telecommunication and Signaling works / ТК и СС радови** |  | 594d | 2022-11-30 | 2025-05-21 |  | 191d |  |  |
| 678 | 3.11.3.1 | 房建工程/Construction & renovation for Equipment house / Радови изградње и реновирању зграда |  | 254d | 2022-11-30 | 2024-02-02 | 682SF-160d | 531d | 0d |  |
| 679 | 3.11.3.2 | **SS工程/ Signaling works/ СС радови** |  | 180d | 2024-08-15 | 2025-05-21 |  | 191d |  |  |
| 680 | 3.11.3.2.1 | 光电缆敷设/ Optical cable laying / Полагање оптичких каблова |  | 90d | 2024-08-15 | 2024-11-29 | 681SF | 281d | 0d |  |
| 681 | 3.11.3.2.2 | 轨旁设备安装/ Trackside equipment mounting / Уградња пружних уређаја |  | 60d | 2024-11-29 | 2025-04-10 | 1938 | 191d | 0d |  |
| 682 | 3.11.3.2.3 | 室内设备安装/ Indoor equipment mounting (at station) / Монтажа унутрашње опреме (у станици) |  | 90d | 2024-08-15 | 2024-11-29 | 680FF | 281d | 0d | start no earlier than 2022-10-08 |
| 683 | 3.11.3.2.4 | 信号设备调试/ Testing of the station SS equipment/ Тестирање станичне СС опреме |  | 60d | 2025-03-07 | 2025-05-21 | 681FS-30d | 191d |  |  |
| 684 | 3.11.3.3 | **TT工程/ Telecommunication works / ТТ радови** |  | 540d | 2023-04-06 | 2025-05-21 |  | 191d |  |  |
| 685 | 3.11.3.3.1 | 光电缆敷设/ Optical cable laying / Полагање оптичких каблова |  | 90d | 2024-08-15 | 2024-11-28 | 680SS | 281d |  |  |
| 686 | 3.11.3.3.2 | 综合布线/ Integrated cabling system / структурно каблирање |  | 90d | 2023-08-18 | 2024-02-02 | 678FF | 531d |  | start no earlier than 2022-09-08 |
| 687 | 3.11.3.3.3 | 站内通信信息设备安装/Installation of telecommunication and information equipment in the station / Уградња телекомуникационе и информационе опреме у станици |  | 90d | 2024-08-15 | 2024-11-29 | 682FF | 281d |  | finish no earlier than 2023-07-24 |
| 688 | 3.11.3.3.4 | 铁塔工程/Communication tower works/ Радови на ТК стубовима |  | 200d | 2023-04-06 | 2024-02-02 | 678FF | 531d |  | finish no earlier than 2023-07-24 |
| 689 | 3.11.3.3.5 | TK设备调试/ Testing of the station TK equipment/ Тестирање станичне TK опреме |  | 60d | 2025-03-07 | 2025-05-21 | 681FS-30d | 191d |  |  |
| 690 | 3.12 | **热麻耶沃站（Km102+514）~维尔巴斯站（Km113+610.13，不含）2023.11.10Zmajevo station ~ Vrbas station Станица Змајево~ ст. Врбас** |  | 757d | 2022-07-01 | 2025-06-30 |  | 157d |  |  |
| 691 | 3.12.1 | **土建工程/ Civil engineering works / Грађевински радови** |  | 596d | 2022-07-01 | 2024-10-15 |  | 170d |  |  |
| 692 | 3.12.1.1 | 既有轨道拆除/ Dismantling of existing track / Демонтажа постојећег колосека | milestone | 0d | 2022-07-01 | 2022-07-01 | 565 | 683d | 120d |  |

| ID | WBS | Task | Duration | Start | Finish | Predecessors | Total slack | Free slack | Constraint |
| --- | --- | --- | --- | --- | --- | --- | --- | --- | --- |
| 693 | 3.12.1.2 | **Km105+797.12公路上跨铁路立交桥/ Km105+797.12 bridge /Мост на Km105+797.12** | 476d | 2022-11-19 | 2024-10-15 |  | 318d |  |  |
| 694 | 3.12.1.2.1 | 征地及房屋拆迁，见附件Land expropriation and house dismantle, refer to Attachment / Експропријација земљишта и демонтажа куће, види Прилог | 30d | 2022-11-19 | 2023-02-25 | 692, 1FS+120d | 563d | 48d |  |
| 695 | 3.12.1.2.2 | 图纸批复Approval of drawings | 30d | 2022-11-19 | 2023-02-25 | 692, 1FS+120d | 563d | 48d |  |
| 696 | 3.12.1.2.3 | **桥梁施工Bridges** | 398d | 2023-04-27 | 2024-10-15 |  | 318d |  |  |
| 697 | 3.12.1.2.3.1 | 试桩/ Test pile / Пробни шип | 21d | 2023-04-27 | 2023-05-23 | 694, 695, 586FS+5d | 515d | 0d |  |
| 698 | 3.12.1.2.3.2 | 桩基施工/ Pile foundations construction / Извођење шипова | 20d | 2023-05-24 | 2023-06-15 | 697 | 515d | 197d |  |
| 699 | 3.12.1.2.3.3 | 承台施工/ Pile caps construction / Извођење наглавних греда | 45d | 2024-04-06 | 2024-06-03 | 698, 492 | 318d | 0d |  |
| 700 | 3.12.1.2.3.4 | 墩身施工/ Pier shafts construction / Извођење тела средњих стубова | 45d | 2024-05-17 | 2024-07-08 | 699SS+30d | 318d | 0d |  |
| 701 | 3.12.1.2.3.5 | 盖梁、桥台施工/ Pier caps, abutments construction / Извођење клупи за лежишта, крајњих стубова | 60d | 2024-06-21 | 2024-08-29 | 700SS+30d | 318d | 0d |  |
| 702 | 3.12.1.2.3.6 | 预制梁安装/ Precast beam installation / Монтажа префабриковане греде | 15d | 2024-08-30 | 2024-09-16 | 701 | 318d | 0d |  |
| 703 | 3.12.1.2.3.7 | 桥面系施工/ Bridge deck system construction / Извођење система коловозне плоче | 25d | 2024-09-17 | 2024-10-15 | 702 | 318d | 0d |  |
| 704 | 3.12.1.2.3.8 | **Km105+797.12铁路立交桥顺接地方公路Km105+797.12 railway overpass conncetion with local road Повезивање железничког надвожњака са локалним путем у Km105+797.12** | 40d | 2024-08-30 | 2024-10-15 |  | 318d |  |  |
| 705 | 3.12.1.2.3.8.1 | 路基施工（开挖、填筑）/ Subgrade construction (excavation, filling) / Радови на доњем строју (ископавање, насипање) | 20d | 2024-08-30 | 2024-09-21 | 701SS+60d | 318d | 0d |  |
| 706 | 3.12.1.2.3.8.2 | 路面施工（含标线）/ Pavement construction (including marking lines) / Извођење коловоза (укључујући ознаке) | 10d | 2024-09-23 | 2024-10-03 | 705 | 318d | 0d |  |
| 707 | 3.12.1.2.3.8.3 | 路灯、边坡腐殖土、水沟等附属工程施工/ Construction of auxiliary projects such as street lamps, slope topsoiling, ditches etc. / Извођење помоћних пројеката попут уличних лампи, хумузирања косина, јаркова, итд. | 10d | 2024-10-04 | 2024-10-15 | 706, 703FF | 318d |  |  |
| 708 | 3.12.1.3 | **Km108+115.69 公路上跨铁路立交桥/ Km108+115.69 bridge / Мост на Km108+115.69** | 232d | 2023-02-27 | 2024-01-03 |  | 532d |  |  |
| 709 | 3.12.1.3.1 | 征地及房屋拆迁，见附件Land expropriation and house dismantle, refer to Attachment / Експропријација земљишта и демонтажа куће, види Прилог | 30d | 2023-02-27 | 2023-04-01 | 1FS+150d | 545d | 42d |  |
| 710 | 3.12.1.3.2 | 图纸批复Approval of drawings | 30d | 2023-02-27 | 2023-04-01 | 1FS+150d | 545d | 42d |  |
| 711 | 3.12.1.3.3 | **桥梁施工Bridges** | 160d | 2023-05-27 | 2024-01-03 |  | 503d |  |  |
| 712 | 3.12.1.3.3.1 | 试桩/ Test pile / Пробни шип | 21d | 2023-05-27 | 2023-06-20 | 709, 710, 334FS+5d | 503d | 0d |  |
| 713 | 3.12.1.3.3.2 | 桩基施工/ Pile foundations construction / Извођење шипова | 20d | 2023-06-21 | 2023-07-13 | 712 | 503d | 0d |  |
| 714 | 3.12.1.3.3.3 | 承台施工/ Pile caps construction / Извођење наглавних греда | 45d | 2023-07-14 | 2023-09-04 | 713 | 503d | 0d | start no earlier than 2022-06-01 |
| 715 | 3.12.1.3.3.4 | 墩身施工/ Pier shafts construction / Извођење тела средњих стубова | 45d | 2023-08-07 | 2023-09-27 | 714SS+20d | 503d | 18d |  |
| 716 | 3.12.1.3.3.5 | 盖梁、桥台施工/ Pier caps, abutments construction / Извођење клупи за лежишта, крајњих стубова | 70ed | 2023-09-04 | 2023-11-13 | 715SS+25d | 2184d | 0d |  |
| 717 | 3.12.1.3.3.6 | 预制梁安装/ Precast beam installation / Монтажа префабриковане греде | 21ed | 2023-11-13 | 2023-12-04 | 716 | 2184d | 0d |  |
| 718 | 3.12.1.3.3.7 | 桥面系施工/ Bridge deck system construction / Извођење система коловозне плоче | 30ed | 2023-12-04 | 2024-01-03 | 717 | 2184d | 0d |  |

| ID | WBS | Task | Duration | Start | Finish | Predecessors | Total slack | Free slack | Constraint |
| --- | --- | --- | --- | --- | --- | --- | --- | --- | --- |
| 719 | 3.12.1.3.3.8 | **Km105+797.12铁路立交桥顺接地方公路Km105+797.12 railway overpass conncetion with local road Повезивање железничког надвожњака са локалним путем у Km105+797.12** | 15d | 2023-11-13 | 2024-01-03 |  | 504d |  |  |
| 720 | 3.12.1.3.3.8.1 | 路基施工（开挖、填筑）/ Subgrade construction (excavation, filling) / Радови на доњем строју (ископавање, насипање) | 20ed | 2023-11-13 | 2023-12-03 | 716 | 2187d | 0d |  |
| 721 | 3.12.1.3.3.8.2 | 路面施工（含标线）/ Pavement construction (including marking lines) / Извођење коловоза (укључујући ознаке) | 10ed | 2023-12-03 | 2023-12-13 | 720 | 2187d | 3d |  |
| 722 | 3.12.1.3.3.8.3 | 路灯、边坡腐殖土、水沟等附属工程施工/ Construction of auxiliary projects such as street lamps, slope topsoiling, ditches etc. / Извођење помоћних пројеката попут уличних лампи, хумузирања косина, јаркова, итд. | 20ed | 2023-12-14 | 2024-01-03 | 721, 718FF | 2184d |  |  |
| 723 | 3.12.1.4 | **Km110+351.21铁路跨河钢桁梁（Km110+319.55～Km110+382.55)/ Km110+351.21 bridge （Km110+319.55～Km110+382.55) / Мост на Km110+351.21（Km110+319.55～Km110+382.55)** | 377d | 2022-08-05 | 2024-03-02 |  | 140d |  |  |
| 724 | 3.12.1.4.1 | 征地及房屋拆迁，见附件Land expropriation and house dismantle, refer to Attachment / Експропријација земљишта и демонтажа куће, види Прилог | 30d | 2022-08-05 | 2022-09-08 | 1FS+30d | 205d | 65d |  |
| 725 | 3.12.1.4.2 | 图纸批复Approval of drawings | 30d | 2022-08-05 | 2022-09-08 | 1FS+30d | 140d | 0d |  |
| 726 | 3.12.1.4.3 | 管线迁改，见附件2Pipeline relocation, refer to Attachment 2 / Премештање цевовода, погледајте Прилог 2 | 30d | 2022-08-05 | 2022-09-08 | 1FS+30d | 205d | 65d |  |
| 727 | 3.12.1.4.4 | **桥梁施工Bridges** | 282d | 2022-11-25 | 2024-03-02 |  | 140d |  |  |
| 728 | 3.12.1.4.4.1 | 围堰筑岛，钢板桩施工Cofferdam island works, steel slab piles works Радови на загату острва, радови на челичним плочама шипа | 30d | 2022-11-25 | 2023-03-03 | 724, 725FS+65d, 726 | 140d | 0d | start no earlier than 2022-06-01 |
| 729 | 3.12.1.4.4.2 | 试桩/ Test pile / Пробни шип | 21ed | 2023-03-03 | 2023-03-24 | 728 | 511.88d | 0d |  |
| 730 | 3.12.1.4.4.3 | 桩基施工/ Pile foundations construction / Извођење шипова | 58ed | 2023-03-24 | 2023-05-21 | 729 | 511.88d | 1.88d |  |
| 731 | 3.12.1.4.4.4 | 承台施工/ Pile caps construction / Извођење наглавних греда | 40d | 2023-05-22 | 2023-07-06 | 730 | 146d | 0d | start no earlier than 2022-06-01 |
| 732 | 3.12.1.4.4.5 | 桥台施工Abutment works Радови на упорцу | 50d | 2023-07-07 | 2023-09-02 | 731 | 146d | 0d |  |
| 733 | 3.12.1.4.4.6 | 钢桁梁原位拼装In-situ assembly of steel truss beams Монтажа челичних решеткастих греда на лицу места | 90d | 2023-09-04 | 2024-02-20 | 732 | 146d | 0d |  |
| 734 | 3.12.1.4.4.7 | 桥面系施工/ Bridge deck system construction / Извођење система коловозне плоче | 10d | 2024-02-21 | 2024-03-02 | 733 | 146d | 60d |  |
| 735 | 3.12.1.5 | **涵洞culvert / Пропуст** | 253d | 2022-09-08 | 2023-09-09 |  | 239d | 154d |  |
| 736 | 3.12.1.5.1 | K103+602.05（4.00 × 3.00m）涵洞/culvert / пропуст | 90d | 2023-05-29 | 2023-09-09 | 739FS+5d | 240d | 0d |  |
| 737 | 3.12.1.5.2 | K105+031.01（2.00 × 2.50m）涵洞/culvert / пропуст | 90d | 2023-05-13 | 2023-08-25 | 738FS+5d | 253d | 13d |  |
| 738 | 3.12.1.5.3 | K105+065.01（2.00 × 2.50m）涵洞/culvert / пропуст | 90ed | 2023-02-06 | 2023-05-07 | 740FS+5d | 1099.88d | 1.88d |  |
| 739 | 3.12.1.5.4 | K110+122.59（2.00 × 2.50m）涵洞/culvert / пропуст | 90d | 2022-11-29 | 2023-05-22 | 741FS+5d | 240d | 0d |  |
| 740 | 3.12.1.5.5 | K111+253.01（2.00 × 2.50m）涵洞/culvert / пропуст | 75ed | 2022-09-26 | 2022-12-10 | 1FS+75d | 1255.88d | 169d |  |
| 741 | 3.12.1.5.6 | K111+807.38（2.00 × 2.50m）涵洞/culvert / пропуст | 75ed | 2022-09-08 | 2022-11-22 | 1FS+60d | 1051.88d | 1.88d |  |
| 742 | 3.12.1.6 | **路基/ Subgrade / Доњи строј** | 343d | 2022-07-01 | 2023-10-14 |  | 273d |  |  |
| 743 | 3.12.1.6.1 | 征地及房屋拆迁，见附件Land expropriation and house dismantle, refer to Attachment / Експропријација земљишта и демонтажа куће, види Прилог | 30d | 2022-07-01 | 2022-08-04 | 1 | 273d | 33d |  |
| 744 | 3.12.1.6.2 | 图纸和施工方案的批复Approval of drawings and method statements | 30d | 2022-07-01 | 2022-08-04 | 1 | 273d | 33d |  |
| 745 | 3.12.1.6.3 | 管线迁改，见附件2Pipeline relocation, refer to Attachment 2 / Премештање цевовода, погледајте Прилог 2 | 30d | 2022-07-01 | 2022-08-04 | 1 | 273d | 33d |  |

| ID | WBS | Task | Duration | Start | Finish | Predecessors | Total slack | Free slack | Constraint |
| --- | --- | --- | --- | --- | --- | --- | --- | --- | --- |
| 746 | 3.12.1.6.4 | **路基施工/ Subgrade construction / Радови на доњем строју** | 280d | 2022-09-13 | 2023-10-14 |  | 240d |  |  |
| 747 | 3.12.1.6.4.1 | 区间路基/ Open track subgrade / Доњи строј отворене пруге | 250d | 2022-09-13 | 2023-09-09 | 738FF, 736FF, 737FF, 739FF, 740FF, 741FF, 743, 744, 745 | 240d | 0d |  |
| 748 | 3.12.1.6.4.2 | 排水工程/ Drainage works / Радови на дренажи | 200d | 2022-11-10 | 2023-09-09 | 1, 747FF | 601d |  |  |
| 749 | 3.12.1.6.4.3 | 接触网基础/ Overhead contact system foundations / Темељи контактне мреже | 250d | 2022-10-18 | 2023-10-14 | 1, 747FF+30d | 296d | 0d |  |
| 750 | 3.12.1.6.4.4 | 路基通信、信号过轨管/ Subgrade TK and SS pipes passing through track / ТК и СС продори доњег строја | 200d | 2022-11-10 | 2023-09-09 | 1, 747FF | 601d |  |  |
| 751 | 3.12.1.6.4.5 | 热麻耶沃站牵引变电工程Zmajevo station traction substation project Пројакат тракцијске трафостанице станице Змајево | 60d | 2023-07-03 | 2023-09-09 | 747FF | 601d |  |  |
| 752 | 3.12.2 | **电力电气化工程/Electric power Electrification Engineering/Elektrifikacija i elektroenergetski radoviElectric power Electrification Engineering / Elektrifikacija i elektroenergetski radovi** | 696d | 2022-09-10 | 2025-06-30 |  | 157d |  |  |
| 753 | 3.12.2.1 | 接触网立柱、腕臂安装/OCS pole and cantilever installation/Postavljanje stubova kontaktne mreže, montaža konzola | 75d | 2023-10-16 | 2024-03-15 | 749 | 296d | 139d |  |
| 754 | 3.12.2.2 | 接触网承导线架设/OCS catenary stretching/Razvlačenje kontaktne mreže | 40d | 2024-08-14 | 2024-09-28 | 1876 | 272d | 51d |  |
| 755 | 3.12.2.3 | 接触网悬挂精调/Fine adjustment of catenary suspension/Fina regulacija voznog voda | 60d | 2024-11-29 | 2025-04-10 | 1938, 754 | 221d |  |  |
| 756 | 3.12.2.4 | 变电室外设备安装/Installation of outdoor equipment of Substation/Montaža spoljašnje opreme distributivno transformatorske stanice | 200d | 2024-08-31 | 2025-06-30 | 753 | 157d |  | finish no earlier than 2025-06-30 |
| 757 | 3.12.2.5 | 室内电气安装 /Indoor electrical installation/Unutrašnja elektroinstalacija | 69d | 2022-09-10 | 2022-11-30 |  | 784d |  | finish no earlier than 2022-11-30 |
| 758 | 3.12.2.6 | 电力迁改110kv/Electricity relocation 110kv/Izmeštanje kablova 110kV | 25d | 2023-11-01 | 2023-11-30 |  | 532d |  | finish no earlier than 2023-11-30 |
| 759 | 3.12.3 | **通信信号工程/Telecommunication and Signaling works / ТК и СС радови** | 592d | 2023-02-02 | 2025-05-21 |  | 191d |  |  |
| 760 | 3.12.3.1 | 房建工程/Construction & renovation for Equipment house / Радови изградње и реновирању зграда | 252d | 2023-02-02 | 2024-02-02 | 768SF-160d | 531d | 0d |  |
| 761 | 3.12.3.2 | **SS工程/ Signaling works/ СС радови** | 180d | 2024-08-15 | 2025-05-21 |  | 191d |  |  |
| 762 | 3.12.3.2.1 | 光电缆敷设/ Optical cable laying / Полагање оптичких каблова | 90d | 2024-08-15 | 2024-11-29 | 763SF | 281d | 0d | start no earlier than 2023-05-10 |
| 763 | 3.12.3.2.2 | 轨旁设备安装/ Trackside equipment mounting / Уградња пружних уређаја | 60d | 2024-11-29 | 2025-04-10 | 1938 | 191d | 0d |  |
| 764 | 3.12.3.2.3 | 信号设备调试/ Testing of the station SS equipment/ Тестирање станичне СС опреме | 60d | 2025-03-07 | 2025-05-21 | 763FS-30d | 191d |  |  |
| 765 | 3.12.3.3 | **TT工程/ Telecommunication works / ТТ радови** | 540d | 2023-04-06 | 2025-05-21 |  | 191d |  |  |
| 766 | 3.12.3.3.1 | 光电缆敷设/ Optical cable laying / Полагање оптичких каблова | 90d | 2024-08-15 | 2024-11-28 | 762SS | 281d | 0d |  |
| 767 | 3.12.3.3.2 | 轨旁设备安装/ Trackside equipment mounting / Уградња пружних уређаја | 60d | 2024-11-29 | 2025-04-10 | 763SS | 191d | 0d |  |
| 768 | 3.12.3.3.3 | 室内设备安装/ Indoor equipment mounting (at station) / Монтажа унутрашње опреме (у станици) | 90d | 2024-08-15 | 2024-11-28 | 766FF | 281d | 0d |  |
| 769 | 3.12.3.3.4 | 铁塔工程/Communication tower works/ Радови на ТК стубовима | 200d | 2023-04-06 | 2024-02-02 | 760FF | 531d |  |  |
| 770 | 3.12.3.3.5 | TK设备调试/ Testing of the station TK equipment/ Тестирање станичне TK опреме | 60d | 2025-03-07 | 2025-05-21 | 767FS-30d | 191d |  |  |

| ID | WBS | Task | Type | Duration | Start | Finish | Predecessors | Total slack | Free slack | Constraint |
| --- | --- | --- | --- | --- | --- | --- | --- | --- | --- | --- |
| 771 | 3.13 | **维尔巴斯站（Km113+610.13）Vrbas station（Km113+610.13） Станица Врбас （Km113+610.13）** |  | 810d | 2022-07-01 | 2025-08-30 |  | 104d |  |  |
| 772 | 3.13.1 | **土建工程/ Civil engineering works / Грађевински радови** |  | 375d | 2022-07-01 | 2023-11-22 |  | 184d |  |  |
| 773 | 3.13.1.1 | 征地及房屋拆迁，见附件Land expropriation and house dismantle, refer to Attachment / Експропријација земљишта и демонтажа куће, види Прилог |  | 90d | 2022-07-01 | 2022-10-13 | 1 | 277d | 0d |  |
| 774 | 3.13.1.2 | 图纸批复Approval of drawings |  | 90d | 2022-07-01 | 2022-10-13 | 1 | 277d | 0d |  |
| 775 | 3.13.1.3 | 管线迁改，见附件2Pipeline relocation, refer to Attachment 2 / Премештање цевовода, погледајте Прилог 2 |  | 90d | 2022-07-01 | 2022-10-13 | 1 | 217d | 0d |  |
| 776 | 3.13.1.4 | **车站施工Station** |  | 339d | 2022-08-12 | 2023-11-22 |  | 148d |  |  |
| 777 | 3.13.1.4.1 | 进站道路/ Access roads / Приступни путеви |  | 100d | 2023-06-01 | 2023-09-25 | 1, 773, 774, 775, 788FF | 588d |  |  |
| 778 | 3.13.1.4.2 | 房屋建筑/ Building construction / Високоградња |  | 225d | 2023-02-27 | 2023-11-22 | 1, 773, 774, 775FS+60d | 217d | 0d | start no earlier than 2022-07-01 |
| 779 | 3.13.1.4.3 | 车站标志/ Station signs / Знакови у станици |  | 60d | 2023-09-13 | 2023-11-22 | 1, 778FF | 539d |  |  |
| 780 | 3.13.1.4.4 | 电梯/ Elevators / Лифтови |  | 120d | 2023-07-05 | 2023-11-22 | 1, 778FF | 539d |  | start no earlier than 2022-06-01 |
| 781 | 3.13.1.4.5 | 消防设施/ Fire-fighting facilities / Противпожарни уређаји |  | 60d | 2023-09-13 | 2023-11-22 | 1, 778FF | 539d |  |  |
| 782 | 3.13.1.4.6 | 排水工程/ Drainage works / Радови на дренажи |  | 120d | 2022-08-30 | 2023-03-22 | 788SS+15d | 743d |  |  |
| 783 | 3.13.1.4.7 | 接触网基础/ Overhead contact system foundations / Темељи контактне мреже |  | 90d | 2023-06-13 | 2023-09-25 | 788FF | 528d | 0d |  |
| 784 | 3.13.1.4.8 | 路基通信、信号过轨管/ Subgrade TK and SS pipes passing through track / ТК и СС продори доњег строја |  | 60d | 2022-08-30 | 2022-11-07 | 788SS+15d | 803d |  |  |
| 785 | 3.13.1.4.9 | 旅客通道/ Passenger underpass / Путнички потходник |  | 150d | 2022-10-14 | 2023-06-16 | 1, 773, 774, 775 | 674d |  |  |
| 786 | 3.13.1.4.10 | 雨蓬/ Canopies / Надстрешнице |  | 210d | 2022-10-14 | 2023-08-25 | 1, 773, 774, 775, 787FF+30d | 399d | 0d | start no earlier than 2022-06-01 |
| 787 | 3.13.1.4.11 | 站台/ Platforms / Перони |  | 180d | 2022-10-14 | 2023-07-21 | 1, 773, 774, 775 | 399d | 0d |  |
| 788 | 3.13.1.4.12 | 路基/ Subgrade / Доњи строј |  | 290d | 2022-08-12 | 2023-09-25 | 850FF-30d | 148d | 0d | start no earlier than 2022-06-01 |
| 789 | 3.13.2 | **电力电气化工程/Electric power Electrification Engineering/Elektrifikacija i elektroenergetski radoviElectric power Electrification Engineering / Elektrifikacija i elektroenergetski radovi** |  | 751d | 2022-07-08 | 2025-06-30 |  | 157d |  |  |
| 790 | 3.13.2.1 | 接触网立柱、腕臂安装/OCS pole and cantilever installation/Postavljanje stubova kontaktne mreže, montaža konzola |  | 60d | 2023-09-26 | 2024-02-05 | 783 | 528d |  |  |
| 791 | 3.13.2.2 | 接触网承导线架设/OCS catenary stretching/Razvlačenje kontaktne mreže |  | 38d | 2024-08-14 | 2024-09-26 | 1876 | 311d | 154d |  |
| 792 | 3.13.2.3 | 接触网悬挂精调/Fine adjustment of catenary suspension/Fina regulacija voznog voda |  | 23d | 2025-06-04 | 2025-06-30 | 1939, 791 | 157d |  | finish no earlier than 2025-06-30 |
| 793 | 3.13.2.4 | 维尔巴斯变电所房建主体工程/Main building works of Vrbas ETS/Strukturalni radovi na objektu EVP Vrbas |  | 200d | 2023-04-05 | 2023-11-30 |  | 172d | 0d | finish no earlier than 2023-11-30 |
| 794 | 3.13.2.5 | 维尔巴斯变电所房建装饰工程/Vrbas ETS building decoration project/Dekoraterski radovi na objektu EVP Vrbas |  | 150d | 2024-02-01 | 2024-08-01 | 793 | 382d |  | finish no earlier than 2023-12-31 |
| 795 | 3.13.2.6 | 配电室改造/Transformation of distribution room/Rekonstrukcija distributivno transformatorske stanice |  | 32d | 2023-11-23 | 2024-03-02 | 778 | 507d |  | finish no earlier than 2023-08-30 |
| 796 | 3.13.2.7 | 室内电气安装 /Indoor electrical installation/Unutrašnja elektroinstalacija |  | 322d | 2023-11-23 | 2025-04-15 | 778 | 217d |  | finish no earlier than 2023-10-26 |
| 797 | 3.13.2.8 | 车站照明设备安装/Installation of station lighting equipment /Montaža stanične rasvete |  | 178d | 2022-07-08 | 2023-04-06 |  | 730d |  | finish no earlier than 2023-04-06 |
| 798 | 3.13.2.9 | 变电所亭设备安装/Installation of ETS equipment/Montaža opreme u EVP | manual | 360d | 2024-02-01 | 2025-06-12 | 793 |  |  | finish no earlier than 2024-12-24 |

| ID | WBS | Task | Duration | Start | Finish | Predecessors | Total slack | Free slack | Constraint |
| --- | --- | --- | --- | --- | --- | --- | --- | --- | --- |
| 799 | 3.13.3 | **通信信号工程/Telecommunication and Signaling works / ТК и СС радови** | 672d | 2023-02-10 | 2025-08-30 |  | 104d |  |  |
| 800 | 3.13.3.1 | 房建工程/Construction & renovation for Equipment house / Радови изградње и реновирању зграда | 280d | 2023-02-10 | 2024-03-16 | 804SF-220d | 496d | 0d |  |
| 801 | 3.13.3.2 | **SS工程/ Signaling works/ СС радови** | 172d | 2025-02-05 | 2025-08-30 |  | 83d |  |  |
| 802 | 3.13.3.2.1 | 光电缆敷设/ Optical cable laying / Полагање оптичких каблова | 90d | 2025-02-05 | 2025-05-28 | 803SF | 83d | 0d |  |
| 803 | 3.13.3.2.2 | 轨旁设备安装/ Trackside equipment mounting / Уградња пружних уређаја | 60ed | 2025-05-28 | 2025-07-27 | 1939FS-6d | 109.12d | 0d |  |
| 804 | 3.13.3.2.3 | 室内设备安装/ Indoor equipment mounting (at station) / Монтажа унутрашње опреме (у станици) | 90d | 2025-02-05 | 2025-05-28 | 802FF | 83d | 0d |  |
| 805 | 3.13.3.2.4 | 信号设备调试/ Testing of the station SS equipment/ Тестирање станичне СС опреме | 60d | 2025-06-23 | 2025-08-30 | 803FS-30d | 104d |  |  |
| 806 | 3.13.3.3 | **TT工程/ Telecommunication works / ТТ радови** | 592d | 2023-05-23 | 2025-08-30 |  | 104d |  |  |
| 807 | 3.13.3.3.1 | 光电缆敷设/ Optical cable laying / Полагање оптичких каблова | 90d | 2025-02-05 | 2025-05-27 | 802SS | 186d |  |  |
| 808 | 3.13.3.3.2 | 综合布线/ Integrated cabling system / структурно каблирање | 90d | 2023-09-28 | 2024-03-16 | 800FF | 496d |  | start no earlier than 2022-09-08 |
| 809 | 3.13.3.3.3 | 站内通信信息设备安装/Installation of telecommunication and information equipment in the station / Уградња телекомуникационе и информационе опреме у станици | 150d | 2025-02-05 | 2025-08-05 | 802SS | 126d |  | finish no earlier than 2023-07-24 |
| 810 | 3.13.3.3.4 | 铁塔工程/Communication tower works/ Радови на ТК стубовима | 200d | 2023-05-23 | 2024-03-16 | 800FF | 496d |  | finish no earlier than 2023-07-24 |
| 811 | 3.13.3.3.5 | TK设备调试/ Testing of the station TK equipment/ Тестирање станичне TK опреме | 60d | 2025-06-23 | 2025-08-30 | 803FS-30d | 104d |  |  |
| 812 | 3.14 | **维尔巴斯站（Km113+610.13）—罗沃彻纳茨(不含)Vrbas station（Km113+610.13）—Lovćenac (not included) станица Врбас（Km113+610.13）—Ловћенац(није укључено)** | 810d | 2022-07-01 | 2025-08-30 |  | 104d |  |  |
| 813 | 3.14.1 | **土建工程/ Civil engineering works / Грађевински радови** | 398d | 2022-07-01 | 2024-02-21 |  | 148d |  |  |
| 814 | 3.14.1.1 | **维尔巴斯站（Km113+610.13）~Km115+000 2023.11.10Vrbas station（Km113+610.13）~Km115+000 2023.11.10 станица Врбас（Km113+610.13）~Km115+000 2023.11.1** | 386d | 2022-07-01 | 2024-02-05 |  | 148d |  |  |
| 815 | 3.14.1.1.1 | **km113+327.64框架箱涵km113+327.64 frame box culvert km113+327.64 сандучасти пропуст оквира** | 294d | 2022-07-01 | 2023-08-18 |  | 259d |  |  |
| 816 | 3.14.1.1.1.1 | 征地及房屋拆迁，见附件Land expropriation and house dismantle, refer to Attachment / Експропријација земљишта и демонтажа куће, види Прилог | 43d | 2022-07-01 | 2022-08-19 | 1 | 299d | 39d |  |
| 817 | 3.14.1.1.1.2 | 图纸批复Approval of drawings | 43d | 2022-07-01 | 2022-08-19 | 1 | 299d | 39d |  |
| 818 | 3.14.1.1.1.3 | 管线迁改，见附件2Pipeline relocation, refer to Attachment 2 / Премештање цевовода, погледајте Прилог 2 | 43d | 2022-07-01 | 2022-08-19 | 1 | 260d | 0d |  |
| 819 | 3.14.1.1.1.4 | 交通导改完毕，道路封闭 | 39d | 2022-08-20 | 2022-10-04 | 818 | 260d | 0d |  |
| 820 | 3.14.1.1.1.5 | **桥梁施工Bridges** | 212d | 2022-10-05 | 2023-08-18 | 819 | 259d |  |  |
| 821 | 3.14.1.1.1.5.1 | 钢板桩施工/ Sheet piling construction / Подграђивање талпама | 15d | 2022-10-05 | 2022-10-21 | 816, 817, 818 | 260d | 0d |  |
| 822 | 3.14.1.1.1.5.2 | 基坑开挖基坑开挖 Foundation pit excavation ископ темељне јаме | 15ed | 2022-10-21 | 2022-11-05 | 821 | 1126.88d | 0d |  |
| 823 | 3.14.1.1.1.5.3 | 垫层施工垫层施工 Cushion course works Радови на изравнавајућем слоју | 5ed | 2022-11-05 | 2022-11-10 | 822 | 1126.88d | 0d |  |
| 824 | 3.14.1.1.1.5.4 | 底板施工底板施工 Base plate works Радови на лежишнојплочи | 51ed | 2022-11-10 | 2022-12-31 | 823 | 1126.88d | 4.88d |  |
| 825 | 3.14.1.1.1.5.5 | 涵身板墙施工涵身板墙施工 Culvert body slab wall works Радови на плочама зидова тела пропуста | 45d | 2022-11-30 | 2023-03-25 | 824SS+15d | 259d | 0d |  |
| 826 | 3.14.1.1.1.5.6 | 顶板施工/ RC slab construction / Извођење АБ плоче | 60d | 2023-03-27 | 2023-06-09 | 825 | 259d | 0d |  |
| 827 | 3.14.1.1.1.5.7 | 结构附属施工(连接层，混凝土找坡层、护栏安装、混凝土保护层施工，两侧挡墙)Structure auxiliary construction (connection layer, concrete leveling layer, protective fence installation, concrete protective layer works, barricades on both sides) Помоћна конструкција објеката (повезивајући слој, | 60d | 2023-06-10 | 2023-08-18 | 826 | 259d | 0d |  |

| ID | WBS | Task | Duration | Start | Finish | Predecessors | Total slack | Free slack | Constraint |
| --- | --- | --- | --- | --- | --- | --- | --- | --- | --- |
| 828 | 3.14.1.1.1.5.8 | **km113+327.64铁路框架箱涵顺接地方公路Km113+327.64 railway frame box culverts connection to local road Повезивање оквира сандучастог пропуста железнице са локалним путем у Km113+327.64** | 75d | 2023-05-24 | 2023-08-18 |  | 259d | 173d |  |
| 829 | 3.14.1.1.1.5.8.1 | 路基施工（开挖、填筑）/ Subgrade construction (excavation, filling) / Радови на доњем строју (ископавање, насипање) | 25d | 2023-05-24 | 2023-06-21 | 826SS+45d | 269d | 0d |  |
| 830 | 3.14.1.1.1.5.8.2 | 路面施工（含标线）/ Pavement construction (including marking lines) / Извођење коловоза (укључујући ознаке) | 20d | 2023-06-22 | 2023-07-14 | 829 | 269d | 10d |  |
| 831 | 3.14.1.1.1.5.8.3 | 路灯、边坡腐殖土、水沟等附属工程施工/ Construction of auxiliary projects such as street lamps, slope topsoiling, ditches etc. / Извођење помоћних пројеката попут уличних лампи, хумузирања косина, јаркова, итд. | 20d | 2023-07-27 | 2023-08-18 | 830, 827FF | 259d |  |  |
| 832 | 3.14.1.1.2 | **km114+716.45空间刚构桥/Km114+716.45 gallery/ Галерија на Km114+716.45** | 320d | 2022-09-01 | 2023-11-20 |  | 180d |  |  |
| 833 | 3.14.1.1.2.1 | 征地及房屋拆迁，见附件Land expropriation and house dismantle, refer to Attachment / Експропријација земљишта и демонтажа куће, види Прилог | 29d | 2022-09-01 | 2022-10-04 |  | 180d | 0d | start no earlier than 2022-09-01 |
| 834 | 3.14.1.1.2.2 | 图纸批复Approval of drawings | 25d | 2022-09-01 | 2022-09-29 |  | 184d | 4d | start no earlier than 2022-09-01 |
| 835 | 3.14.1.1.2.3 | **桥梁施工Bridges** | 291d | 2022-10-05 | 2023-11-20 |  | 180d |  |  |
| 836 | 3.14.1.1.2.3.1 | 试桩/ Test pile / Пробни шип | 21d | 2022-10-05 | 2022-10-28 | 833, 834 | 180d | 0d |  |
| 837 | 3.14.1.1.2.3.2 | 桩基施工/ Pile foundations construction / Извођење шипова | 70d | 2022-10-29 | 2023-03-24 | 836 | 180d | 27d |  |
| 838 | 3.14.1.1.2.3.3 | 基础施工（承台/条基）Foundation construction (cap/strip foundation) Конструкција темеља (глава/издужени темељ) | 62ed | 2023-02-03 | 2023-04-06 | 837SS+30d | 658.88d | 1.88d |  |
| 839 | 3.14.1.1.2.3.4 | 墙身、墩柱Wall body, pier stud Тело зида, средњи стуб | 90d | 2023-03-14 | 2023-07-01 | 838SS+30d | 180d | 0d | start no earlier than 2022-06-01 |
| 840 | 3.14.1.1.2.3.5 | 现浇顶板Cast in situ top slab Бетонирање горње плоче на лицу места | 75d | 2023-07-03 | 2023-09-27 | 839 | 180d | 0d |  |
| 841 | 3.14.1.1.2.3.6 | 桥梁附属（防水、护栏及电缆槽等）Bridge related (waterproof, protective fence and cable though, etc) Везано за мост (хидроизолација, заштитна ограда и кабловска каналица) | 45d | 2023-09-28 | 2023-11-20 | 840 | 180d | 94d |  |
| 842 | 3.14.1.1.3 | **涵洞culvert / Пропуст** | 70d | 2022-09-08 | 2023-01-11 |  | 371d | 337d |  |
| 843 | 3.14.1.1.3.1 | K113+547.78（4.00 × 3.00m）涵洞/culvert / пропуст | 90ed | 2022-10-13 | 2023-01-11 | 844SS+30d | 1780.88d |  | start no earlier than 2022-10-12 |
| 844 | 3.14.1.1.3.2 | K114+579.38（4.00 × 3.00m）涵洞/culvert / пропуст | 90ed | 2022-09-08 | 2022-12-07 | 1FS+60d | 1710d | 75d |  |
| 845 | 3.14.1.1.4 | **路基/ Subgrade / Доњи строј** | 386d | 2022-07-01 | 2024-02-05 |  | 148d |  |  |
| 846 | 3.14.1.1.4.1 | 征地及房屋拆迁，见附件Land expropriation and house dismantle, refer to Attachment / Експропријација земљишта и демонтажа куће, види Прилог | 79d | 2022-07-01 | 2022-09-30 | 1 | 148d | 0d |  |
| 847 | 3.14.1.1.4.2 | 图纸批复Approval of drawings | 40d | 2022-07-01 | 2022-08-16 | 1 | 187d | 39d |  |
| 848 | 3.14.1.1.4.3 | 管线迁改，见附件2Pipeline relocation, refer to Attachment 2 / Премештање цевовода, погледајте Прилог 2 | 79d | 2022-07-01 | 2022-09-30 | 1 | 148d | 0d |  |
| 849 | 3.14.1.1.4.4 | **路基施工/ Subgrade construction / Радови на доњем строју** | 307d | 2022-10-01 | 2024-02-05 |  | 148d |  |  |
| 850 | 3.14.1.1.4.4.1 | 区间路基/ Open track subgrade / Доњи строј отворене пруге | 277d | 2022-10-01 | 2023-10-30 | 846, 847, 848, 844FF | 148d | 0d |  |
| 851 | 3.14.1.1.4.4.2 | 排水工程/ Drainage works / Радови на дренажи | 60d | 2023-08-22 | 2023-10-30 | 850FF | 558d |  |  |
| 852 | 3.14.1.1.4.4.3 | 接触网基础/ Overhead contact system foundations / Темељи контактне мреже | 70d | 2023-09-14 | 2024-02-05 | 850FF+30d | 528d |  |  |
| 853 | 3.14.1.1.4.4.4 | 路基通信、信号过轨管/ Subgrade TK and SS pipes passing through track / ТК и СС продори доњег строја | 35d | 2022-10-13 | 2022-11-23 | 850SS+10d | 790d |  |  |
| 854 | 3.14.1.1.4.4.5 | 维尔巴斯站牵引变电工程Vrbas station traction substation project Пројакат тракцијске трафостанице станице Врбас | 24d | 2023-10-03 | 2023-10-30 | 850FF | 558d |  |  |

| ID | WBS | Task | Duration | Start | Finish | Predecessors | Total slack | Free slack | Constraint |
| --- | --- | --- | --- | --- | --- | --- | --- | --- | --- |
| 855 | 3.14.1.2 | **Km115+000~Km122+500** | 359d | 2022-07-28 | 2023-11-30 |  | 290d |  |  |
| 856 | 3.14.1.2.1 | **km118+708.31公路下穿通道桥Km118+708.31 road passing under the bridge Km118+708.31 цеста која пролази испод моста** | 195d | 2022-08-05 | 2023-05-30 |  | 425d |  |  |
| 857 | 3.14.1.2.1.1 | 征地，见附件Land expropriation, refer to Attachment / Експропријација земљишта, погледајте Прилог | 30d | 2022-08-05 | 2022-09-08 | 1FS+30d | 425d | 7d |  |
| 858 | 3.14.1.2.1.2 | 图纸批复Approval of drawings | 30d | 2022-08-05 | 2022-09-08 | 1FS+30d | 425d | 7d |  |
| 859 | 3.14.1.2.1.3 | **桥梁施工Bridges** | 156d | 2022-09-19 | 2023-05-30 |  | 425d |  |  |
| 860 | 3.14.1.2.1.3.1 | 钢板桩施工/ Sheet piling construction / Подграђивање талпама | 30ed | 2022-09-19 | 2022-10-19 | 857FS+9d, 858FS+9d | 1915.88d | 0d |  |
| 861 | 3.14.1.2.1.3.2 | 基坑开挖 Foundation pit excavation ископ темељне јаме | 15ed | 2022-10-19 | 2022-11-03 | 860 | 1915.88d | 1.88d |  |
| 862 | 3.14.1.2.1.3.3 | 垫层施工垫层施工 Cushion course works Радови на изравнавајућем слоју | 5d | 2022-11-04 | 2022-11-09 | 861 | 425d | 0d | start no earlier than 2022-06-01 |
| 863 | 3.14.1.2.1.3.4 | 底板施工 Base plate works Радови на лежишнојплочи | 15ed | 2022-11-09 | 2022-11-24 | 862 | 1915.88d | 0d |  |
| 864 | 3.14.1.2.1.3.5 | 涵身施工Culvert body slab wall works Радови на плочама зидова тела пропуста | 26ed | 2022-11-24 | 2022-12-20 | 863 | 1915.88d | 0d |  |
| 865 | 3.14.1.2.1.3.6 | 顶板施工/ RC slab construction / Извођење АБ плоче | 46ed | 2022-12-20 | 2023-02-04 | 864 | 1915.88d | 4.88d |  |
| 866 | 3.14.1.2.1.3.7 | 结构附属施工(连接层，混凝土找坡层、护栏安装、混凝土保护层施工，两侧挡墙)Structure auxiliary construction (connection layer, concrete leveling layer, protective fence installation, concrete protective layer works, barricades on both sides) Помоћна конструкција објеката (повезивајући слој, | 60d | 2023-02-06 | 2023-04-21 | 865 | 478d | 31d |  |
| 867 | 3.14.1.2.1.3.8 | **km118+708.31铁路立交桥顺接地方公路Km118+708.31 railway overpass conncetion with local road Повезивање железничког надвожњака са локалним путем у Km118+708.31** | 65d | 2023-03-10 | 2023-05-30 |  | 447d |  |  |
| 868 | 3.14.1.2.1.3.8.1 | 路基施工（开挖、填筑）/ Subgrade construction (excavation, filling) / Радови на доњем строју (ископавање, насипање) | 25d | 2023-03-10 | 2023-04-07 | 865SS+30d | 447d | 0d |  |
| 869 | 3.14.1.2.1.3.8.2 | 路面施工（含标线）/ Pavement construction (including marking lines) / Извођење коловоза (укључујући ознаке) | 20d | 2023-04-08 | 2023-05-06 | 868 | 447d | 0d |  |
| 870 | 3.14.1.2.1.3.8.3 | 路灯、边坡腐殖土、水沟等附属工程施工/ Construction of auxiliary projects such as street lamps, slope topsoiling, ditches etc. / Извођење помоћних пројеката попут уличних лампи, хумузирања косина, јаркова, итд. | 20d | 2023-05-08 | 2023-05-30 | 869, 866FF | 447d | 157d |  |
| 871 | 3.14.1.2.2 | **km120+571.30公路上跨铁路桥Km120+571.30 highway crossing railway bridge Мост железничког прелаза преко цесте у Km120+571.30** | 241d | 2022-08-27 | 2023-08-14 |  | 349d |  |  |
| 872 | 3.14.1.2.2.1 | 征地，见附件Land expropriation, refer to Attachment / Експропријација земљишта, погледајте Прилог | 70d | 2022-08-27 | 2022-11-17 | 1FS+49d | 349d | 0d |  |
| 873 | 3.14.1.2.2.2 | 图纸批复Approval of drawings | 70d | 2022-08-27 | 2022-11-17 | 1FS+49d | 349d | 0d |  |
| 874 | 3.14.1.2.2.3 | 管线迁改，见附件2Pipeline relocation, refer to Attachment 2 / Премештање цевовода, погледајте Прилог 2 | 70d | 2022-08-27 | 2022-11-17 | 1FS+49d | 349d | 0d |  |
| 875 | 3.14.1.2.2.4 | **桥梁施工Bridges** | 171d | 2022-11-17 | 2023-08-14 |  | 349d |  |  |
| 876 | 3.14.1.2.2.4.1 | 试桩/ Test pile / Пробни шип | 21ed | 2022-11-17 | 2022-12-08 | 872, 873, 874 | 1648.88d | 0d |  |
| 877 | 3.14.1.2.2.4.2 | 桩基施工/ Pile foundations construction / Извођење шипова | 30ed | 2022-12-08 | 2023-01-07 | 876 | 1648.88d | 73.88d |  |
| 878 | 3.14.1.2.2.4.3 | 承台施工/ Pile caps construction / Извођење наглавних греда | 60d | 2023-02-01 | 2023-04-13 | 877 | 382d | 0d |  |
| 879 | 3.14.1.2.2.4.4 | 墩柱施工/ Piers construction / Извођење средњих стубова | 60d | 2023-02-21 | 2023-05-06 | 878SS+15d | 382d | 0d | start no earlier than 2022-06-01 |
| 880 | 3.14.1.2.2.4.5 | 盖梁施工Bent cap works Радови на лежишној греди | 80d | 2023-03-10 | 2023-06-16 | 879SS+15d | 382d | 0d |  |
| 881 | 3.14.1.2.2.4.6 | 梁体架设Beam body erection Постављање тела греде | 15d | 2023-06-17 | 2023-07-04 | 880 | 382d | 0d |  |
| 882 | 3.14.1.2.2.4.7 | 桥面系施工/ Bridge deck system construction / Извођење система коловозне плоче | 35d | 2023-07-05 | 2023-08-14 | 881 | 382d | 0d |  |

| ID | WBS | Task | Duration | Start | Finish | Predecessors | Total slack | Free slack | Constraint |
| --- | --- | --- | --- | --- | --- | --- | --- | --- | --- |
| 883 | 3.14.1.2.2.4.8 | **km120+571.30铁路立交桥顺接地方公路km120+571.30 railway overpass conncetion with local road Повезивање железничког надвожњака са локалним путем у km120+571.30** | 50d | 2023-06-17 | 2023-08-14 |  | 382d |  |  |
| 884 | 3.14.1.2.2.4.8.1 | 路基施工（开挖、填筑）/ Subgrade construction (excavation, filling) / Радови на доњем строју (ископавање, насипање) | 25d | 2023-06-17 | 2023-07-15 | 880 | 382d | 0d |  |
| 885 | 3.14.1.2.2.4.8.2 | 路面施工（含标线）/ Pavement construction (including marking lines) / Извођење коловоза (укључујући ознаке) | 10d | 2023-07-17 | 2023-07-27 | 884 | 382d | 0d |  |
| 886 | 3.14.1.2.2.4.8.3 | 路灯、边坡腐殖土、水沟等附属工程施工/ Construction of auxiliary projects such as street lamps, slope topsoiling, ditches etc. / Извођење помоћних пројеката попут уличних лампи, хумузирања косина, јаркова, итд. | 15d | 2023-07-28 | 2023-08-14 | 885, 882FF | 382d | 92d |  |
| 887 | 3.14.1.2.3 | **路基施工/ Subgrade construction / Радови на доњем строју** | 359d | 2022-07-28 | 2023-11-30 |  | 290d |  |  |
| 888 | 3.14.1.2.3.1 | 征地及房屋拆迁，见附件Land expropriation and house dismantle, refer to Attachment / Експропријација земљишта и демонтажа куће, види Прилог | 30d | 2022-07-28 | 2022-08-31 | 1FS+23d | 290d | 0d |  |
| 889 | 3.14.1.2.3.2 | 图纸批复Approval of drawings | 30d | 2022-07-28 | 2022-08-31 | 1FS+23d | 290d | 0d |  |
| 890 | 3.14.1.2.3.3 | 管线迁改，见附件2Pipeline relocation, refer to Attachment 2 / Премештање цевовода, погледајте Прилог 2 | 30d | 2022-07-28 | 2022-08-31 | 1FS+23d | 290d | 0d |  |
| 891 | 3.14.1.2.3.4 | **路基施工/ Subgrade construction / Радови на доњем строју** | 329d | 2022-09-01 | 2023-11-30 |  | 290d |  |  |
| 892 | 3.14.1.2.3.4.1 | 区间路基/ Open track subgrade / Доњи строј отворене пруге | 329d | 2022-09-01 | 2023-11-30 | 886FF, 870FF, 888, 889, 890 | 290d | 0d |  |
| 893 | 3.14.1.2.3.4.2 | 排水工程/ Drainage works / Радови на дренажи | 200d | 2023-04-05 | 2023-11-30 | 1, 892FF | 532d |  | start no earlier than 2022-07-01 |
| 894 | 3.14.1.2.3.4.3 | 接触网基础/ Overhead contact system foundations / Темељи контактне мреже | 260d | 2022-11-22 | 2023-11-30 | 1, 892FF | 532d |  | finish no earlier than 2022-07-01 |
| 895 | 3.14.1.2.3.4.4 | 路基通信、信号过轨管/ Subgrade TK and SS pipes passing through track / ТК и СС продори доњег строја | 120d | 2022-11-10 | 2023-06-08 | 892SF+180d | 681d |  | start no earlier than 2022-07-01 |
| 896 | 3.14.1.3 | **Km122+500~新罗沃彻纳茨站（Km129+523，不含） 2023.12.10Km122+500~new station Lovćenac（Km129+523 not included） 2023.12.10 Km122+500~нова станица Ловћенац（без Km129+523）** | 398d | 2022-07-01 | 2024-02-21 |  | 278d |  |  |
| 897 | 3.14.1.3.1 | 既有轨道拆除/ Dismantling of existing track / Демонтажа постојећег колосека | 5d | 2022-07-01 | 2022-07-06 | 1 | 303d | 25d |  |
| 898 | 3.14.1.3.2 | **km125+191.62公路上跨铁路桥Km125+191.62 highway crossing railway bridge Мост железничког прелаза преко цесте у Km125+191.62** | 253d | 2022-11-19 | 2023-11-20 |  | 535d |  |  |
| 899 | 3.14.1.3.2.1 | 征地及房屋拆迁，见附件Land expropriation and house dismantle, refer to Attachment / Експропријација земљишта и демонтажа куће, види Прилог | 60d | 2022-11-19 | 2023-04-01 | 1FS+120d | 535d | 0d |  |
| 900 | 3.14.1.3.2.2 | 图纸批复Approval of drawings | 60d | 2022-11-19 | 2023-04-01 | 1FS+120d | 535d | 0d |  |
| 901 | 3.14.1.3.2.3 | **桥梁施工Bridges** | 193d | 2023-04-01 | 2023-11-20 |  | 535d |  |  |
| 902 | 3.14.1.3.2.3.1 | 试桩/ Test pile / Пробни шип | 21ed | 2023-04-01 | 2023-04-22 | 899, 900, 897 | 2317.88d | 0d |  |
| 903 | 3.14.1.3.2.3.2 | 桩基施工/ Pile foundations construction / Извођење шипова | 30ed | 2023-04-22 | 2023-05-22 | 902 | 2317.88d | 0d |  |
| 904 | 3.14.1.3.2.3.3 | 承台施工/ Pile caps construction / Извођење наглавних греда | 45ed | 2023-05-22 | 2023-07-06 | 903 | 2317.88d | 62d |  |
| 905 | 3.14.1.3.2.3.4 | 墩柱施工/ Piers construction / Извођење средњих стубова | 45ed | 2023-06-20 | 2023-08-04 | 904SS+25d | 2317.88d | 75d | start no earlier than 2022-06-01 |
| 906 | 3.14.1.3.2.3.5 | 盖梁施工Bent cap works Радови на лежишној греди | 60ed | 2023-07-25 | 2023-09-23 | 905SS+30d | 2317.88d | 4.88d |  |
| 907 | 3.14.1.3.2.3.6 | 预制梁安装/ Precast beam installation / Монтажа префабриковане греде | 15d | 2023-09-25 | 2023-10-11 | 906 | 549d | 0d |  |
| 908 | 3.14.1.3.2.3.7 | 桥面系施工/ Bridge deck system construction / Извођење система коловозне плоче | 25d | 2023-10-12 | 2023-11-09 | 907 | 549d | 8d |  |

| ID | WBS | Task | Duration | Start | Finish | Predecessors | Total slack | Free slack | Constraint |
| --- | --- | --- | --- | --- | --- | --- | --- | --- | --- |
| 909 | 3.14.1.3.2.3.8 | **km125+191.62铁路立交桥顺接地方公路Km125+191.62 railway overpass conncetion with local road Повезивање железничког надвожњака са локалним путем у Km125+191.62** | 55d | 2023-09-15 | 2023-11-20 |  | 541d |  |  |
| 910 | 3.14.1.3.2.3.8.1 | 路基施工（开挖、填筑）/ Subgrade construction (excavation, filling) / Радови на доњем строју (ископавање, насипање) | 30ed | 2023-09-15 | 2023-10-15 | 906SS+45d | 2320.88d | 1.88d |  |
| 911 | 3.14.1.3.2.3.8.2 | 路面施工（含标线）/ Pavement construction (including marking lines) / Извођење коловоза (укључујући ознаке) | 15d | 2023-10-16 | 2023-11-01 | 910 | 541d | 0d |  |
| 912 | 3.14.1.3.2.3.8.3 | 路灯、边坡腐殖土、水沟等附属工程施工/ Construction of auxiliary projects such as street lamps, slope topsoiling, ditches etc. / Извођење помоћних пројеката попут уличних лампи, хумузирања косина, јаркова, итд. | 15d | 2023-11-02 | 2023-11-20 | 911, 908FF | 541d |  |  |
| 913 | 3.14.1.3.3 | **km126+976.11公路上跨铁路桥Km126+976.11 highway crossing railway bridge Мост железничког прелаза преко цесте у Km126+976.11** | 278d | 2022-11-19 | 2024-02-21 |  | 515d |  |  |
| 914 | 3.14.1.3.3.1 | 征地，见附件Land expropriation, refer to Attachment / Експропријација земљишта, погледајте Прилог | 60d | 2022-11-19 | 2023-04-01 | 1FS+120d | 515d | 0d |  |
| 915 | 3.14.1.3.3.2 | 图纸批复Approval of drawings | 60d | 2022-11-19 | 2023-04-01 | 1FS+120d | 515d | 0d |  |
| 916 | 3.14.1.3.3.3 | **桥梁施工Bridges** | 218d | 2023-04-01 | 2024-02-21 |  | 515d |  |  |
| 917 | 3.14.1.3.3.3.1 | 试桩/ Test pile / Пробни шип | 21ed | 2023-04-01 | 2023-04-22 | 914, 915, 897 | 2230.88d | 0d |  |
| 918 | 3.14.1.3.3.3.2 | 桩基施工/ Pile foundations construction / Извођење шипова | 30ed | 2023-04-22 | 2023-05-22 | 917 | 2230.88d | 1.88d |  |
| 919 | 3.14.1.3.3.3.3 | 承台施工/ Pile caps construction / Извођење наглавних греда | 45d | 2023-05-23 | 2023-07-13 | 918 | 516d | 0d |  |
| 920 | 3.14.1.3.3.3.4 | 墩柱施工/ Piers construction / Извођење средњих стубова | 45d | 2023-06-27 | 2023-08-17 | 919SS+30d | 516d | 0d |  |
| 921 | 3.14.1.3.3.3.5 | 盖梁施工Bent cap works Радови на лежишној греди | 60d | 2023-08-01 | 2023-10-09 | 920SS+30d | 516d | 0d | start no earlier than 2022-06-01 |
| 922 | 3.14.1.3.3.3.6 | 梁体架设Beam body erection Постављање тела греде | 15d | 2023-10-10 | 2023-10-26 | 921 | 536d | 0d |  |
| 923 | 3.14.1.3.3.3.7 | 桥面系施工/ Bridge deck system construction / Извођење система коловозне плоче | 25d | 2023-10-27 | 2023-11-25 | 922 | 536d | 20d |  |
| 924 | 3.14.1.3.3.3.8 | **km126+976.11铁路立交桥顺接地方公路Km126+976.11railway overpass conncetion with local road Повезивање железничког надвожњака са локалним путем у Km126+976.11** | 75d | 2023-09-22 | 2024-02-21 |  | 516d |  |  |
| 925 | 3.14.1.3.3.3.8.1 | 路基施工（开挖、填筑）/ Subgrade construction (excavation, filling) / Радови на доњем строју (ископавање, насипање) | 25d | 2023-09-22 | 2023-10-20 | 921SS+45d | 516d | 0d |  |
| 926 | 3.14.1.3.3.3.8.2 | 路面施工（含标线）/ Pavement construction (including marking lines) / Извођење коловоза (укључујући ознаке) | 20d | 2023-10-21 | 2023-11-14 | 925 | 516d | 0d |  |
| 927 | 3.14.1.3.3.3.8.3 | 路灯、边坡腐殖土、水沟等附属工程施工/ Construction of auxiliary projects such as street lamps, slope topsoiling, ditches etc. / Извођење помоћних пројеката попут уличних лампи, хумузирања косина, јаркова, итд. | 30d | 2023-11-15 | 2024-02-21 | 926, 923FF | 516d |  |  |
| 928 | 3.14.1.3.4 | **涵洞culvert / Пропуст** | 162d | 2022-10-13 | 2023-06-30 |  | 284d | 258d |  |
| 929 | 3.14.1.3.4.1 | K0+569.88（4.00 × 3.00m）涵洞/culvert / пропуст | 90ed | 2022-10-13 | 2023-01-11 | 897FS+5d, 1FS+90d | 1276.88d | 61.88d |  |
| 930 | 3.14.1.3.4.2 | K126+922.63（4.00 × 3.00m）涵洞/culvert / пропуст | 73d | 2023-04-01 | 2023-06-30 | 929FS+49d | 284d | 6d |  |
| 931 | 3.14.1.3.5 | **路基施工/ Subgrade construction / Радови на доњем строју** | 348d | 2022-07-01 | 2023-10-20 |  | 278d |  |  |
| 932 | 3.14.1.3.5.1 | 征地及房屋拆迁，见附件Land expropriation and house dismantle, refer to Attachment / Експропријација земљишта и демонтажа куће, види Прилог | 30d | 2022-07-01 | 2022-08-04 |  | 278d | 0d |  |
| 933 | 3.14.1.3.5.2 | 图纸批复Approval of drawings | 10d | 2022-07-01 | 2022-07-12 |  | 298d | 20d |  |
| 934 | 3.14.1.3.5.3 | 管线迁改，见附件2Pipeline relocation, refer to Attachment 2 / Премештање цевовода, погледајте Прилог 2 | 35d | 2022-07-01 | 2022-08-10 |  | 879d |  |  |

| ID | WBS | Task | Duration | Start | Finish | Predecessors | Total slack | Free slack | Constraint |
| --- | --- | --- | --- | --- | --- | --- | --- | --- | --- |
| 935 | 3.14.1.3.5.4 | **路基施工/ Subgrade construction / Радови на доњем строју** | 318d | 2022-08-05 | 2023-10-20 |  | 278d |  |  |
| 936 | 3.14.1.3.5.4.1 | 区间路基/ Open track subgrade / Доњи строј отворене пруге | 288d | 2022-08-05 | 2023-09-15 | 930FF+60d, 897, 932, 933 | 278d | 0d |  |
| 937 | 3.14.1.3.5.4.2 | 排水工程/ Drainage works / Радови на дренажи | 280d | 2022-09-09 | 2023-10-11 | 936SS+30d | 574d |  | start no earlier than 2022-06-01 |
| 938 | 3.14.1.3.5.4.3 | 接触网基础/ Overhead contact system foundations / Темељи контактне мреже | 150d | 2023-04-27 | 2023-10-20 | 936FF+30d | 381d | 0d |  |
| 939 | 3.14.1.3.5.4.4 | 路基通信、信号过轨管/ Subgrade TK and SS pipes passing through track / ТК и СС продори доњег строја | 60d | 2022-09-09 | 2022-11-18 | 936SS+30d | 794d |  |  |
| 940 | 3.14.2 | **电力电气化工程/Electric power Electrification Engineering/Elektrifikacija i elektroenergetski radoviElectric power Electrification Engineering / Elektrifikacija i elektroenergetski radovi** | 477d | 2023-08-03 | 2025-06-30 |  | 157d |  |  |
| 941 | 3.14.2.1 | 接触网立柱、腕臂安装/OCS pole and cantilever installation/Postavljanje stubova kontaktne mreže, montaža konzola | 65d | 2024-05-20 | 2024-08-02 | 938FS+120d | 381d |  |  |
| 942 | 3.14.2.2 | 接触网承导线架设/OCS catenary stretching/Razvlačenje kontaktne mreže | 30d | 2025-04-12 | 2025-05-22 | 1878, 1877 | 190d |  |  |
| 943 | 3.14.2.3 | 接触网悬挂精调/Fine adjustment of catenary suspension/Fina regulacija voznog voda | 23d | 2025-06-04 | 2025-06-30 | 1939, 1940 | 157d |  |  |
| 944 | 3.14.2.4 | 电力迁改110kv/Electricity relocation 110kv/Izmeštanje kablova 110kV | 32d | 2023-08-03 | 2023-09-08 |  | 602d |  | finish no earlier than 2023-09-08 |
| 945 | 3.14.3 | **通信信号工程/Telecommunication and Signaling works / ТК и СС радови** | 672d | 2023-02-10 | 2025-08-30 |  | 104d |  |  |
| 946 | 3.14.3.1 | 房建工程/Construction & renovation for Equipment house / Радови изградње и реновирању зграда | 280d | 2023-02-10 | 2024-03-16 | 954SF-220d | 496d | 0d |  |
| 947 | 3.14.3.2 | **SS工程/ Signaling works/ СС радови** | 172d | 2025-02-05 | 2025-08-30 |  | 104d |  |  |
| 948 | 3.14.3.2.1 | 光电缆敷设/ Optical cable laying / Полагање оптичких каблова | 90d | 2025-02-05 | 2025-05-28 | 949SF | 126d | 0d |  |
| 949 | 3.14.3.2.2 | 轨旁设备安装/ Trackside equipment mounting / Уградња пружних уређаја | 60ed | 2025-05-28 | 2025-07-27 | 1939FS-6d | 367.12d | 0d |  |
| 950 | 3.14.3.2.3 | 信号设备调试/ Testing of the station SS equipment/ Тестирање станичне СС опреме | 60d | 2025-06-23 | 2025-08-30 | 949FS-30d | 104d |  |  |
| 951 | 3.14.3.3 | **TT工程/ Telecommunication works / ТТ радови** | 592d | 2023-05-23 | 2025-08-30 |  | 104d |  |  |
| 952 | 3.14.3.3.1 | 光电缆敷设/ Optical cable laying / Полагање оптичких каблова | 90d | 2025-02-05 | 2025-05-27 | 948SS | 126d | 0d |  |
| 953 | 3.14.3.3.2 | 轨旁设备安装/ Trackside equipment mounting / Уградња пружних уређаја | 60d | 2025-05-28 | 2025-08-05 | 949SS | 126d |  |  |
| 954 | 3.14.3.3.3 | 室内设备安装/ Indoor equipment mounting (at station) / Монтажа унутрашње опреме (у станици) | 150d | 2025-02-05 | 2025-08-05 | 952SS | 126d | 0d |  |
| 955 | 3.14.3.3.4 | 铁塔工程/Communication tower works/ Радови на ТК стубовима | 200d | 2023-05-23 | 2024-03-16 | 946FF | 496d |  |  |
| 956 | 3.14.3.3.5 | TK设备调试/ Testing of the station TK equipment/ Тестирање станичне TK опреме | 60d | 2025-06-23 | 2025-08-30 | 949FS-30d | 104d |  |  |
| 957 | 3.15 | **km117+155.43维尔巴斯特大桥Km117+155.43 Vrbas big bridge Врбас велики мост у Km117+155.43** | 642d | 2022-08-04 | 2025-03-17 |  | 0d |  |  |
| 958 | 3.15.1 | 征地及房屋拆迁，见附件Land expropriation and house dismantle, refer to Attachment / Експропријација земљишта и демонтажа куће, види Прилог | 149ed | 2022-08-04 | 2022-12-31 | 1FS+30d | 1.88d |  |  |
| 959 | 3.15.2 | 图纸批复Approval of drawings | 149ed | 2022-08-04 | 2022-12-31 | 1FS+30d | 73.88d |  |  |
| 960 | 3.15.3 | 管线迁改，见附件2Pipeline relocation, refer to Attachment 2 / Премештање цевовода, погледајте Прилог 2 | 149ed | 2022-08-04 | 2022-12-31 | 1FS+30d | 73.88d |  |  |

| ID | WBS | Task | Type | Duration | Start | Finish | Predecessors | Total slack | Free slack | Constraint |
| --- | --- | --- | --- | --- | --- | --- | --- | --- | --- | --- |
| 961 | 3.15.4 | **桥梁施工Bridges** |  | 562d | 2022-11-05 | 2025-03-17 |  | 0d |  |  |
| 962 | 3.15.4.1 | 钢板桩施工/ Sheet piling construction / Подграђивање талпама |  | 60ed | 2022-11-30 | 2023-01-29 | 959SS+60d, 958SS+100d, 960SS+60d | 3201d |  |  |
| 963 | 3.15.4.2 | 试桩/ Test pile / Пробни шип |  | 40ed | 2022-11-05 | 2022-12-15 | 959SS+60d, 958SS+80d, 960SS+60d | 4.88d |  |  |
| 964 | 3.15.4.3 | 桩基工程Pile foundation works Радови на темељима шипова |  | 150d | 2022-11-30 | 2023-08-01 | 963SS+19d | 0d |  |  |
| 965 | 3.15.4.4 | 承台施工/ Pile caps construction / Извођење наглавних греда |  | 273ed | 2023-01-10 | 2023-10-10 | 964FF+60d | 1.88d |  |  |
| 966 | 3.15.4.5 | 墩身施工/ Pier shafts construction / Извођење тела средњих стубова |  | 250d | 2023-02-25 | 2024-02-22 | 965FF+60d | 0d |  |  |
| 967 | 3.15.4.6 | 墩帽施工Pier top works Радови на глави средњег стуба |  | 300d | 2023-04-13 | 2024-06-12 | 966FF+90d | 0d |  |  |
| 968 | 3.15.4.7 | 现浇梁施工/ Cast-in-situ beam construction / Извођење греде ливене на лицу места |  | 564ed | 2023-06-27 | 2025-01-11 | 967SS+60d | 1.88d | 0d |  |
| 969 | 3.15.4.8 | 钢桁梁施工Steel truss girder works Радови на мосту челичне решетке |  | 564ed | 2023-06-27 | 2025-01-11 | 967SS+60d | 1.88d | 0d |  |
| 970 | 3.15.4.9 | 桥面系施工/ Bridge deck system construction / Извођење система коловозне плоче |  | 65ed | 2025-01-11 | 2025-03-17 | 968, 969 | 1.88d | 0d |  |
| 971 | 3.16 | **新罗沃彻纳茨站（Km128+849~Km129+523）/New Lovcenac Station (Km128+849-Km129+523）/Nova stanica Lovćenac (Km128+849-Km129+523）** |  | 810d | 2022-07-01 | 2025-08-30 |  |  |  |  |
| 972 | 3.16.1 | 土地移交，进场许可/Land handover and access permit/Primopredaja zemljišta I pristupna dozvola | milestone | 0d | 2022-07-01 | 2022-07-01 | 1 | 182d | 0d |  |
| 973 | 3.16.2 | **土建工程/Civil works/Грађевински радови** |  | 434d | 2022-07-01 | 2024-04-03 |  | 182d |  |  |
| 974 | 3.16.2.1 | 既有轨道拆除/Existing track dismantling/Demontiranje postojećeg koloseka | milestone | 0d | 2022-07-01 | 2022-07-01 | 1016 | 436d | 0d | start no earlier than 2022-04-15 |
| 975 | 3.16.2.2 | **新罗沃彻纳茨站（Km128+849~Km129+523）** |  | 434d | 2022-07-01 | 2024-04-03 |  | 182d |  |  |
| 976 | 3.16.2.2.1 | 征地及房屋拆迁，见附件3/For land acquisition and house demolition, see Annex 3/За куповину земљишта и рушење кућа, погледајте Анекс 3 |  | 30d | 2022-08-05 | 2022-09-08 | 1FS+30d | 854d |  |  |
| 977 | 3.16.2.2.2 | 图纸批复/Approval of drawings |  | 30d | 2022-09-09 | 2022-10-13 | 1FS+60d | 824d |  |  |
| 978 | 3.16.2.2.3 | 管线迁改，见附件4/Pipeline relocation, see Annex4/Премештање цевовода, видети Анекс 4 |  | 60d | 2022-07-01 | 2022-09-08 | 972, 974 | 854d |  |  |
| 979 | 3.16.2.2.4 | **车站施工/station construction/изградња станице** |  | 434d | 2022-07-01 | 2024-04-03 |  | 182d |  |  |
| 980 | 3.16.2.2.4.1 | 进站道路225m+2924m/Access road 225m+2924m/Prilazni put 225m+2924m |  | 60d | 2023-10-17 | 2024-02-28 | 987 | 480d | 0d |  |
| 981 | 3.16.2.2.4.2 | 车站标志/Station signs/Stanični znakovi |  | 30d | 2024-02-29 | 2024-04-03 | 980, 985 | 480d |  |  |
| 982 | 3.16.2.2.4.3 | 电梯/Elevator/Lift |  | 60d | 2023-05-25 | 2023-08-02 | 984FF | 634d |  |  |
| 983 | 3.16.2.2.4.4 | 排水工程/Drainage works/Radovi na odvodnjavanju |  | 90d | 2023-04-03 | 2023-07-21 | 987SS+180d | 644d |  |  |
| 984 | 3.16.2.2.4.5 | 旅客通道/Passenger passage/Putnički prolaz |  | 150d | 2023-02-01 | 2023-08-02 | 972, 1358 | 634d | 0d |  |
| 985 | 3.16.2.2.4.6 | 站台雨蓬/Platform canopy/Nadsteršnica za platformu |  | 99ed | 2023-03-01 | 2023-06-08 |  | 2391d | 0d | start no earlier than 2023-03-01 |
| 986 | 3.16.2.2.4.7 | 既有管线、结构物迁改/Relocation of existing pipelines and structures/Izmeštanje postojećih gasovoda i objekata |  | 90d | 2022-07-01 | 2022-10-13 | 972, 974 | 436d | 254d |  |
| 987 | 3.16.2.2.4.8 | 车站路基/Station Subgrade/Posteljica u stanici |  | 344d | 2022-07-01 | 2023-10-16 | 972, 986FF | 182d | 0d |  |
| 988 | 3.16.2.2.4.9 | 接触网基础/OCS Foundation/Temelj kontaktne mreže |  | 100d | 2023-06-22 | 2023-10-16 | 987FF | 505d | 0d |  |

| ID | WBS | Task | Type | Duration | Start | Finish | Predecessors | Total slack | Free slack | Constraint |
| --- | --- | --- | --- | --- | --- | --- | --- | --- | --- | --- |
| 989 | 3.16.3 | **电力电气化工程/Electric power Electrification Engineering/Elektrifikacija i elektroenergetski radovi** |  | 587d | 2023-03-22 | 2025-06-30 |  | 157d |  |  |
| 990 | 3.16.3.1 | 接触网立柱、腕臂安装/OCS pole and cantilever installation/Postavljanje stubova kontaktne mreže, montaža konzola |  | 65d | 2023-10-17 | 2024-03-05 | 988 | 505d |  |  |
| 991 | 3.16.3.2 | 接触网承导线架设/OCS catenary stretching/Razvlačenje kontaktne mreže |  | 45d | 2025-03-05 | 2025-04-29 | 1879 | 178d | 0d |  |
| 992 | 3.16.3.3 | 接触网悬挂精调/Fine adjustment of catenary suspension/Fina regulacija voznog voda |  | 30d | 2025-04-30 | 2025-06-05 | 1941, 991 | 178d |  |  |
| 993 | 3.16.3.4 | 罗沃彻纳茨分区所房建主体工程/Main building works of Lovćenac TSPn/Strukturalni radovi na oblektu PSN Lovćenac |  | 187d | 2023-03-22 | 2023-10-31 |  | 157d | 0d | finish no earlier than 2023-10-31 |
| 994 | 3.16.3.5 | 罗沃彻纳茨分区所房建装饰工程/Building decoration works of Lovćenac TSPn/Dekoraterski radovi na objektu PSN Lovćenac |  | 147d | 2023-11-01 | 2024-06-29 | 993 | 410d |  | finish no earlier than 2024-06-29 |
| 995 | 3.16.3.6 | 配电室改造/Transformation of distribution room/Rekonstrukcija distributivno transformatorske stanice |  | 31d | 2023-08-26 | 2023-10-01 |  | 583d |  | finish no earlier than 2023-10-01 |
| 996 | 3.16.3.7 | 室内电气安装 /Indoor electrical installation/Unutrašnja elektroinstalacija |  | 156d | 2023-03-24 | 2023-09-27 |  | 586d |  | start no earlier than 2023-03-24 |
| 997 | 3.16.3.8 | 车站照明设备安装/Installation of station lighting equipment /Montaža stanične rasvete |  | 122d | 2023-07-03 | 2023-11-22 | 985SS | 539d |  | start no earlier than 2023-07-03 |
| 998 | 3.16.3.9 | 变电所亭设备安装/Installation of ETS equipment/Montaža opreme u EVP | manual | 400d | 2023-11-01 | 2025-06-30 | 993 |  |  | start no earlier than 2023-11-01 |
| 999 | 3.16.4 | **通信信号工程/Telecommunication and Signaling works / ТК и СС радови** |  | 630d | 2023-02-01 | 2025-07-03 |  | 154d |  |  |
| 1000 | 3.16.4.1 | 房建工程/Construction & renovation for Equipment house / Радови изградње и реновирању зграда |  | 280d | 2023-02-01 | 2024-03-07 | 1004SF-230d | 504d | 0d |  |
| 1001 | 3.16.4.2 | **SS工程/ Signaling works/ СС радови** |  | 180d | 2024-09-27 | 2025-07-03 |  | 154d |  |  |
| 1002 | 3.16.4.2.1 | 光电缆敷设/ Optical cable laying / Полагање оптичких каблова |  | 90d | 2024-09-27 | 2025-03-15 | 1003SF | 184d | 0d | start no earlier than 2023-05-10 |
| 1003 | 3.16.4.2.2 | 轨旁设备安装/ Trackside equipment mounting / Уградња пружних уређаја |  | 60d | 2025-03-15 | 2025-05-29 | 1941 | 154d | 0d |  |
| 1004 | 3.16.4.2.3 | 室内设备安装/ Indoor equipment mounting (at station) / Монтажа унутрашње опреме (у станици) |  | 90d | 2025-02-07 | 2025-05-29 | 1003FF | 184d | 0d | start no earlier than 2022-10-08 |
| 1005 | 3.16.4.2.4 | 信号设备调试/ Testing of the station SS equipment/ Тестирање станичне СС опреме |  | 60d | 2025-04-23 | 2025-07-03 | 1003FS-30d | 154d |  |  |
| 1006 | 3.16.4.3 | **TT工程/ Telecommunication works / ТТ радови** |  | 550d | 2023-05-13 | 2025-07-03 |  | 154d |  |  |
| 1007 | 3.16.4.3.1 | 光电缆敷设/ Optical cable laying / Полагање оптичких каблова |  | 90d | 2024-09-27 | 2025-03-14 | 1002SS | 184d | 0d |  |
| 1008 | 3.16.4.3.2 | 综合布线/ Integrated cabling system / структурно каблирање |  | 90d | 2023-09-19 | 2024-03-07 | 1000FF | 504d |  | start no earlier than 2022-09-08 |
| 1009 | 3.16.4.3.3 | 站内通信信息设备安装/Installation of telecommunication and information equipment in the station / Уградња телекомуникационе и информационе опреме у станици |  | 150d | 2024-09-27 | 2025-05-29 | 1007SS | 184d |  | finish no earlier than 2023-07-24 |
| 1010 | 3.16.4.3.4 | 铁塔工程/Communication tower works/ Радови на ТК стубовима |  | 200d | 2023-05-13 | 2024-03-07 | 1000FF | 504d |  | finish no earlier than 2023-07-24 |
| 1011 | 3.16.4.3.5 | TK设备调试/ Testing of the station TK equipment/ Тестирање станичне TK опреме |  | 60d | 2025-04-23 | 2025-07-03 | 1003FS-30d | 154d |  |  |
| 1012 | 3.17 | **新罗沃彻纳茨站（Km129+523）~巴奇卡托波拉站（Km142+682,不含）/Land handover and access permit/Primopredaja zemljišta I pristupna dozvola** |  | 760d | 2022-07-01 | 2025-07-03 |  | 90d |  |  |
| 1013 | 3.17.1 | 土地移交，进场许可/Land handover and access permit/Primopredaja zemljišta I pristupna dozvola | milestone | 0d | 2022-07-01 | 2022-07-01 | 1 | 147d | 0d |  |

| ID | WBS | Task | Type | Duration | Start | Finish | Predecessors | Total slack | Free slack | Constraint | Text10 |
| --- | --- | --- | --- | --- | --- | --- | --- | --- | --- | --- | --- |
| 1014 | 3.17.2 | **新罗沃彻纳茨站（Km129+523）~巴奇卡托波拉站（Km142+682,不含）/New Lovcenac Station (Km129+523) - Backa Topola Station (km142+682, not included)/„Nova stanica Lovćenac (Km129+523) – Bačka Topola Stanica (km142+682, isključivo)"** |  | 616d | 2022-07-01 | 2024-11-07 |  | 90d |  |  |  |
| 1015 | 3.17.2.1 | **新罗沃彻纳茨站（Km129+523）~Km136+000 2023.12.31/New Lovcenac Station (km129+523) -km136+0002023.12.31./„Nova stanica Lovćenac (km129+523) -km136+000** |  | 616d | 2022-07-01 | 2024-11-07 |  | 90d |  |  |  |
| 1016 | 3.17.2.1.1 | 既有轨道拆除/Existing track dismantling/Demontiranje postojećeg koloseka | milestone | 0d | 2022-07-01 | 2022-07-01 | 1072 | 147d | 0d |  |  |
| 1017 | 3.17.2.1.2 | **Km131+245上跨立交桥/km 131+245 Overpass/km131+245 Nadvožnjak** |  | 435d | 2022-08-05 | 2024-05-15 |  | 414d |  |  | Km131+245 Overpass |
| 1018 | 3.17.2.1.2.1 | 征地及房屋拆迁，见附件3/For land acquisition and house demolition, see Annex 3/За куповину земљишта и рушење кућа, погледајте Анекс 3 |  | 30d | 2022-08-05 | 2022-09-08 | 1FS+30d | 414d | 0d |  |  |
| 1019 | 3.17.2.1.2.2 | 图纸批复/Approval of drawings |  | 30d | 2022-08-05 | 2022-09-08 | 1FS+30d | 414d | 0d |  |  |
| 1020 | 3.17.2.1.2.3 | **桥梁施工/bridge construction/конструкција мостова** |  | 405d | 2022-09-09 | 2024-05-15 |  | 414d |  |  |  |
| 1021 | 3.17.2.1.2.3.1 | 旧桥拆除 |  | 40d | 2022-09-09 | 2022-10-25 | 1018, 1019 | 414d | 14d |  |  |
| 1022 | 3.17.2.1.2.3.2 | 试验桩/Test pile/Probni šip |  | 32ed | 2022-11-18 | 2022-12-20 | 1021FS+20d | 1876.88d | 0d |  | test pile |
| 1023 | 3.17.2.1.2.3.3 | 桩基/Pile foundation/Temelj šipova |  | 20ed | 2022-12-20 | 2023-01-09 | 1022 | 1876.88d | 67.88d |  | Piles |
| 1024 | 3.17.2.1.2.3.4 | 桩头破除 |  | 5d | 2023-03-02 | 2023-03-07 | 1023FF+28d | 449d | 0d |  |  |
| 1025 | 3.17.2.1.2.3.5 | 承台/Pile caps/Naglavnice |  | 60d | 2023-03-04 | 2023-05-18 | 1024SS+2d | 449d | 0d |  | Foundations |
| 1026 | 3.17.2.1.2.3.6 | 墩柱/Pier column/Mostovski stub |  | 80d | 2023-03-28 | 2023-07-04 | 1025SS+20d | 449d | 0d |  | Piers |
| 1027 | 3.17.2.1.2.3.7 | 预制梁安装/Precast beam installation/Montaža prefabrikovane grede |  | 40d | 2023-07-28 | 2023-09-12 | 1026FS+20d | 449d | 0d | start no earlier than 2022-11-30 | Girders |
| 1028 | 3.17.2.1.2.3.8 | 桥面铺装/Bridge deck pavement/Плочник моста |  | 50d | 2023-09-14 | 2023-11-10 | 1027FS+1d | 548d |  |  | Slab |
| 1029 | 3.17.2.1.2.3.9 | **顺接地方公路/Local road connection/Povezivanje sa lokanim putevima** |  | 180d | 2023-08-09 | 2024-05-15 |  | 449d |  |  |  |
| 1030 | 3.17.2.1.2.3.9.1 | 路基施工（开挖、填筑）/Subgrade works (excavation and filling)/Radovi na posteljici (iskop i nasipanje) |  | 70d | 2023-08-09 | 2023-10-28 | 1027FF+40d | 449d | 0d |  |  |
| 1031 | 3.17.2.1.2.3.9.2 | 路面施工（含标线）/Road surface works (including marking)/Radovi na kolovoznom zastoru (uključujući označavanje) |  | 50d | 2023-10-30 | 2024-02-29 | 1030 | 449d | 0d |  |  |
| 1032 | 3.17.2.1.2.3.9.3 | 路灯、边坡腐殖土、水沟等附属工程施工/Construction of road light, humus slope, ditch andother subsidary works/Izgradnja putne rasvete, humusne kosine, jarka i ostali pomoćni radovi |  | 60d | 2024-03-01 | 2024-05-15 | 1031 | 449d |  | start no earlier than 2022-04-01 |  |
| 1033 | 3.17.2.1.3 | **Km131+830铁路桥梁(L=489.3m)/km 131+830 Railway Bridge (L=489,3)/km131+830 Železnički most (L=489,3m)** |  | 616d | 2022-07-01 | 2024-11-07 |  | 90d |  |  | Km131+830 Overpass |
| 1034 | 3.17.2.1.3.1 | 征地及房屋拆迁，见附件3/For land acquisition and house demolition, see Annex 3/За куповину земљишта и рушење кућа, погледајте Анекс 3 |  | 30d | 2022-10-14 | 2022-11-18 | 1FF+120d | 0d |  |  |  |
| 1035 | 3.17.2.1.3.2 | 图纸批复/Approval of drawings |  | 50d | 2022-09-21 | 2022-11-18 | 1FF+120d | 794d |  |  |  |
| 1036 | 3.17.2.1.3.3 | 管线迁改，见附件4/Pipeline relocation, see Annex4/Премештање цевовода, видети Анекс 4 |  | 30d | 2022-07-01 | 2022-08-04 | 1013, 1016 | 884d |  |  |  |
| 1037 | 3.17.2.1.3.4 | **桥梁施工/bridge construction/конструкција мостова** |  | 496d | 2022-11-19 | 2024-11-07 |  | 0d |  |  |  |
| 1038 | 3.17.2.1.3.4.1 | 试验桩/Test pile/Probni šip |  | 32d | 2022-11-19 | 2023-02-28 | 1034 | 0d |  |  | test pile |
| 1039 | 3.17.2.1.3.4.2 | 桩基施工/Pile foundation/Temelj šipova |  | 131d | 2023-03-04 | 2023-08-09 | 1038FS+3d | 0d |  |  | Piles |
| 1040 | 3.17.2.1.3.4.3 | 承台/Pile caps/Naglavnice |  | 142d | 2023-04-13 | 2023-09-30 | 1039FF+45d | 0d |  |  | Foundations |
| 1041 | 3.17.2.1.3.4.4 | 墩身/Pier body/Telo stuba |  | 141d | 2023-06-13 | 2023-11-24 | 1040FF+46d | 0d |  |  | Piers |
| 1042 | 3.17.2.1.3.4.5 | 现浇梁/Cast in situ beam/Grede livene na licu mesta |  | 361ed | 2023-09-23 | 2024-09-18 | 1041FF+196d | 1.88d |  |  | Girders |
| 1043 | 3.17.2.1.3.4.6 | 桥面系施工/Bridge floor system works/Плочник моста |  | 376ed | 2023-10-28 | 2024-11-07 | 1042FF+43d | 1.88d |  |  | Slab |

| ID | WBS | Task | Duration | Start | Finish | Predecessors | Total slack | Free slack | Constraint | Text10 |
| --- | --- | --- | --- | --- | --- | --- | --- | --- | --- | --- |
| 1044 | 3.17.2.1.4 | **Km135+113上跨立交桥/km135+113 Overpass/km135+113 nadvožnjak** | 465d | 2022-07-01 | 2024-05-15 |  | 449d |  |  | Km135+113 Overpass |
| 1045 | 3.17.2.1.4.1 | 征地及房屋拆迁，见附件3/For land acquisition and house demolition, see Annex 3/За куповину земљишта и рушење кућа, погледајте Анекс 3 | 30d | 2022-08-05 | 2022-09-08 | 1FS+30d | 820d | 90d |  |  |
| 1046 | 3.17.2.1.4.2 | 图纸批复/Approval of drawings | 30d | 2022-08-05 | 2022-09-08 | 1FS+30d | 820d | 90d |  |  |
| 1047 | 3.17.2.1.4.3 | 管线迁改，见附件4/Pipeline relocation, see Annex4/Премештање цевовода, видети Анекс 4 | 30d | 2022-07-01 | 2022-08-04 | 1013, 1016 | 884d |  |  |  |
| 1048 | 3.17.2.1.4.4 | 确定交通导改方案 | 150d | 2022-07-01 | 2023-02-25 |  | 730d | 0d |  |  |
| 1049 | 3.17.2.1.4.5 | **桥梁施工/bridge construction/конструкција мостова** | 235d | 2022-11-05 | 2023-10-17 |  | 395d |  |  |  |
| 1050 | 3.17.2.1.4.5.1 | 旧桥拆除/Old bridge removal/Uklanjanje starog mosta | 40ed | 2023-02-25 | 2023-04-06 | 1045, 1046, 1048 | 3000d |  |  | Existing bridge demolished |
| 1051 | 3.17.2.1.4.5.2 | 试验桩/Test pile/Probni šip | 32ed | 2022-11-05 | 2022-12-07 | 1231 | 1813.88d | 0d |  | test pile |
| 1052 | 3.17.2.1.4.5.3 | 桩基/Pile foundation/Temelj šipova | 54ed | 2022-12-07 | 2023-01-30 | 1051 | 1813.88d | 4.88d |  | Piles |
| 1053 | 3.17.2.1.4.5.4 | 桩头破除 | 20d | 2023-02-10 | 2023-03-07 | 1052FF+28d | 449d | 0d |  |  |
| 1054 | 3.17.2.1.4.5.5 | 承台、桥台/Pile caps, abutments/Naglavnice, obalni stubovi | 50d | 2023-02-21 | 2023-04-22 | 1053SS+7d | 449d | 0d |  | Foundations |
| 1055 | 3.17.2.1.4.5.6 | 墩柱、盖梁/Pier, capping beam/Stub, naglavna greda | 57d | 2023-03-16 | 2023-05-26 | 1054SS+20d | 449d | 0d |  | Piers |
| 1056 | 3.17.2.1.4.5.7 | 现浇梁/Cast in situ beam/Grede livene na licu mesta | 130d | 2023-05-19 | 2023-10-17 | 1055SS+50d | 449d | 0d |  | Girders |
| 1057 | 3.17.2.1.4.6 | **顺接地方公路/Local road connection/Povezivanje sa lokanim putevima** | 110d | 2023-10-30 | 2024-05-15 |  | 449d |  |  |  |
| 1058 | 3.17.2.1.4.6.1 | 路基施工（开挖、填筑）/Subgrade works (excavation and filling)/Radovi na posteljici (iskop i nasipanje) | 50d | 2023-10-30 | 2024-02-29 | 1056FF+60d | 449d | 0d |  |  |
| 1059 | 3.17.2.1.4.6.2 | 路面施工（含标线）/Road surface works (including marking)/Radovi na kolovoznom zastoru (uključujući označavanje) | 20d | 2024-04-17 | 2024-05-15 | 1058FF+60d | 449d | 0d |  |  |
| 1060 | 3.17.2.1.4.6.3 | 路灯、边坡腐殖土、水沟等附属工程施工/Construction of road light, humus slope, ditch andother subsidary works/Izgradnja putne rasvete, humusne kosine, jarka i ostali pomoćni radovi | 20d | 2024-04-17 | 2024-05-15 | 1059FF | 449d |  | start no earlier than 2022-04-01 |  |
| 1061 | 3.17.2.1.5 | **路基工程/Subgrade works/Radovi na posteljici** | 440d | 2022-07-01 | 2024-04-10 |  | 202d |  |  |  |
| 1062 | 3.17.2.1.5.1 | 征地及房屋拆迁，见附件3/For land acquisition and house demolition, see Annex 3/За куповину земљишта и рушење кућа, погледајте Анекс 3 | 30d | 2022-07-01 | 2022-08-04 | 1 | 202d | 0d |  |  |
| 1063 | 3.17.2.1.5.2 | 图纸批复/Approval of drawings | 30d | 2022-07-01 | 2022-08-04 | 1 | 202d | 0d |  |  |
| 1064 | 3.17.2.1.5.3 | 管线迁改，见附件4/Pipeline relocation, see Annex4/Премештање цевовода, видети Анекс 4 | 30d | 2022-07-01 | 2022-08-04 | 1013, 1016 | 884d |  |  |  |
| 1065 | 3.17.2.1.5.4 | **区间路基/Section subgrade/Deonica posteljice** | 440d | 2022-07-01 | 2024-04-10 |  | 202d |  |  |  |
| 1066 | 3.17.2.1.5.4.1 | 区间路基/Section subgrade/Deonica posteljice | 414d | 2022-07-01 | 2024-03-11 | 1016, 1013SS, 1062SS, 1063SS | 202d | 0d | start no earlier than 2022-04-15 |  |
| 1067 | 3.17.2.1.5.4.2 | 声屏障/Sound barrier/Zvučna barijera | 60d | 2023-11-29 | 2024-04-10 | 1066SS+380d | 414d | 0d |  |  |
| 1068 | 3.17.2.1.5.4.3 | 排水工程/Drainage works/Radovi na odvodnjavanju | 117d | 2023-04-12 | 2023-08-31 | 1066SS+188d | 609d |  |  |  |
| 1069 | 3.17.2.1.5.4.4 | 接触网基础/OCS Foundation/Temelj kontaktne mreže | 250d | 2023-03-15 | 2024-03-11 | 1066FF | 500d |  |  |  |
| 1070 | 3.17.2.1.5.4.5 | 路基通信、信号过轨管/subgrade undertrack pipes for signalization and telecommunication/okiten cevi za signalizaciju i telekomunikaciju | 270d | 2023-02-20 | 2024-03-11 | 1066FF | 500d |  |  |  |

| ID | WBS | Task | Type | Duration | Start | Finish | Predecessors | Total slack | Free slack | Constraint | Text10 |
| --- | --- | --- | --- | --- | --- | --- | --- | --- | --- | --- | --- |
| 1071 | 3.17.2.2 | **Km136+000~巴奇卡托波拉站（Km142+682,不含） 2024.1.31/km136+000 Bačka Topola Station (km142+682, not included) 31.1.2024./km136+000 stanica Bačka Topola (km142+682, isključivo) 31.1.2024.** |  | 500d | 2022-07-01 | 2024-06-25 |  | 147d |  |  |  |
| 1072 | 3.17.2.2.1 | 既有轨道拆除/Existing track dismantling/Demontiranje postojećeg koloseka | milestone | 0d | 2022-07-01 | 2022-07-01 | 1143 | 147d | 0d |  |  |
| 1073 | 3.17.2.2.2 | **Km137+300隧道(明洞动物通道)/km137+300 tunnel ( open-cut tunnel animal passage)/km137+300 tunel (otvoreni tunel prolaz za životinje)** |  | 364d | 2022-08-05 | 2024-02-14 |  | 291d |  |  | Animal crossing at KM 137+300 |
| 1074 | 3.17.2.2.2.1 | 征地及房屋拆迁，见附件3/For land acquisition and house demolition, see Annex 3/За куповину земљишта и рушење кућа, погледајте Анекс 3 |  | 30d | 2022-08-05 | 2022-09-08 | 1FS+30d | 854d |  |  |  |
| 1075 | 3.17.2.2.2.2 | 图纸批复/Approval of drawings |  | 30d | 2022-10-26 | 2022-11-30 | 1FS+100d | 784d |  |  |  |
| 1076 | 3.17.2.2.2.3 | **桥梁施工/bridge construction/конструкција мостова** |  | 295d | 2022-10-25 | 2024-02-14 |  | 222d |  |  |  |
| 1077 | 3.17.2.2.2.3.1 | 桩基/Pile foundation/Temelj šipova |  | 25d | 2022-10-25 | 2022-11-23 | 1087FS+7d | 222d | 0d |  | Piles |
| 1078 | 3.17.2.2.2.3.2 | 基础/Foundation/Temelj |  | 60d | 2022-11-18 | 2023-03-31 | 1077SS+20d | 222d | 0d |  | Foundations |
| 1079 | 3.17.2.2.2.3.3 | Springline wall/Springline wall/Springline zid |  | 60d | 2023-04-22 | 2023-07-03 | 1078FS+15d | 222d | 0d |  | Springline wall |
| 1080 | 3.17.2.2.2.3.4 | 隧道顶建设/Tunnel roof construction/Krovna konstukcija tunela |  | 60d | 2023-07-21 | 2023-09-28 | 1079FS+15d | 222d | 0d |  | Crown construction |
| 1081 | 3.17.2.2.2.3.5 | 回填/Backfilling/Zatrpavanje |  | 50d | 2023-10-17 | 2024-02-14 | 1080FS+15d | 222d |  |  | Top filling |
| 1082 | 3.17.2.2.3 | **Km139+003上跨立交桥/km 139+003 Overpass/km 139+003 Nadvožnjak** |  | 400d | 2022-07-01 | 2024-02-23 |  | 230d |  |  | Km139+003 Overpass |
| 1083 | 3.17.2.2.3.1 | 征地及房屋拆迁，见附件3/For land acquisition and house demolition, see Annex 3/За куповину земљишта и рушење кућа, погледајте Анекс 3 |  | 30d | 2022-08-05 | 2022-09-08 | 1FS+30d | 252d | 30d |  |  |
| 1084 | 3.17.2.2.3.2 | 图纸批复/Approval of drawings |  | 30d | 2022-09-09 | 2022-10-13 | 1FS+60d | 222d | 0d |  |  |
| 1085 | 3.17.2.2.3.3 | **桥梁施工/bridge construction/конструкција мостова** |  | 400d | 2022-07-01 | 2024-02-23 |  | 230d |  |  |  |
| 1086 | 3.17.2.2.3.3.1 | 2#钻机进场 |  | 50d | 2022-07-01 | 2022-08-27 |  | 230d | 8d |  |  |
| 1087 | 3.17.2.2.3.3.2 | 试验桩/Test pile/Probni šip |  | 32d | 2022-09-09 | 2022-10-15 | 1013SS, 1083SS, 1084SS, 1086FS+2d | 222d | 0d |  | test pile |
| 1088 | 3.17.2.2.3.3.3 | 桩基/Pile foundation/Temelj šipova |  | 30ed | 2022-10-15 | 2022-11-14 | 1087 | 3058.88d | 260d |  | Piles |
| 1089 | 3.17.2.2.3.3.4 | 桩头破除 |  | 15ed | 2023-02-03 | 2023-02-18 | 1088FF+28d | 2869.88d | 1.88d |  |  |
| 1090 | 3.17.2.2.3.3.5 | 承台/Pile cap/Naglavnice |  | 60d | 2023-02-18 | 2023-05-04 | 1089SS+10d | 691d | 0d |  | Foundations |
| 1091 | 3.17.2.2.3.3.6 | 墩柱/Pier column/Mostovski stub |  | 60d | 2023-03-14 | 2023-05-27 | 1090SS+20d | 691d |  |  | Piers |
| 1092 | 3.17.2.2.3.3.7 | 预制梁安装/Precast beam installation/Montaža prefabrikovane grede |  | 21d | 2023-09-06 | 2023-09-29 | 1235 | 514d | 0d |  | Girders |
| 1093 | 3.17.2.2.3.3.8 | 桥面铺装/Bridge deck pavement/Плочник моста |  | 50d | 2023-09-30 | 2023-11-28 | 1092 | 514d | 0d |  | Slab |
| 1094 | 3.17.2.2.3.3.9 | **顺接地方公路/Local road connection/Povezivanje sa lokanim putevima** |  | 70d | 2023-09-30 | 2024-02-23 |  | 514d |  |  |  |
| 1095 | 3.17.2.2.3.3.9.1 | 路基施工（开挖、填筑）/Subgrade works (excavation and filling)/Radovi na posteljici (iskop i nasipanje) |  | 60d | 2023-09-30 | 2024-02-09 | 1093FF+10d | 514d | 0d |  |  |
| 1096 | 3.17.2.2.3.3.9.2 | 路面施工（含标线）/Road surface works (including marking)/Radovi na kolovoznom zastoru (uključujući označavanje) |  | 20d | 2023-11-29 | 2024-02-23 | 1095FF+10d | 514d | 0d |  |  |
| 1097 | 3.17.2.2.3.3.9.3 | 路灯、边坡腐殖土、水沟等附属工程施工/Construction of road light, humus slope, ditch andother subsidary works/Izgradnja putne rasvete, humusne kosine, jarka i ostali pomoćni radovi |  | 20d | 2023-11-29 | 2024-02-23 | 1096FF | 514d |  | start no earlier than 2022-04-01 |  |

| ID | WBS | Task | Duration | Start | Finish | Predecessors | Total slack | Free slack | Constraint | Text10 |
| --- | --- | --- | --- | --- | --- | --- | --- | --- | --- | --- |
| 1098 | 3.17.2.2.4 | **Km142+055下穿立交桥/km142+055 Underpass/km142+055 Podvožnjak** | 378d | 2022-07-01 | 2023-11-25 |  | 444d |  |  | Km142+055 Underpass |
| 1099 | 3.17.2.2.4.1 | 征地及房屋拆迁，见附件3/For land acquisition and house demolition, see Annex 3/За куповину земљишта и рушење кућа, погледајте Анекс 3 | 30d | 2022-08-05 | 2022-09-08 | 1FS+30d | 854d |  |  |  |
| 1100 | 3.17.2.2.4.2 | 图纸批复/Approval of drawings | 30d | 2022-08-05 | 2022-09-08 | 1FS+30d | 854d |  |  |  |
| 1101 | 3.17.2.2.4.3 | 管线迁改，见附件4/Pipeline relocation, see Annex4/Премештање цевовода, видети Анекс 4 | 30d | 2022-07-01 | 2022-08-04 | 1013, 1016 | 884d |  |  |  |
| 1102 | 3.17.2.2.4.4 | **桥梁施工/bridge construction/конструкција мостова** | 310d | 2022-09-19 | 2023-11-25 |  | 376d |  |  |  |
| 1103 | 3.17.2.2.4.4.1 | 机械进场，围挡安装 | 5d | 2022-09-19 | 2022-09-23 | 1163 | 376d | 0d |  |  |
| 1104 | 3.17.2.2.4.4.2 | 基坑防护、开挖/Foundation pit protection and excavation/Iskop i zaštita temelja | 55ed | 2022-09-23 | 2022-11-17 | 1103 | 1729.88d | 1.88d | start no earlier than 2022-04-15 | Excavation |
| 1105 | 3.17.2.2.4.4.3 | 垫层混凝土/Concrete slab/Betonska ploča | 115d | 2022-09-30 | 2023-04-20 | 1104SS+5d | 376d | 0d |  | Lean concrete base |
| 1106 | 3.17.2.2.4.4.4 | 框构底板/Base plate/Osnovna ploča | 30d | 2022-10-06 | 2022-11-09 | 1105SS+5d | 376d | 0d |  | Foundation slab |
| 1107 | 3.17.2.2.4.4.5 | 框构侧墙/Side wall/Bočni zid | 45d | 2022-11-10 | 2023-03-07 | 1106 | 376d | 0d |  | Side walls |
| 1108 | 3.17.2.2.4.4.6 | 框构顶板/Top plate/Gornja ploča | 45d | 2023-03-08 | 2023-05-04 | 1107 | 681d | 0d |  | Upper slab |
| 1109 | 3.17.2.2.4.4.7 | U型槽/U shaped groove/U-profil | 140ed | 2022-11-18 | 2023-04-07 | 1107SS+7d | 1741.88d | 0d |  | U-shaped groove |
| 1110 | 3.17.2.2.4.4.8 | 挡土墙/Retaining wall/Potporni zid | 150ed | 2023-04-07 | 2023-09-04 | 1109 | 1828.88d | 1.88d |  | Retaining wall |
| 1111 | 3.17.2.2.4.4.9 | 回填/Backfilling/Zatrpavanje | 30d | 2023-05-05 | 2023-06-08 | 1108 | 681d |  |  | Outer wall side backfill |
| 1112 | 3.17.2.2.4.4.10 | 道路施工380m+116m+128m+196m/Road works 380m+116m+128m+196m/Radovi na kolovozu 380m+116m+128m+196m | 70d | 2023-09-05 | 2023-11-25 | 1110 | 401d | 0d |  |  |
| 1113 | 3.17.2.2.5 | **路基工程/Subgrade works/Radovi na posteljici** | 500d | 2022-07-01 | 2024-06-25 |  | 163d |  |  |  |
| 1114 | 3.17.2.2.5.1 | 征地及房屋拆迁，见附件3/For land acquisition and house demolition, see Annex 3/За куповину земљишта и рушење кућа, погледајте Анекс 3 | 30d | 2022-08-05 | 2022-09-08 | 1FS+30d | 133d | 0d |  |  |
| 1115 | 3.17.2.2.5.2 | 图纸批复/Approval of drawings | 30d | 2022-08-05 | 2022-09-08 | 1FS+30d | 133d | 0d |  |  |
| 1116 | 3.17.2.2.5.3 | 管线迁改，见附件4/Pipeline relocation, see Annex4/Премештање цевовода, видети Анекс 4 | 30d | 2022-07-01 | 2022-08-04 | 1013, 1016 | 884d |  |  |  |
| 1117 | 3.17.2.2.5.4 | **区间路基/Section subgrade/Deonica posteljice** | 440d | 2022-09-09 | 2024-06-25 |  | 133d |  |  |  |
| 1118 | 3.17.2.2.5.4.1 | 区间路基/Section subgrade/Deonica posteljice | 423d | 2022-09-09 | 2024-06-05 | 1114, 1115 | 133d | 0d |  |  |
| 1119 | 3.17.2.2.5.4.2 | 声屏障/Sound barrier/Zvučna barijera | 60d | 2024-04-11 | 2024-06-25 | 1067, 1118SS+200d | 414d |  |  |  |
| 1120 | 3.17.2.2.5.4.3 | 排水工程/Drainage works/Radovi na odvodnjavanju | 118d | 2023-07-17 | 2024-02-01 | 1118SS+205d | 531d |  |  |  |
| 1121 | 3.17.2.2.5.4.4 | 接触网基础/OCS Foundation/Temelj kontaktne mreže | 300d | 2023-04-06 | 2024-06-05 | 1118FF | 366d | 0d |  |  |
| 1122 | 3.17.2.2.5.4.5 | 路基通信、信号过轨管/subgrade undertrack pipes for signalization and telecommunication/okiten cevi za signalizaciju i telekomunikaciju | 300d | 2023-02-27 | 2024-04-22 | 1118SS+90d | 464d |  |  |  |

| ID | WBS | Task | Type | Duration | Start | Finish | Predecessors | Total slack | Free slack | Text10 |
| --- | --- | --- | --- | --- | --- | --- | --- | --- | --- | --- |
| 1123 | 3.17.3 | **电力电气化工程/Electric power Electrification Engineering/Elektrifikacija i elektroenergetski radovi** |  | 226d | 2024-06-06 | 2025-05-05 |  | 205d |  |  |
| 1124 | 3.17.3.1 | 接触网立柱、腕臂安装/OCS pole and cantilever installation/Postavljanje stubova kontaktne mreže, montaža konzola |  | 65d | 2024-06-06 | 2024-08-20 | 1121 | 366d |  |  |
| 1125 | 3.17.3.2 | 接触网承导线架设/OCS catenary stretching/Razvlačenje kontaktne mreže |  | 45d | 2025-03-05 | 2025-04-29 | 1879 | 208d |  |  |
| 1126 | 3.17.3.3 | 接触网悬挂精调/Fine adjustment of catenary suspension/Fina regulacija voznog voda |  | 39d | 2025-03-15 | 2025-05-05 | 1941 | 205d |  |  |
| 1127 | 3.17.4 | **通信信号工程/Telecommunication and Signaling works / ТК и СС радови** |  | 620d | 2023-02-13 | 2025-07-03 |  | 154d |  |  |
| 1128 | 3.17.4.1 | 房建工程/Construction & renovation for Equipment house / Радови изградње и реновирању зграда |  | 280d | 2023-02-13 | 2024-03-19 | 1136SF-160d | 494d | 0d |  |
| 1129 | 3.17.4.2 | **SS工程/ Signaling works/ СС радови** |  | 180d | 2024-09-27 | 2025-07-03 |  | 154d |  |  |
| 1130 | 3.17.4.2.1 | 光电缆敷设/ Optical cable laying / Полагање оптичких каблова |  | 90d | 2024-09-27 | 2025-03-15 | 1131SF | 244d | 0d |  |
| 1131 | 3.17.4.2.2 | 轨旁设备安装/ Trackside equipment mounting / Уградња пружних уређаја |  | 60d | 2025-03-15 | 2025-05-29 | 1941 | 154d | 0d |  |
| 1132 | 3.17.4.2.3 | 信号设备调试/ Testing of the station SS equipment/ Тестирање станичне СС опреме |  | 60d | 2025-04-23 | 2025-07-03 | 1131FS-30d | 154d |  |  |
| 1133 | 3.17.4.3 | **TT工程/ Telecommunication works / ТТ радови** |  | 540d | 2023-05-25 | 2025-07-03 |  | 154d |  |  |
| 1134 | 3.17.4.3.1 | 光电缆敷设/ Optical cable laying / Полагање оптичких каблова |  | 90d | 2024-09-27 | 2025-03-14 | 1130SS | 244d | 0d |  |
| 1135 | 3.17.4.3.2 | 轨旁设备安装/ Trackside equipment mounting / Уградња пружних уређаја |  | 60d | 2025-03-15 | 2025-05-29 | 1131SS | 154d | 0d |  |
| 1136 | 3.17.4.3.3 | 室内设备安装/ Indoor equipment mounting (at station) / Монтажа унутрашње опреме (у станици) |  | 90d | 2024-09-27 | 2025-03-14 | 1134FF | 244d | 0d |  |
| 1137 | 3.17.4.3.4 | 铁塔工程/Communication tower works/ Радови на ТК стубовима |  | 200d | 2023-05-25 | 2024-03-19 | 1128FF | 494d |  |  |
| 1138 | 3.17.4.3.5 | TK设备调试/ Testing of the station TK equipment/ Тестирање станичне TK опреме |  | 60d | 2025-04-23 | 2025-07-03 | 1135FS-30d | 154d |  |  |
| 1139 | 3.18 | **巴奇卡托波拉站（Km142+682-Km144+327） 2023.10.15/Bačka Topola Station (km142+682-km144+327)15.10.2023./Stanica Bačka Topola (142+682-km144+327)15.10.2023.** |  | 760d | 2022-07-01 | 2025-07-03 |  | 4d |  |  |
| 1140 | 3.18.1 | 土地交付/Land handover/Primopredaja zemljišta | milestone | 0d | 2022-07-01 | 2022-07-01 |  | 177d | 0d |  |
| 1141 | 3.18.2 | **土建工程/Civil works/Грађевински радови** |  | 508d | 2022-07-01 | 2024-07-04 |  | 4d |  |  |
| 1142 | 3.18.2.1 | **巴奇卡托波拉站（Km142+682-Km144+327） 2023.10.15/Bačka Topola Station (km142+682-km144+327)15.10.2023./Stanica Bačka Topola (142+682-km144+327)15.10.2023.** |  | 508d | 2022-07-01 | 2024-07-04 |  | 4d |  |  |
| 1143 | 3.18.2.1.1 | 既有轨道拆除/Existing track dismantling/Demontiranje postojećeg koloseka | milestone | 0d | 2022-07-01 | 2022-07-01 | 1 | 147d | 0d |  |
| 1144 | 3.18.2.1.2 | **Km142+712下穿立交桥(站内)/km 142+714 Underpass (in the station)/km 142+712 Podvožnjak (u stanici)** |  | 219d | 2022-07-01 | 2023-05-23 |  | 379d |  | Km142+712 Underpass |
| 1145 | 3.18.2.1.2.1 | 征地及房屋拆迁，见附件3/For land acquisition and house demolition, see Annex 3/За куповину земљишта и рушење кућа, погледајте Анекс 3 | milestone | 0d | 2022-07-01 | 2022-07-01 | 1 | 379d | 0d |  |
| 1146 | 3.18.2.1.2.2 | 图纸批复/Approval of drawings | milestone | 0d | 2022-07-01 | 2022-07-01 | 1 | 379d | 0d |  |

| ID | WBS | Task | Duration | Start | Finish | Predecessors | Total slack | Free slack | Constraint | Text10 |
| --- | --- | --- | --- | --- | --- | --- | --- | --- | --- | --- |
| 1147 | 3.18.2.1.2.3 | **桥梁施工/bridge construction/конструкција мостова** | 129d | 2022-07-01 | 2022-11-29 |  | 379d |  |  |  |
| 1148 | 3.18.2.1.2.3.1 | 基坑防护、开挖/Foundation pit protection and excavation/Iskop i zaštita temelja | 10d | 2022-07-01 | 2022-07-12 | 1140, 1145, 1146 | 379d | 0d | start no earlier than 2022-04-15 | Excavation |
| 1149 | 3.18.2.1.2.3.2 | 垫层混凝土/Concrete slab/Betonska ploča | 10d | 2022-07-06 | 2022-07-16 | 1148FF+4d | 695d | 0d |  | Lean concrete base |
| 1150 | 3.18.2.1.2.3.3 | 框构底板/Base plate/Osnovna ploča | 20d | 2022-08-04 | 2022-08-26 | 1153SS+20d | 695d | 0d |  | Foundation slab |
| 1151 | 3.18.2.1.2.3.4 | 框构侧墙/Side wall/Bočni zid | 30d | 2022-08-27 | 2022-09-30 | 1150 | 695d | 0d |  | Side walls |
| 1152 | 3.18.2.1.2.3.5 | 框构顶板/Top plate/Gornja ploča | 30d | 2022-10-01 | 2022-11-04 | 1151 | 695d | 0d |  | Upper slab |
| 1153 | 3.18.2.1.2.3.6 | 挡土墙/Retaining wall/Potporni zid | 40d | 2022-07-12 | 2022-08-26 | 1149SS+5d | 695d | 0d | start no earlier than 2022-04-15 | Retaining wall |
| 1154 | 3.18.2.1.2.3.7 | 回填/Backfilling/Zatrpavanje | 20d | 2022-11-05 | 2022-11-29 | 1152 | 695d | 0d |  | Outer wall side backfill |
| 1155 | 3.18.2.1.2.4 | 道路施工176m/Road works 176m/Radovi na kolovozu 176m | 110d | 2022-11-05 | 2023-05-23 | 1154SS | 695d |  |  |  |
| 1156 | 3.18.2.1.3 | **Km143+729下穿立交桥(站内)/km 143+729 Underpass (in the station)/km143+729 Podvožnjak (u stanici)** | 508d | 2022-07-01 | 2024-07-04 |  | 379d |  |  | Km143+729 Underpass |
| 1157 | 3.18.2.1.3.1 | 征地及房屋拆迁，见附件3/For land acquisition and house demolition, see Annex 3/За куповину земљишта и рушење кућа, погледајте Анекс 3 | 30d | 2022-08-05 | 2022-09-08 | 1FS+30d | 854d |  |  |  |
| 1158 | 3.18.2.1.3.2 | 图纸批复/Approval of drawings | 30d | 2022-07-01 | 2022-08-04 | 1 | 884d |  |  |  |
| 1159 | 3.18.2.1.3.3 | 管线迁改，见附件4/Pipeline relocation, see Annex4/Премештање цевовода, видети Анекс 4 | 30d | 2022-07-01 | 2022-08-04 | 1140, 1143 | 884d |  |  |  |
| 1160 | 3.18.2.1.3.4 | **桥梁施工/bridge construction/конструкција мостова** | 478d | 2022-07-01 | 2024-05-30 |  | 379d |  |  |  |
| 1161 | 3.18.2.1.3.4.1 | 机械进场，围挡安装 | 5d | 2022-07-01 | 2022-07-06 | 1148SS | 379d | 2d |  |  |
| 1162 | 3.18.2.1.3.4.2 | **一阶段** | 138d | 2022-07-04 | 2023-02-13 |  | 379d |  |  |  |
| 1163 | 3.18.2.1.3.4.2.1 | 开挖/Excavation/Iskop | 75ed | 2022-07-04 | 2022-09-17 | 1161SS+3d | 1729.88d | 1.88d |  | Excavation |
| 1164 | 3.18.2.1.3.4.2.2 | 垫层混凝土/Concrete slab/Betonska ploča | 10d | 2022-08-15 | 2022-08-25 | 1163SS+35d | 432d | 5.12d |  | Lean concrete base |
| 1165 | 3.18.2.1.3.4.2.3 | 框构底板/Base plate/Osnovna ploča | 30ed | 2022-08-22 | 2022-09-21 | 1164SS+7d | 1939.88d | 0d |  | Foundation slab |
| 1166 | 3.18.2.1.3.4.2.4 | 框构侧墙/Side wall/Bočni zid | 30ed | 2022-09-21 | 2022-10-21 | 1165 | 1939.88d | 0d |  | Side walls |
| 1167 | 3.18.2.1.3.4.2.5 | 框构顶板/Top plate/Gornja ploča | 30ed | 2022-10-21 | 2022-11-20 | 1166 | 1939.88d | 1.88d |  | Upper slab |
| 1168 | 3.18.2.1.3.4.2.6 | 回填 | 20d | 2022-11-21 | 2023-02-13 | 1167 | 773d |  |  |  |
| 1169 | 3.18.2.1.3.4.3 | **二阶段** | 90d | 2023-11-27 | 2024-05-19 |  | 401d |  |  |  |
| 1170 | 3.18.2.1.3.4.3.1 | 机械进场，围挡安装 | 7d | 2023-11-27 | 2024-02-03 | 1112 | 401d | 0d |  |  |
| 1171 | 3.18.2.1.3.4.3.2 | 开挖/Excavation/Iskop | 75ed | 2024-02-03 | 2024-04-18 | 1170 | 1642.88d | 84d |  |  |
| 1172 | 3.18.2.1.3.4.3.3 | U型槽/U shaped groove/U-profil | 60ed | 2024-03-12 | 2024-05-11 | 1171SS+30d | 1633.88d | 49d |  | U-shaped groove |
| 1173 | 3.18.2.1.3.4.3.4 | 挡土墙/Retaining wall/Potporni zid | 45ed | 2024-04-04 | 2024-05-19 | 1172SS+20d | 1633.88d | 1.88d |  | Retaining wall |
| 1174 | 3.18.2.1.3.4.4 | 回填/Backfilling/Zatrpavanje | 10d | 2024-05-20 | 2024-05-30 | 1173 | 436d |  |  | Outer wall side backfill |
| 1175 | 3.18.2.1.3.5 | 道路施工396m+199m+182m+95m+87m/Road works396m+199m+182m+95m+87m/Radovi na kolovozu 396m+199m+182m+95m+87m | 40d | 2024-05-20 | 2024-07-04 | 1173 | 406d |  |  |  |

| ID | WBS | Task | Type | Duration | Start | Finish | Predecessors | Total slack | Free slack | Constraint |
| --- | --- | --- | --- | --- | --- | --- | --- | --- | --- | --- |
| 1176 | 3.18.2.1.4 | **巴奇卡托波拉站（Km142+682-Km144+327）/Bačka Topola Station (km142+682-km144+327)/Stnica Bačka Topola (km142+682-km144+327)** |  | 490d | 2022-07-06 | 2024-06-18 |  |  |  |  |
| 1177 | 3.18.2.1.4.1 | 征地及房屋拆迁，见附件3/For land acquisition and house demolition, see Annex 3/За куповину земљишта и рушење кућа, погледајте Анекс 3 |  | 30d | 2022-08-05 | 2022-09-08 | 1FS+30d | 602d | 0d |  |
| 1178 | 3.18.2.1.4.2 | 图纸批复/Approval of drawings |  | 30d | 2022-08-05 | 2022-09-08 | 1FS+30d | 404d | 0d |  |
| 1179 | 3.18.2.1.4.3 | 管线迁改，见附件4/Pipeline relocation, see Annex4/Премештање цевовода, видети Анекс 4 |  | 30d | 2022-07-06 | 2022-08-09 | 1013, 1016 | 628d | 26d |  |
| 1180 | 3.18.2.1.4.4 | **车站施工/station construction/изградња станице** |  | 330d | 2022-09-08 | 2024-02-09 |  | 524d |  |  |
| 1181 | 3.18.2.1.4.4.1 | 停车场通道路700m/Parking lot access road 700m/Pristupni put za parking 700m |  | 90d | 2023-06-17 | 2023-09-29 | 1183FF | 524d | 0d |  |
| 1182 | 3.18.2.1.4.4.2 | 车站辅路116m/Station auxiliary road/Stanični pomoćni put |  | 30d | 2023-09-30 | 2023-11-03 | 1181 | 524d | 0d |  |
| 1183 | 3.18.2.1.4.4.3 | 房屋建筑（装修）/Buildingconstruction(renovation)/Izgradnja objekata (rekonstrukcija) |  | 150d | 2023-04-03 | 2023-09-29 | 1178FS+120d | 404d | 0d |  |
| 1184 | 3.18.2.1.4.4.4 | 车站标志/Station signs/Stanični znakovi |  | 30d | 2023-11-04 | 2024-02-09 | 1189, 1181, 1182 | 524d |  |  |
| 1185 | 3.18.2.1.4.4.5 | 电梯/Elevator/Lift |  | 120d | 2023-02-17 | 2023-07-12 | 1188 | 652d |  |  |
| 1186 | 3.18.2.1.4.4.6 | 消防设施/Fire fighting facilities/Protivpožarni objekti |  | 90d | 2023-07-22 | 2023-11-03 | 1183SS+90d | 554d |  |  |
| 1187 | 3.18.2.1.4.4.7 | 排水工程/Drainage works/Radovi na odvodnjavanju |  | 120d | 2023-07-22 | 2024-02-09 | 1183SS+90d | 524d |  |  |
| 1188 | 3.18.2.1.4.4.8 | 旅客通道/Passenger passage/Putnički prolaz |  | 160ed | 2022-09-08 | 2023-02-15 | 1177, 1178, 1179 | 2728.88d | 4.88d |  |
| 1189 | 3.18.2.1.4.4.9 | 站台雨蓬/Platform canopy/Nadsteršnica za platformu |  | 104ed | 2023-06-08 | 2023-09-20 | 985, 1140, 1143 | 2391d | 0d |  |
| 1190 | 3.18.2.1.5 | **路基工程/Subgrade workd/Radovi na posteljici** |  | 437d | 2022-07-01 | 2024-04-06 |  | 147d |  |  |
| 1191 | 3.18.2.1.5.1 | 征地及房屋拆迁，见附件3/For land acquisition and house demolition, see Annex 3/За куповину земљишта и рушење кућа, погледајте Анекс 3 |  | 30d | 2022-08-05 | 2022-09-08 | 1FS+30d | 117d | 0d |  |
| 1192 | 3.18.2.1.5.2 | 图纸批复/Approval of drawings | milestone | 0d | 2022-07-01 | 2022-07-01 | 1 | 177d | 60d |  |
| 1193 | 3.18.2.1.5.3 | 管线迁改，见附件4/Pipeline relocation, see Annex4/Премештање цевовода, видети Анекс 4 |  | 30d | 2022-07-01 | 2022-08-04 | 1013, 1016 | 147d | 30d |  |
| 1194 | 3.18.2.1.5.4 | **路基工程/Subgrade workd/Radovi na posteljici** |  | 377d | 2022-09-09 | 2024-04-06 |  | 117d |  |  |
| 1195 | 3.18.2.1.5.4.1 | 车站路基/Station Subgrade/Posteljica u stanici |  | 377d | 2022-09-09 | 2024-04-06 | 1140, 1143, 1191, 1192, 1193 | 117d | 0d |  |
| 1196 | 3.18.2.1.5.4.2 | 接触网基础/OCS Foundation/Temelj kontaktne mreže |  | 280d | 2023-03-07 | 2024-04-06 | 1195FF | 417d | 0d |  |
| 1197 | 3.18.3 | **电力电气化工程/Electric power Electrification Engineering/Elektrifikacija i elektroenergetski radovi** |  | 561d | 2023-02-24 | 2025-05-05 |  | 135d |  |  |
| 1198 | 3.18.3.1 | 接触网立柱、腕臂安装/OCS pole and cantilever installation/Postavljanje stubova kontaktne mreže, montaža konzola |  | 60d | 2024-04-08 | 2024-06-21 | 1196 | 417d |  |  |
| 1199 | 3.18.3.2 | 接触网承导线架设/OCS catenary stretching/Razvlačenje kontaktne mreže |  | 45d | 2025-03-05 | 2025-04-29 | 1879 | 208d |  |  |
| 1200 | 3.18.3.3 | 接触网悬挂精调/Fine adjustment of catenary suspension/Fina regulacija voznog voda |  | 39d | 2025-03-15 | 2025-05-05 | 1941 | 205d |  |  |
| 1201 | 3.18.3.4 | 巴奇卡托波拉分区所房建主体工程/Main building works of Bačka Topola TSPn/Strukturalni radovi na objektu PSN Bačka Topola |  | 135d | 2023-02-24 | 2023-08-05 |  | 205d | 0d | finish no earlier than 2023-08-05 |
| 1202 | 3.18.3.5 | 巴奇卡托波拉分区所房建装饰工程/Construction and decoration works of Bačka Topola TSPn/Dekoraterski radovi na objektu PSN Bačka Topola |  | 150d | 2023-09-30 | 2024-06-01 | 1201 | 434d |  | finish no earlier than 2024-06-01 |
| 1203 | 3.18.3.6 | 变电所亭设备安装/Installation of ETS equipment/Montaža opreme u EVP | manual | 426d | 2023-08-07 | 2025-05-05 | 1201 |  |  | finish no earlier than 2025-12-25 |
| 1204 | 3.18.3.7 | 配电室改造/Transformation of distribution room/Rekonstrukcija distributivno transformatorske stanice |  | 19d | 2023-09-30 | 2023-10-21 | 1183 | 565d |  | start no earlier than 2023-08-08 |
| 1205 | 3.18.3.8 | 室内电气安装 /Indoor electrical installation/Unutrašnja elektroinstalacija |  | 150d | 2023-09-30 | 2024-06-01 | 1183SS | 434d |  | start no earlier than 2023-09-30 |
| 1206 | 3.18.3.9 | 车站照明设备安装/Installation of station lighting equipment /Montaža stanične rasvete |  | 120d | 2023-06-08 | 2023-10-25 | 1189SS | 562d |  | start no earlier than 2023-04-26 |

| ID | WBS | Task | Type | Duration | Start | Finish | Predecessors | Total slack | Free slack | Constraint |
| --- | --- | --- | --- | --- | --- | --- | --- | --- | --- | --- |
| 1207 | 3.18.4 | **通信信号工程/Telecommunication and Signaling works / ТК и СС радови** |  | 610d | 2023-02-27 | 2025-07-03 |  | 154d |  |  |
| 1208 | 3.18.4.1 | 房建工程/Construction & renovation for Equipment house / Радови изградње и реновирању зграда |  | 260d | 2023-02-27 | 2024-03-07 | 1212SF-170d | 504d | 0d |  |
| 1209 | 3.18.4.2 | **SS工程/ Signaling works/ СС радови** |  | 180d | 2024-09-27 | 2025-07-03 |  | 154d |  |  |
| 1210 | 3.18.4.2.1 | 光电缆敷设/ Optical cable laying / Полагање оптичких каблова |  | 90d | 2024-09-27 | 2025-03-15 | 1211SF | 184d | 0d |  |
| 1211 | 3.18.4.2.2 | 轨旁设备安装/ Trackside equipment mounting / Уградња пружних уређаја |  | 60d | 2025-03-15 | 2025-05-29 | 1941 | 154d | 0d |  |
| 1212 | 3.18.4.2.3 | 室内设备安装/ Indoor equipment mounting (at station) / Монтажа унутрашње опреме (у станици) |  | 90d | 2024-09-27 | 2025-03-15 | 1210FF | 244d | 0d | start no earlier than 2022-10-08 |
| 1213 | 3.18.4.2.4 | 信号设备调试/ Testing of the station SS equipment/ Тестирање станичне СС опреме |  | 60d | 2025-04-23 | 2025-07-03 | 1211FS-30d | 154d |  |  |
| 1214 | 3.18.4.3 | **TT工程/ Telecommunication works / ТТ радови** |  | 550d | 2023-05-13 | 2025-07-03 |  | 154d |  |  |
| 1215 | 3.18.4.3.1 | 光电缆敷设/ Optical cable laying / Полагање оптичких каблова |  | 90d | 2024-09-27 | 2025-03-14 | 1210SS | 184d | 0d |  |
| 1216 | 3.18.4.3.2 | 综合布线/ Integrated cabling system / структурно каблирање |  | 90d | 2023-09-19 | 2024-03-07 | 1208FF | 504d |  | start no earlier than 2022-09-08 |
| 1217 | 3.18.4.3.3 | 站内通信信息设备安装/Installation of telecommunication and information equipment in the station / Уградња телекомуникационе и информационе опреме у станици |  | 150d | 2024-09-27 | 2025-05-29 | 1215SS | 184d |  | finish no earlier than 2023-07-24 |
| 1218 | 3.18.4.3.4 | 铁塔工程/Communication tower works/ Радови на ТК стубовима |  | 200d | 2023-05-13 | 2024-03-07 | 1208FF | 504d |  | finish no earlier than 2023-07-24 |
| 1219 | 3.18.4.3.5 | TK设备调试/ Testing of the station TK equipment/ Тестирање станичне TK опреме |  | 60d | 2025-04-23 | 2025-07-03 | 1211FS-30d | 154d |  |  |
| 1220 | 3.19 | **巴奇卡托波拉站（Km144+327）~热德尼克站（Km157+116,不含）/Bačka Topola Station (km144+327) + Žednik Station(km157+116, not included)/Stanica Bačka Topola (144+327) - stanica Žednik (km157+116, isključivo)** |  | 770d | 2022-07-01 | 2025-07-15 |  | 144d |  |  |
| 1221 | 3.19.1 | 土地移交，进场许可/Land handover and access permit/Primopredaja zemljišta i pristupna dozvola | milestone | 0d | 2022-07-01 | 2022-07-01 | 1 | 194d | 0d |  |
| 1222 | 3.19.2 | **土建工程/Civil works/Грађевински радови** |  | 460d | 2022-07-01 | 2024-05-09 |  | 194d |  |  |
| 1223 | 3.19.2.1 | **巴奇卡托波拉站（Km144+327）~Km148+000 2023.11.30/Bačka Topola station (km144+327) - km148+00030.11.2023./Stanica Bačka Topola (km144+327) - km148+000 30.11.2023.** |  | 400d | 2022-07-01 | 2024-02-23 |  | 194d |  |  |
| 1224 | 3.19.2.1.1 | 既有轨道拆除/Existing track dismantling/Demontiranje postojećeg koloseka | milestone | 0d | 2022-07-01 | 2022-07-01 | 1252 | 194d | 0d |  |
| 1225 | 3.19.2.1.2 | **Km147+137上跨立交桥/km147+137 Overpass/km147+137 Nadvožnjak** |  | 330d | 2022-07-01 | 2023-09-29 |  | 293d |  |  |
| 1226 | 3.19.2.1.2.1 | 征地及房屋拆迁，见附件3/For land acquisition and house demolition, see Annex 3/За куповину земљишта и рушење кућа, погледајте Анекс 3 |  | 30d | 2022-07-01 | 2022-08-04 | 1 | 882d | 10d |  |
| 1227 | 3.19.2.1.2.2 | 图纸批复/Approval of drawings | milestone | 0d | 2022-07-01 | 2022-07-01 | 1 | 882d | 10d |  |
| 1228 | 3.19.2.1.2.3 | 管线迁改，见附件4/Pipeline relocation, see Annex4/Премештање цевовода, видети Анекс 4 |  | 30d | 2022-07-01 | 2022-08-04 | 1221, 1224 | 882d | 10d |  |
| 1229 | 3.19.2.1.2.4 | **桥梁施工/bridge construction/конструкција мостова** |  | 320d | 2022-07-13 | 2023-09-29 |  | 283d |  |  |
| 1230 | 3.19.2.1.2.4.1 | 试验桩/Test pile/Probni šip |  | 32d | 2022-07-13 | 2022-08-18 | 1221SS, 1226SS, 1227SS, 1228SS, 1257SS+10d | 872d |  | start no earlier than 2022-04-01 |
| 1231 | 3.19.2.1.2.4.2 | 桩基/Pile foundation/Temelj šipova |  | 41d | 2022-09-20 | 2022-11-05 | 1258FS+7d | 224d | 0d |  |
| 1232 | 3.19.2.1.2.4.3 | 桩头破除 |  | 20d | 2022-11-17 | 2023-02-09 | 1231FF+28d | 224d | 0d |  |
| 1233 | 3.19.2.1.2.4.4 | 承台/Pile caps/Naglavnice |  | 60d | 2022-11-29 | 2023-04-11 | 1232SS+10d | 224d | 0d |  |
| 1234 | 3.19.2.1.2.4.5 | 墩柱/Pier column/Mostovski stub |  | 40d | 2023-05-20 | 2023-07-05 | 1233FS+28d | 224d | 0d |  |
| 1235 | 3.19.2.1.2.4.6 | 梁/Girder/Nosač |  | 25d | 2023-08-08 | 2023-09-05 | 1262, 1234FS+28d | 224d | 0d |  |
| 1236 | 3.19.2.1.2.4.7 | 桥面铺装/Bridge deck pavement/Плочник моста |  | 40d | 2023-08-15 | 2023-09-29 | 1235SS+6d | 224d | 0d |  |

| ID | WBS | Task | Type | Duration | Start | Finish | Predecessors | Total slack | Free slack | Constraint |
| --- | --- | --- | --- | --- | --- | --- | --- | --- | --- | --- |
| 1237 | 3.19.2.1.2.4.8 | **顺接地方公路/Local road connection/Povezivanje sa lokanim putevima** |  | 60d | 2023-07-22 | 2023-09-29 |  | 584d |  |  |
| 1238 | 3.19.2.1.2.4.8.1 | 路基施工（开挖、填筑）/Subgrade works (excavation and filling)/Radovi na posteljici (iskop i nasipanje) |  | 60d | 2023-07-22 | 2023-09-29 | 1236FF | 584d | 0d |  |
| 1239 | 3.19.2.1.2.4.8.2 | 路面施工（含标线）/Road surface works (including marking)/Radovi na kolovoznom zastoru (uključujući označavanje) |  | 20d | 2023-09-07 | 2023-09-29 | 1238FF | 584d | 0d |  |
| 1240 | 3.19.2.1.2.4.8.3 | 路灯、边坡腐殖土、水沟等附属工程施工/Construction of road light, humus slope, ditch andother subsidary works/Izgradnja putne rasvete, kosine od humusa, jarka i ostali pomoćni radovi |  | 20d | 2023-09-07 | 2023-09-29 | 1239FF | 584d |  | start no earlier than 2022-04-01 |
| 1241 | 3.19.2.1.3 | **路基工程/Subgrade works/Radovi na posteljici** |  | 400d | 2022-07-01 | 2024-02-23 |  | 224d |  |  |
| 1242 | 3.19.2.1.3.1 | 征地及房屋拆迁，见附件3/For land acquisition and house demolition, see Annex 3/За куповину земљишта и рушење кућа, погледајте Анекс 3 |  | 30d | 2022-07-01 | 2022-08-04 | 1 | 224d | 0d |  |
| 1243 | 3.19.2.1.3.2 | 图纸批复/Approval of drawings | milestone | 0d | 2022-07-01 | 2022-07-01 | 1 | 224d | 0d |  |
| 1244 | 3.19.2.1.3.3 | 管线迁改，见附件4/Pipeline relocation, see Annex4/Премештање цевовода, видети Анекс 4 |  | 30d | 2022-07-01 | 2022-08-04 | 1221, 1224 | 224d | 0d |  |
| 1245 | 3.19.2.1.3.4 | **路基工程/Subgrade works/Radovi na posteljici** |  | 400d | 2022-07-01 | 2024-02-23 |  | 224d |  |  |
| 1246 | 3.19.2.1.3.4.1 | 区间路基/open track subgrade/donji stroj na otvorenoj pruzi |  | 330d | 2022-07-01 | 2023-09-29 | 1242SS, 1243SS, 1244SS | 224d | 0d |  |
| 1247 | 3.19.2.1.3.4.2 | 声屏障/Sound barrier/Zvučna barijera |  | 90d | 2023-08-03 | 2023-11-16 | 1246SS+280d | 544d |  |  |
| 1248 | 3.19.2.1.3.4.3 | 排水工程/Drainage works/Radovi na odvodu |  | 120d | 2023-08-03 | 2024-02-23 | 1246SS+280d | 514d |  |  |
| 1249 | 3.19.2.1.3.4.4 | 接触网基础/OCS Foundation/Temelj kontaktne mreže |  | 110d | 2023-05-25 | 2023-09-29 | 1246FF | 584d |  |  |
| 1250 | 3.19.2.1.3.4.5 | 路基通信、信号过轨管/subgrade undertrack pipes for signalization and telecommunication/okiten cevi za signalizaciju i telekomunikaciju |  | 150d | 2023-02-01 | 2023-08-02 | 1246SS+130d | 634d |  |  |
| 1251 | 3.19.2.2 | **Km148+000~Km153+000 2023.10.31** |  | 450d | 2022-07-01 | 2024-04-22 |  | 194d |  |  |
| 1252 | 3.19.2.2.1 | 既有轨道拆除/Existing track dismantling/Demontiranje postojećeg koloseka | milestone | 0d | 2022-07-01 | 2022-07-01 | 1278 | 194d | 0d |  |
| 1253 | 3.19.2.2.2 | **Km152+282上跨立交桥/Km152+282 overpass/Km152+282 nadvožnjak** |  | 252d | 2022-07-01 | 2023-06-30 |  | 224d |  |  |
| 1254 | 3.19.2.2.2.1 | 征地及房屋拆迁，见附件3/For land acquisition and house demolition, see Annex 3/За куповину земљишта и рушење кућа, погледајте Анекс 3 |  | 30d | 2022-07-01 | 2022-08-04 | 1 | 884d |  |  |
| 1255 | 3.19.2.2.2.2 | 图纸批复/Approval of drawings | milestone | 0d | 2022-07-01 | 2022-07-01 | 1 | 914d |  |  |
| 1256 | 3.19.2.2.2.3 | **桥梁施工/bridge construction/конструкција мостова** |  | 252d | 2022-07-01 | 2023-06-30 |  | 224d |  |  |
| 1257 | 3.19.2.2.2.3.1 | 试验桩/Test pile/Probni šip |  | 22d | 2022-07-01 | 2022-07-26 | 1221 | 224d | 0d | start no earlier than 2022-04-15 |
| 1258 | 3.19.2.2.2.3.2 | 桩基/Pile foundation/šipovi |  | 40d | 2022-07-27 | 2022-09-10 | 1257 | 224d | 0d |  |
| 1259 | 3.19.2.2.2.3.3 | 桩头破除 |  | 15d | 2022-09-27 | 2022-10-13 | 1258FF+28d | 752d | 0d |  |
| 1260 | 3.19.2.2.2.3.4 | 承台/Pile caps/Naglavnice |  | 60d | 2022-10-05 | 2023-02-14 | 1259SS+7d | 752d | 0d |  |
| 1261 | 3.19.2.2.2.3.5 | 墩柱/Pier column/Mostovski stub |  | 60d | 2022-10-28 | 2023-03-11 | 1260SS+20d | 752d |  |  |
| 1262 | 3.19.2.2.2.3.6 | 预制梁安装/Precast beam installation/Montaža prefabrikovanih nosača |  | 40d | 2023-02-03 | 2023-03-23 | 12 | 336d | 0d |  |
| 1263 | 3.19.2.2.2.3.7 | 桥面铺装/Bridge deck pavement/Плочник моста |  | 60d | 2023-03-24 | 2023-06-07 | 1262 | 662d | 0d |  |

| ID | WBS | Task | Type | Duration | Start | Finish | Predecessors | Total slack | Free slack | Constraint |
| --- | --- | --- | --- | --- | --- | --- | --- | --- | --- | --- |
| 1264 | 3.19.2.2.2.3.8 | **顺接地方公路/Local road connection/Povezivanje sa lokanim putevima** |  | 70d | 2023-04-05 | 2023-06-30 |  | 662d |  |  |
| 1265 | 3.19.2.2.2.3.8.1 | 路基施工（开挖、填筑）/subgrade (digging, backfilling)/Radovi na posteljici (iskop i nasipanje) |  | 60d | 2023-04-05 | 2023-06-19 | 1263FF+10d | 662d | 0d |  |
| 1266 | 3.19.2.2.2.3.8.2 | 路面施工（含标线）/Road surface works (including marking)/Radovi na kolovoznom zastoru (uključujući označavanje) |  | 20d | 2023-06-08 | 2023-06-30 | 1265FF+10d | 662d | 0d |  |
| 1267 | 3.19.2.2.2.3.8.3 | 路灯、边坡腐殖土、水沟等附属工程施工/Construction of road light, humus slope, ditch andother subsidary works/Izgradnja putne rasvete, humusne kosine, jarka i ostali pomoćni radovi |  | 20d | 2023-06-08 | 2023-06-30 | 1266FF | 662d |  | start no earlier than 2022-04-01 |
| 1268 | 3.19.2.2.3 | **路基工程/Subgrade works/donji stroj** |  | 450d | 2022-07-01 | 2024-04-22 |  | 194d |  |  |
| 1269 | 3.19.2.2.3.1 | 征地及房屋拆迁，见附件3/For land acquisition and house demolition, see Annex 3/За куповину земљишта и рушење кућа, погледајте Анекс 3 |  | 30d | 2022-08-05 | 2022-09-08 | 1FS+30d | 164d | 30d |  |
| 1270 | 3.19.2.2.3.2 | 图纸批复/Approval of drawings | milestone | 0d | 2022-07-01 | 2022-07-01 | 1 | 224d | 90d |  |
| 1271 | 3.19.2.2.3.3 | 管线迁改，见附件4/Pipeline relocation, see Annex4/Премештање цевовода, видети Анекс 4 |  | 30d | 2022-07-01 | 2022-08-04 | 1221, 1224 | 194d | 60d |  |
| 1272 | 3.19.2.2.3.4 | **路基工程/Subgrade works/donji stroj** |  | 360d | 2022-10-14 | 2024-04-22 |  | 134d |  |  |
| 1273 | 3.19.2.2.3.4.1 | 区间路基/open track subgrade/donji stroj na otvorenoj pruzi |  | 330d | 2022-10-14 | 2024-03-18 | 1252, 1293SS, 1221, 1269, 1270, 1271 | 134d | 0d |  |
| 1274 | 3.19.2.2.3.4.2 | 排水工程/Drainage works/Radovi na odvodu |  | 120d | 2023-09-30 | 2024-04-22 | 1273FF+30d | 464d |  |  |
| 1275 | 3.19.2.2.3.4.3 | 接触网基础/OCS Foundation/Temelj kontaktne mreže |  | 220d | 2023-04-29 | 2024-03-18 | 1273FF | 494d |  |  |
| 1276 | 3.19.2.2.3.4.4 | 路基通信、信号过轨管/subgrade undertrack pipes for signalization and telecommunication/okiten cevi za signalizaciju i telekomunikaciju |  | 250d | 2023-02-27 | 2024-02-23 | 1273SS+60d | 514d |  |  |
| 1277 | 3.19.2.3 | **Km153+000~热德尼克站（Km157+116,不含） 2023.9.30/Km153+000~ Zednik staion (Km157+116, not including) 30.9.2023./Km153+000~stanica Žednik (Km157+116,ne uključuje) 30.9.2023.** |  | 460d | 2022-07-01 | 2024-05-09 |  | 194d |  |  |
| 1278 | 3.19.2.3.1 | 既有轨道拆除/Existing track dismantling/Demontiranje postojećeg koloseka | milestone | 0d | 2022-07-01 | 2022-07-01 | 1318 | 194d | 0d |  |
| 1279 | 3.19.2.3.2 | **Km155+025隧道(明洞动物通道)/Km155+025 tunnel (propusti za svetlo, prelazi za životinje )/Km155+025 tunel (propusti za svetlo, prelazi za životinje )** |  | 331d | 2022-07-01 | 2023-09-30 | 1221 | 332d |  |  |
| 1280 | 3.19.2.3.2.1 | 征地及房屋拆迁，见附件3/For land acquisition and house demolition, see Annex 3/За куповину земљишта и рушење кућа, погледајте Анекс 3 |  | 30d | 2022-08-05 | 2022-09-08 | 1FS+30d | 302d | 39d |  |
| 1281 | 3.19.2.3.2.2 | 图纸批复/Approval of drawings |  | 30d | 2022-07-01 | 2022-08-04 | 1 | 332d | 69d |  |
| 1282 | 3.19.2.3.2.3 | **桥梁施工/bridge construction/конструкција мостова** |  | 262d | 2022-09-20 | 2023-09-30 |  | 263d |  |  |
| 1283 | 3.19.2.3.2.3.1 | 桩基/Pile foundation/Temelj šipova |  | 24d | 2022-09-20 | 2022-10-17 | 1258FS+7d, 1280SS, 1281SS | 263d | 0d |  |
| 1284 | 3.19.2.3.2.3.2 | 基础/Foundation/Temelj |  | 30d | 2022-10-18 | 2022-11-22 | 1283 | 263d | 0d |  |
| 1285 | 3.19.2.3.2.3.3 | Springline wall/Springline wall/Springline zid |  | 60d | 2023-02-28 | 2023-05-13 | 1284FS+28d | 263d | 0d |  |
| 1286 | 3.19.2.3.2.3.4 | 隧道顶建设/Tunnel roof construction/Krovna konstukcija tunela |  | 80d | 2023-05-15 | 2023-08-15 | 1285 | 263d | 0d |  |
| 1287 | 3.19.2.3.2.3.5 | 回填/Backfilling/Zatrpavanje |  | 40d | 2023-08-16 | 2023-09-30 | 1286 | 583d |  |  |

| ID | WBS | Task | Type | Duration | Start | Finish | Predecessors | Total slack | Free slack | Constraint |
| --- | --- | --- | --- | --- | --- | --- | --- | --- | --- | --- |
| 1288 | 3.19.2.3.3 | **路基工程** |  | 460d | 2022-07-01 | 2024-05-09 |  | 194d |  |  |
| 1289 | 3.19.2.3.3.1 | 征地及房屋拆迁，见附件3/For land acquisition and house demolition, see Annex 3/За куповину земљишта и рушење кућа, погледајте Анекс 3 |  | 30d | 2022-08-05 | 2022-09-08 | 1FS+30d | 164d | 30d |  |
| 1290 | 3.19.2.3.3.2 | 图纸批复/Approval of drawings | milestone | 0d | 2022-07-01 | 2022-07-01 | 1 | 224d | 90d |  |
| 1291 | 3.19.2.3.3.3 | 管线迁改，见附件4/Pipeline relocation, see Annex4/Премештање цевовода, видети Анекс 4 |  | 30d | 2022-07-01 | 2022-08-04 | 1221, 1224 | 194d | 60d |  |
| 1292 | 3.19.2.3.3.4 | **路基工程/Subgrade works/donji stroj** |  | 370d | 2022-10-14 | 2024-05-09 |  | 134d |  |  |
| 1293 | 3.19.2.3.3.4.1 | 区间路基/open track subgrade/donji stroj na otvorenoj pruzi |  | 330d | 2022-10-14 | 2024-03-18 | 1278, 1365SS+30d, 1221, 1289, 1290, 1291 | 134d | 0d |  |
| 1294 | 3.19.2.3.3.4.2 | 声屏障/Sound barrier/Zvučna barijera |  | 90d | 2023-11-17 | 2024-05-09 | 1293SS+280d | 454d |  |  |
| 1295 | 3.19.2.3.3.4.3 | 排水工程/Drainage works/Radovi na odvodu |  | 120d | 2023-09-30 | 2024-04-22 | 1293FF+30d | 464d |  |  |
| 1296 | 3.19.2.3.3.4.4 | 接触网基础/OCS Foundation/Temelj kontaktne mreže |  | 220d | 2023-04-29 | 2024-03-18 | 1293FF | 404d | 0d |  |
| 1297 | 3.19.2.3.3.4.5 | 路基通信、信号过轨管/subgrade undertrack pipes for signalization and telecommunication/okiten cevi za signalizaciju i telekomunikaciju |  | 220d | 2023-02-27 | 2023-11-16 | 1293SS+60d | 454d | 0d |  |
| 1298 | 3.19.3 | **电力电气化工程/Electric power Electrification Engineering/Elektrifikacija i elektroenergetski radovi** |  | 330d | 2024-03-19 | 2025-06-21 |  | 164d |  |  |
| 1299 | 3.19.3.1 | 接触网立柱、腕臂安装/OCS pole and cantilever installation/Postavljanje stubova kontaktne mreže, montaža konzola |  | 90d | 2024-03-19 | 2024-07-06 | 1296 | 404d |  |  |
| 1300 | 3.19.3.2 | 接触网承导线架设/OCS catenary stretching/Razvlačenje kontaktne mreže |  | 50d | 2024-07-17 | 2024-09-12 | 1881 | 346d |  |  |
| 1301 | 3.19.3.3 | 接触网悬挂精调/Fine adjustment of catenary suspension/Fina regulacija voznog voda |  | 70d | 2025-03-27 | 2025-06-21 | 1943 | 164d |  |  |
| 1302 | 3.19.4 | **通信信号工程/Telecommunication and Signaling works / ТК и СС радови** |  | 620d | 2023-02-27 | 2025-07-15 |  | 144d |  |  |
| 1303 | 3.19.4.1 | 房建工程/Construction & renovation for Equipment house / Радови изградње и реновирању зграда |  | 260d | 2023-02-27 | 2024-03-07 | 1311SF-180d | 504d | 0d |  |
| 1304 | 3.19.4.2 | **SS工程/ Signaling works/ СС радови** |  | 180d | 2024-10-09 | 2025-07-15 |  | 144d |  |  |
| 1305 | 3.19.4.2.1 | 光电缆敷设/ Optical cable laying / Полагање оптичких каблова |  | 90d | 2024-10-09 | 2025-03-27 | 1306SF | 174d | 0d | start no earlier than 2023-05-10 |
| 1306 | 3.19.4.2.2 | 轨旁设备安装/ Trackside equipment mounting / Уградња пружних уређаја |  | 60d | 2025-03-27 | 2025-06-10 | 1943 | 144d | 0d |  |
| 1307 | 3.19.4.2.3 | 信号设备调试/ Testing of the station SS equipment/ Тестирање станичне СС опреме |  | 60d | 2025-05-07 | 2025-07-15 | 1306FS-30d | 144d |  |  |
| 1308 | 3.19.4.3 | **TT工程/ Telecommunication works / ТТ радови** |  | 560d | 2023-05-13 | 2025-07-15 |  | 144d |  |  |
| 1309 | 3.19.4.3.1 | 光电缆敷设/ Optical cable laying / Полагање оптичких каблова |  | 90d | 2024-10-09 | 2025-03-26 | 1305SS | 174d | 0d |  |
| 1310 | 3.19.4.3.2 | 轨旁设备安装/ Trackside equipment mounting / Уградња пружних уређаја |  | 60d | 2025-03-27 | 2025-06-10 | 1306SS | 144d | 0d |  |
| 1311 | 3.19.4.3.3 | 室内设备安装/ Indoor equipment mounting (at station) / Монтажа унутрашње опреме (у станици) |  | 150d | 2024-10-09 | 2025-06-10 | 1309SS | 174d | 0d |  |
| 1312 | 3.19.4.3.4 | 铁塔工程/Communication tower works/ Радови на ТК стубовима |  | 200d | 2023-05-13 | 2024-03-07 | 1303FF | 504d |  |  |
| 1313 | 3.19.4.3.5 | TK设备调试/ Testing of the station TK equipment/ Тестирање станичне TK опреме |  | 60d | 2025-05-07 | 2025-07-15 | 1310FS-30d | 144d |  |  |

| ID | WBS | Task | Type | Duration | Start | Finish | Predecessors | Total slack | Free slack | Constraint | Text10 |
| --- | --- | --- | --- | --- | --- | --- | --- | --- | --- | --- | --- |
| 1314 | 3.20 | **热德尼克站（Km156+211-Km157+525） 2023.8.31/Zednik station (Km156+211-Km157+525) 31.8.2023./stanica Žednik (Km156+211-Km157+525) 31.8.2023.** |  | 757d | 2022-07-01 | 2025-06-30 |  | 7d |  |  |  |
| 1315 | 3.20.1 | 土地交付/Land handover/Primopredaja zemljišta | milestone | 0d | 2022-07-01 | 2022-07-01 |  | 22d | 0d |  |  |
| 1316 | 3.20.2 | **土建工程/Civil works/građevinski radovi** |  | 510d | 2022-07-01 | 2024-07-06 |  | 7d |  |  |  |
| 1317 | 3.20.2.1 | **热德尼克站（Km156+211-Km157+525） 2023.8.31/Zednik station (Km156+211-Km157+525) 31.8.2023./stanica Žednik (Km156+211-Km157+525) 31.8.2023.** |  | 510d | 2022-07-01 | 2024-07-06 |  | 7d |  |  |  |
| 1318 | 3.20.2.1.1 | 既有轨道拆除/Existing track dismantling/Demontiranje postojećeg koloseka | milestone | 0d | 2022-07-01 | 2022-07-01 | 1 | 22d | 0d |  |  |
| 1319 | 3.20.2.1.2 | **Km156+453下穿立交桥/Km156+453 underpass/Km156+453 podvožnjak** |  | 315d | 2022-07-01 | 2023-09-12 |  | 7d |  |  |  |
| 1320 | 3.20.2.1.2.1 | 征地及房屋拆迁，见附件3/For land acquisition and house demolition, see Annex 3/За куповину земљишта и рушење кућа, погледајте Анекс 3 |  | 30d | 2022-07-01 | 2022-08-04 | 1 | 22d | 15d |  |  |
| 1321 | 3.20.2.1.2.2 | 图纸批复/Approval of drawings | milestone | 0d | 2022-07-01 | 2022-07-01 | 1 | 7d | 0d |  |  |
| 1322 | 3.20.2.1.2.3 | 管线迁改，见附件4/Pipeline relocation, see Annex4/Премештање цевовода, видети Анекс 4 |  | 30d | 2022-07-01 | 2022-08-04 | 1315, 1318 | 22d | 15d |  |  |
| 1323 | 3.20.2.1.2.4 | **桥梁施工/bridge construction/конструкција мостова** |  | 300d | 2022-07-19 | 2023-09-12 |  | 7d |  |  |  |
| 1324 | 3.20.2.1.2.4.1 | 基坑防护、开挖/Foundation pit protection and excavation/Iskop i zaštita temelja |  | 60d | 2022-07-19 | 2022-09-26 | 1315SS, 1320SS, 1321SS+15d, 1322SS | 7d | 0d | start no earlier than 2022-04-15 |  |
| 1325 | 3.20.2.1.2.4.2 | 垫层混凝土/Concrete slab/Betonska ploča |  | 115d | 2022-08-11 | 2023-02-25 | 1324SS+20d | 721d | 5d |  |  |
| 1326 | 3.20.2.1.2.4.3 | 框构底板/Base plate/Osnovna ploča |  | 60d | 2022-10-20 | 2023-03-03 | 1324SS+80d | 7d | 0d |  |  |
| 1327 | 3.20.2.1.2.4.4 | 框构侧墙/Side wall/Bočni zid |  | 60d | 2022-11-14 | 2023-03-27 | 1326SS+20d | 7d | 0d |  |  |
| 1328 | 3.20.2.1.2.4.5 | 框构顶板/Top plate/Gornja ploča |  | 80d | 2022-11-25 | 2023-05-06 | 1327SS+10d | 7d | 0d |  |  |
| 1329 | 3.20.2.1.2.4.6 | U型槽/U shaped groove/U-profil |  | 150ed | 2022-09-14 | 2023-02-11 | 1330SS+22d | 3162d |  |  |  |
| 1330 | 3.20.2.1.2.4.7 | 挡土墙/Retaining wall/Potporni zid |  | 104ed | 2022-08-19 | 2022-12-01 | 1325SS+8d | 3163.88d | 56d |  |  |
| 1331 | 3.20.2.1.2.4.8 | 回填/Backfilling/Zatrpavanje |  | 110d | 2023-05-08 | 2023-09-12 | 1328 | 7d | 0d |  |  |
| 1332 | 3.20.2.1.2.4.9 | 配套路（90m+350m）施工（含标线）/complete road works （90m+350m）(inscluding marking )/kompletni radovi na trasi（90m+350m）(uključijući označavanje) |  | 50d | 2023-05-08 | 2023-07-04 | 1331SS | 7d | 0d |  | EAT CONFIRM |
| 1333 | 3.20.2.1.3 | **Km157+443下穿立交桥/Km157+443 underpass/Km157+443 podvožnjak** |  | 481d | 2022-07-01 | 2024-06-03 |  | 172d |  |  |  |
| 1334 | 3.20.2.1.3.1 | 征地及房屋拆迁，见附件3/For land acquisition and house demolition, see Annex 3/За куповину земљишта и рушење кућа, погледајте Анекс 3 |  | 30d | 2022-08-05 | 2022-09-08 | 1FS+30d | 202d | 195d |  |  |
| 1335 | 3.20.2.1.3.2 | 图纸批复/Approval of drawings |  | 90d | 2022-07-01 | 2022-10-13 | 1 | 172d | 165d |  |  |
| 1336 | 3.20.2.1.3.3 | 管线迁改，见附件4/Pipeline relocation, see Annex4/Премештање цевовода, видети Анекс 4 |  | 30d | 2022-07-01 | 2022-08-04 | 1315, 1318 | 232d | 225d |  |  |
| 1337 | 3.20.2.1.3.4 | **桥梁施工/bridge construction/конструкција мостова** |  | 226d | 2023-07-05 | 2024-06-03 |  | 7d |  |  |  |
| 1338 | 3.20.2.1.3.4.1 | 基坑防护、开挖/Foundation pit protection and excavation/Iskop i zaštita temelja |  | 95d | 2023-07-05 | 2023-10-23 | 1315, 1334, 1335, 1336, 1332 | 7d | 0d | start no earlier than 2022-04-15 |  |
| 1339 | 3.20.2.1.3.4.2 | 垫层混凝土/Concrete slab/Betonska ploča |  | 115d | 2023-07-13 | 2023-11-24 | 1338SS+7d | 7d | 0d |  |  |
| 1340 | 3.20.2.1.3.4.3 | 框构底板/Base plate/Osnovna ploča |  | 15d | 2023-07-15 | 2023-08-01 | 1339SS+2d | 7d | 0d |  |  |
| 1341 | 3.20.2.1.3.4.4 | 框构侧墙/Side wall/Bočni zid |  | 15d | 2023-08-02 | 2023-08-18 | 1340 | 7d | 0d |  |  |
| 1342 | 3.20.2.1.3.4.5 | 框构顶板/Top plate/Gornja ploča |  | 20d | 2023-08-19 | 2023-09-11 | 1341 | 7d | 0d |  |  |
| 1343 | 3.20.2.1.3.4.6 | U型槽/U shaped groove/U-profil |  | 70d | 2023-08-04 | 2023-10-24 | 1341SS+2d | 433d | 0d |  |  |
| 1344 | 3.20.2.1.3.4.7 | 挡土墙/Retaining wall/Potporni zid |  | 60d | 2023-10-25 | 2024-03-07 | 1343 | 433d | 0d |  |  |
| 1345 | 3.20.2.1.3.4.8 | 回填/Backfilling/Zatrpavanje |  | 90d | 2023-09-12 | 2024-02-28 | 1342 | 510d |  |  |  |
| 1346 | 3.20.2.1.3.4.9 | 配套路施工399m+147m+124m（含标线）/complete road works 399m+147m+124m(inscluding marking )/kompletni radovi na trasi 399m+147m+124m(uključijući označavanje) |  | 70d | 2024-03-08 | 2024-06-03 | 1344 | 433d |  |  | EAT CONFIRM |

| ID | WBS | Task | Duration | Start | Finish | Predecessors | Total slack | Free slack | Constraint | Text10 |
| --- | --- | --- | --- | --- | --- | --- | --- | --- | --- | --- |
| 1347 | 3.20.2.1.4 | **热德尼克站/Zednik station/station Žednik** | 510d | 2022-07-01 | 2024-07-06 |  | 404d |  |  |  |
| 1348 | 3.20.2.1.4.1 | 征地及房屋拆迁，见附件3/For land acquisition and house demolition, see Annex 3/За куповину земљишта и рушење кућа, погледајте Анекс 3 | 30d | 2022-08-05 | 2022-09-08 | 1FS+30d | 854d |  |  |  |
| 1349 | 3.20.2.1.4.2 | 图纸批复/Approval of drawings | 30d | 2022-08-05 | 2022-09-08 | 1FS+30d | 854d |  |  |  |
| 1350 | 3.20.2.1.4.3 | 管线迁改，见附件4/Pipeline relocation, see Annex4/Премештање цевовода, видети Анекс 4 | 30d | 2022-07-01 | 2022-08-04 | 1315, 1318 | 884d |  |  |  |
| 1351 | 3.20.2.1.4.4 | **车站施工/station construction/изградња станице** | 430d | 2022-10-01 | 2024-07-06 |  | 404d |  |  |  |
| 1352 | 3.20.2.1.4.4.1 | 进站道路30m/Access road 30m/Prilazni put | 30d | 2024-02-10 | 2024-03-18 | 1365 | 468d | 0d |  |  |
| 1353 | 3.20.2.1.4.4.2 | 房屋建筑（装修）/Building construction (renovation)/izgradnja objekta (renoviranje) | 90d | 2023-09-30 | 2024-03-18 | 1183 | 404d | 0d |  |  |
| 1354 | 3.20.2.1.4.4.3 | 车站标志/Station signs/Stanični znakovi | 30ed | 2024-03-18 | 2024-04-17 | 1359, 1352 | 1869d |  |  |  |
| 1355 | 3.20.2.1.4.4.4 | 电梯/Elevator/Lift | 60d | 2023-02-13 | 2023-04-28 | 1358SS+60d | 714d |  |  |  |
| 1356 | 3.20.2.1.4.4.5 | 消防设施/Fire fighting facilities/Protivpožarni objekti | 90d | 2024-03-19 | 2024-07-06 | 1353SS+90d | 404d |  |  |  |
| 1357 | 3.20.2.1.4.4.6 | 排水工程/Drainage works/Radovi na odvodu | 90d | 2024-03-19 | 2024-07-06 | 1353SS+90d | 404d |  |  |  |
| 1358 | 3.20.2.1.4.4.7 | 旅客通道/Passenger passage/Putnički prolaz | 90ed | 2022-10-01 | 2022-12-30 | 1188SS+20d | 2764.88d | 4.88d |  |  |
| 1359 | 3.20.2.1.4.4.8 | 站台雨蓬/Platform canopy/nadsteršnica na peronu | 80d | 2023-02-01 | 2023-05-12 | 1358 | 664d | 8d |  |  |
| 1360 | 3.20.2.1.5 | **路基工程/Subgrade works/radovi na donjem stroju** | 390d | 2022-07-01 | 2024-02-09 |  | 164d |  |  |  |
| 1361 | 3.20.2.1.5.1 | 征地及房屋拆迁，见附件3/For land acquisition and house demolition, see Annex 3/За куповину земљишта и рушење кућа, погледајте Анекс 3 | 30d | 2022-08-05 | 2022-09-08 | 1FS+30d | 134d | 0d |  |  |
| 1362 | 3.20.2.1.5.2 | 图纸批复/Approval of drawings | 30d | 2022-08-05 | 2022-09-08 | 1FS+30d | 134d | 0d |  |  |
| 1363 | 3.20.2.1.5.3 | 管线迁改，见附件4/Pipeline relocation, see Annex4/Премештање цевовода, видети Анекс 4 | 30d | 2022-07-01 | 2022-08-04 | 1315, 1318 | 164d | 30d |  |  |
| 1364 | 3.20.2.1.5.4 | **车站路基/Station Subgrade/donji stroj u stanici** | 330d | 2022-09-09 | 2024-02-09 |  | 134d |  |  |  |
| 1365 | 3.20.2.1.5.4.1 | 车站路基/Station Subgrade/donji stroj u stanici | 330d | 2022-09-09 | 2024-02-09 | 1315, 1318, 1361, 1362, 1363 | 134d | 0d |  | EAT CONFIRM |
| 1366 | 3.20.2.1.5.4.2 | 接触网基础/OCS Foundation/Temelj kontaktne mreže | 250d | 2023-02-13 | 2024-02-09 | 1365FF | 434d | 0d |  |  |
| 1367 | 3.20.3 | **电力电气化工程/Electric power Electrification Engineering/Elektrifikacija i elektroenergetski radovi** | 619d | 2023-02-10 | 2025-06-30 |  | 157d |  |  |  |
| 1368 | 3.20.3.1 | 接触网立柱、腕臂安装/OCS pole and cantilever installation/Postavljanje stubova kontaktne mreže, montaža konzola | 90d | 2024-02-10 | 2024-06-01 | 1366 | 434d |  |  |  |
| 1369 | 3.20.3.2 | 接触网承导线架设/OCS catenary stretching/Razvlačenje kontaktne mreže | 50d | 2024-07-17 | 2024-09-12 | 1881 | 346d |  |  |  |
| 1370 | 3.20.3.3 | 接触网悬挂精调/Fine adjustment of catenary suspension/Fina regulacija voznog voda | 70d | 2025-02-05 | 2025-05-03 | 1944 | 206d |  |  |  |
| 1371 | 3.20.3.4 | 热德尼克分区所房建主体工程/Main building works of Žednik TSPn/Strukturalni radovi na objektu PSN Žednik | 130d | 2023-02-24 | 2023-07-31 |  | 186d | 17d | finish no earlier than 2023-07-31 |  |
| 1372 | 3.20.3.5 | 热德尼克分区所房建装饰工程/Decoration works of Žednik TSPn/Dekoraterski radovi na objektu PSN Žednik | 180d | 2023-08-21 | 2024-05-27 | 1371 | 439d |  | finish no earlier than 2024-05-27 |  |
| 1373 | 3.20.3.6 | 变电所亭设备安装/Installation of ETS equipment/Montaža opreme u EVP | 450d | 2023-09-04 | 2025-06-30 | 1371 | 157d |  | finish no earlier than 2025-06-30 |  |
| 1374 | 3.20.3.7 | 配电室改造/Transformation of distribution room/Rekonstrukcija distributivno transformatorske stanice | 53d | 2024-06-06 | 2024-08-06 | 1353 | 378d |  | start no earlier than 2024-06-06 |  |
| 1375 | 3.20.3.8 | 室内电气安装 /Indoor electrical installation/Unutrašnja elektroinstalacija | 150d | 2024-04-04 | 2024-10-01 | 1353SS | 330d |  | finish no earlier than 2024-10-01 |  |
| 1376 | 3.20.3.9 | 车站照明设备安装/Installation of station lighting equipment /Montaža stanične rasvete | 120d | 2023-02-10 | 2023-07-07 | 1359SS | 656d |  | finish no earlier than 2023-07-07 |  |

| ID | WBS | Task | Type | Duration | Start | Finish | Predecessors | Total slack | Free slack | Constraint | Text10 |
| --- | --- | --- | --- | --- | --- | --- | --- | --- | --- | --- | --- |
| 1377 | 3.20.4 | **通信信号工程/Telecommunication and Signaling works / ТК и СС радови** |  | 580d | 2023-02-24 | 2025-05-27 |  | 186d |  |  |  |
| 1378 | 3.20.4.1 | 房建工程/Construction & renovation for Equipment house / Радови изградње и реновирању зграда |  | 270d | 2023-02-24 | 2024-03-16 | 1382SF-130d | 496d | 0d |  |  |
| 1379 | 3.20.4.2 | **SS工程/ Signaling works/ СС радови** |  | 180d | 2024-08-21 | 2025-05-27 |  | 186d |  |  |  |
| 1380 | 3.20.4.2.1 | 光电缆敷设/ Optical cable laying / Полагање оптичких каблова |  | 90d | 2024-08-21 | 2025-02-05 | 1381SF | 186d | 0d | start no earlier than 2023-05-10 |  |
| 1381 | 3.20.4.2.2 | 轨旁设备安装/ Trackside equipment mounting / Уградња пружних уређаја |  | 60d | 2025-02-05 | 2025-04-16 | 1944 | 186d | 0d |  |  |
| 1382 | 3.20.4.2.3 | 室内设备安装/ Indoor equipment mounting (at station) / Монтажа унутрашње опреме (у станици) |  | 90d | 2024-08-21 | 2025-02-05 | 1380FF | 276d | 0d | start no earlier than 2022-10-08 |  |
| 1383 | 3.20.4.2.4 | 信号设备调试/ Testing of the station SS equipment/ Тестирање станичне СС опреме |  | 60d | 2025-03-13 | 2025-05-27 | 1381FS-30d | 186d |  |  |  |
| 1384 | 3.20.4.3 | **TT工程/ Telecommunication works / ТТ радови** |  | 510d | 2023-05-23 | 2025-05-27 |  | 186d |  |  |  |
| 1385 | 3.20.4.3.1 | 光电缆敷设/ Optical cable laying / Полагање оптичких каблова |  | 90d | 2024-08-21 | 2025-02-04 | 1380SS | 186d | 0d |  |  |
| 1386 | 3.20.4.3.2 | 综合布线/ Integrated cabling system / структурно каблирање |  | 90d | 2023-09-28 | 2024-03-16 | 1378FF | 496d |  | start no earlier than 2022-09-08 |  |
| 1387 | 3.20.4.3.3 | 站内通信信息设备安装/Installation of telecommunication and information equipment in the station / Уградња телекомуникационе и информационе опреме у станици |  | 150d | 2024-08-21 | 2025-04-16 | 1385SS | 186d | 0d | finish no earlier than 2023-07-24 |  |
| 1388 | 3.20.4.3.4 | 铁塔工程/Communication tower works/ Радови на ТК стубовима |  | 200d | 2023-05-23 | 2024-03-16 | 1378FF | 496d |  | finish no earlier than 2023-07-24 |  |
| 1389 | 3.20.4.3.5 | TK设备调试/ Testing of the station TK equipment/ Тестирање станичне TK опреме |  | 60d | 2025-03-13 | 2025-05-27 | 1387FS-30d | 186d |  |  |  |
| 1390 | 3.21 | **热德尼克站（Km157+116）~那维切沃站（Km166+519.63,不含）/Zednik station （Km157+116）~ Naumovićevo station (Km166+519.63, not including)/stanica Žednik（Km157+116）~ stanica Naumovićevo (Km166+519.63, neuključuje)** |  | 735d | 2022-07-01 | 2025-06-04 |  | 0d |  |  |  |
| 1391 | 3.21.1 | 土地移交，进场许可/land is transferred, entrance allowed/zemljište je predato, dozvoljen ulazak na gradilište | milestone | 0d | 2022-07-01 | 2022-07-01 | 1 | 0d |  |  |  |
| 1392 | 3.21.2 | **土建工程/civil engineering works/zemljani radovi** |  | 428d | 2022-07-01 | 2024-03-27 |  | 0d |  |  |  |
| 1393 | 3.21.2.1 | **热德尼克站（Km157+525）~Km162+000 2023.9.10/Zednik station (Km157+525) ~Km162+000/stanica Žednik (Km157+525) ~Km162+000 10.09.2023** |  | 428d | 2022-07-01 | 2024-03-27 |  | 17d |  |  |  |
| 1394 | 3.21.2.1.1 | 既有轨道拆除/demounting of existing tracks/demontaža postojećih koloseka | milestone | 0d | 2022-07-01 | 2022-07-01 | 1417 | 17d | 0d |  |  |
| 1395 | 3.21.2.1.2 | **Km160+094上跨立交桥/overpass at Km160+094/nadvožnjak na Km160+094** |  | 398d | 2022-08-05 | 2024-03-27 |  | 486d |  |  | KARIN CONFIRM |
| 1396 | 3.21.2.1.2.1 | 征地及房屋拆迁，见附件3/For land acquisition and house demolition, see Annex 3/За куповину земљишта и рушење кућа, погледајте Анекс 3 |  | 30d | 2022-08-05 | 2022-09-08 | 1FS+30d | 557d | 0d |  |  |
| 1397 | 3.21.2.1.2.2 | 图纸批复/Approval of drawings |  | 30d | 2022-08-05 | 2022-09-08 | 1FS+30d | 557d | 0d |  |  |
| 1398 | 3.21.2.1.2.3 | **桥梁施工/bridge construction/конструкција мостова** |  | 398d | 2022-08-05 | 2024-03-27 |  | 486d |  |  |  |
| 1399 | 3.21.2.1.2.3.1 | 施工准备/preparation works/pripremni radovi |  | 21d | 2023-02-02 | 2023-02-28 | 1514, 1391, 1396, 1397 | 486d | 0d |  |  |
| 1400 | 3.21.2.1.2.3.2 | 桩基/pile/šipovi |  | 52d | 2023-03-01 | 2023-05-05 | 1399 | 486d | 0d |  |  |
| 1401 | 3.21.2.1.2.3.3 | 承台/pile caps/nadglavnice |  | 67d | 2023-04-20 | 2023-07-08 | 1400SS+40d | 486d | 0d |  |  |
| 1402 | 3.21.2.1.2.3.4 | 墩柱/heavy-duty pier/noseći stubovi |  | 52d | 2023-07-10 | 2023-09-07 | 1401 | 486d | 0d |  |  |
| 1403 | 3.21.2.1.2.3.5 | 梁/girder/nosači |  | 63d | 2023-09-08 | 2023-11-21 | 1402 | 486d | 0d |  |  |
| 1404 | 3.21.2.1.2.3.6 | 附属工程/auxiliary works/propratni radovi |  | 72d | 2023-10-31 | 2024-03-27 | 1403SS+45d | 486d |  |  |  |
| 1405 | 3.21.2.1.2.3.7 | 顺接地方公路/connect to local road/nastavljanje na lokalni put |  | 150d | 2022-08-05 | 2023-04-01 | 1396SS, 1397SS | 734d |  |  |  |

| ID | WBS | Task | Type | Duration | Start | Finish | Predecessors | Total slack | Free slack | Text10 |
| --- | --- | --- | --- | --- | --- | --- | --- | --- | --- | --- |
| 1406 | 3.21.2.1.3 | **路基工程/subgrade works/radovi na donjem stroju** |  | 364d | 2022-07-01 | 2023-11-08 |  | 17d |  |  |
| 1407 | 3.21.2.1.3.1 | 征地及房屋拆迁，见附件3/For land acquisition and house demolition, see Annex 3/За куповину земљишта и рушење кућа, погледајте Анекс 3 |  | 30d | 2022-07-01 | 2022-08-04 | 1 | 17d | 0d |  |
| 1408 | 3.21.2.1.3.2 | 图纸批复/Approval of drawings |  | 30d | 2022-07-01 | 2022-08-04 | 1 | 17d | 0d |  |
| 1409 | 3.21.2.1.3.3 | 管线迁改，见附件4/Pipeline relocation, see Annex4/Премештање цевовода, видети Анекс 4 |  | 30d | 2022-07-01 | 2022-08-04 | 1 | 17d | 0d |  |
| 1410 | 3.21.2.1.3.4 | **区间路基/open track subgrade/donji stroj na otvorenoj pruzi** |  | 364d | 2022-07-01 | 2023-11-08 |  | 17d |  |  |
| 1411 | 3.21.2.1.3.4.1 | 区间路基/open track subgrade/donji stroj na otvorenoj pruzi |  | 304d | 2022-07-01 | 2023-08-30 | 1394SS, 1391SS, 1407SS, 1408SS, 1409SS | 17d | 0d | KARIN CONFIRM |
| 1412 | 3.21.2.1.3.4.2 | 声屏障/Sound barrier/Zvučna barijera |  | 50d | 2023-07-27 | 2023-09-22 | 1411FF+20d | 590d |  |  |
| 1413 | 3.21.2.1.3.4.3 | 排水工程/Drainage works/Radovi na odvodu |  | 120d | 2023-06-22 | 2023-11-08 | 1411FF+60d | 550d |  |  |
| 1414 | 3.21.2.1.3.4.4 | 接触网基础/OCS Foundation/Temelj kontaktne mreže |  | 110d | 2023-03-15 | 2023-07-26 | 1411FF-30d | 640d |  |  |
| 1415 | 3.21.2.1.3.4.5 | 路基通信、信号过轨管/subgrade undertrack pipes for signalization and telecommunication/okiten cevi za signalizaciju i telekomunikaciju |  | 110d | 2023-02-06 | 2023-06-21 | 1411FF-60d | 670d |  |  |
| 1416 | 3.21.2.2 | **Km162+000~那维切沃站（Km166+519.63,不含） 2023.8.10/Km162+000~Naumovicevo （Km166+519.63, not including ）10.08.2023./Km162+000~stanica Naumovićevo （Km166+519.63, ne ukjlučuje）** |  | 370d | 2022-07-01 | 2023-11-16 |  | 0d |  |  |
| 1417 | 3.21.2.2.1 | 既有轨道拆除/demounting of existing tracks/demontaža postojećih koloseka | milestone | 0d | 2022-07-01 | 2022-07-01 | 1463 | 17d | 0d |  |
| 1418 | 3.21.2.2.2 | Km163+414涵洞/culvert Km163+414/propust Km163+414 |  | 62d | 2022-07-01 | 2022-09-10 | 1417 | 259d |  |  |
| 1419 | 3.21.2.2.3 | **Km163+562上跨立交桥/overpass at Km163+562/nadvožnjak na Km163+562** |  | 368d | 2022-07-01 | 2023-11-14 |  | 0d |  | KARIN CONFIRM |
| 1420 | 3.21.2.2.3.1 | 征地及房屋拆迁，见附件3/For land acquisition and house demolition, see Annex 3/За куповину земљишта и рушење кућа, погледајте Анекс 3 |  | 30d | 2022-07-01 | 2022-08-04 | 1 | 0d |  |  |
| 1421 | 3.21.2.2.3.2 | 图纸批复/Approval of drawings |  | 30d | 2022-07-01 | 2022-08-04 | 1 | 0d |  |  |
| 1422 | 3.21.2.2.3.3 | **桥梁施工/bridge construction/конструкција мостова** |  | 368d | 2022-07-01 | 2023-11-14 |  | 0d |  |  |
| 1423 | 3.21.2.2.3.3.1 | 施工准备/preparation works/pripremni radovi |  | 21d | 2022-07-01 | 2022-07-25 | 1391SS, 1420SS, 1421SS | 0d |  |  |
| 1424 | 3.21.2.2.3.3.2 | 试验桩 |  | 15d | 2022-07-25 | 2022-08-10 | 1423SS+20d | 0d |  |  |
| 1425 | 3.21.2.2.3.3.3 | 桩基/pile/šipovi |  | 84d | 2022-08-11 | 2022-11-17 | 1424 | 0d |  |  |
| 1426 | 3.21.2.2.3.3.4 | 承台/pile caps/nadglavnice |  | 98d | 2022-09-15 | 2023-03-13 | 1425SS+30d | 0d |  |  |
| 1427 | 3.21.2.2.3.3.5 | 墩柱/heavy-duty pier/noseći stubovi |  | 68d | 2023-03-14 | 2023-06-06 | 1426 | 0d |  |  |
| 1428 | 3.21.2.2.3.3.6 | 梁/girder/nosači |  | 90d | 2023-06-07 | 2023-09-19 | 1427 | 0d |  |  |
| 1429 | 3.21.2.2.3.3.7 | 附属工程/auxiliary works/propratni radovi |  | 67d | 2023-08-28 | 2023-11-14 | 1428SS+70d | 546d |  |  |
| 1430 | 3.21.2.2.3.3.8 | 顺接地方公路/connect to local road/nastavljanje na lokalni put |  | 150d | 2022-08-05 | 2023-04-01 | 1420, 1421 | 734d |  |  |

| ID | WBS | Task | Duration | Start | Finish | Predecessors | Total slack | Free slack | Constraint | Text10 |
| --- | --- | --- | --- | --- | --- | --- | --- | --- | --- | --- |
| 1431 | 3.21.2.2.4 | **路基工程/subgrade works/radovi na donjem stroju** | 370d | 2022-07-01 | 2023-11-16 |  | 17d |  |  |  |
| 1432 | 3.21.2.2.4.1 | 征地及房屋拆迁，见附件3/For land acquisition and house demolition, see Annex 3/За куповину земљишта и рушење кућа, погледајте Анекс 3 | 30d | 2022-07-01 | 2022-08-04 | 1 | 17d | 0d |  |  |
| 1433 | 3.21.2.2.4.2 | 图纸批复/Approval of drawings | 30d | 2022-07-01 | 2022-08-04 | 1 | 17d | 0d |  |  |
| 1434 | 3.21.2.2.4.3 | 管线迁改，见附件4/Pipeline relocation, see Annex4/Премештање цевовода, видети Анекс 4 | 30d | 2022-07-01 | 2022-08-04 | 1 | 17d | 0d |  |  |
| 1435 | 3.21.2.2.4.4 | **区间路基/open track subgrade/donji stroj na otvorenoj pruzi** | 370d | 2022-07-01 | 2023-11-16 |  | 17d |  |  |  |
| 1436 | 3.21.2.2.4.4.1 | KM162+000-KM165+000区间路基/open track subgrade/donji stroj na otvorenoj pruzi | 304d | 2022-07-01 | 2023-08-30 | 1417SS, 1391SS, 1432SS, 1433SS, 1434SS | 17d | 0d |  | KARIN CONFIRM |
| 1437 | 3.21.2.2.4.4.2 | 排水工程/Drainage works/Radovi na odvodu | 120d | 2023-06-22 | 2023-11-08 | 1436FF+60d | 550d |  |  |  |
| 1438 | 3.21.2.2.4.4.3 | 接触网基础/OCS Foundation/Temelj kontaktne mreže | 220d | 2023-02-27 | 2023-11-16 | 1297FF | 454d | 0d |  |  |
| 1439 | 3.21.2.2.4.4.4 | 路基通信、信号过轨管/subgrade undertrack pipes for signalization and telecommunication/okiten cevi za signalizaciju i telekomunikaciju | 220d | 2023-02-27 | 2023-11-16 | 1436SS+150d | 544d |  |  |  |
| 1440 | 3.21.3 | **电力电气化工程/Electric power Electrification Engineering/Elektrifikacija i elektroenergetski radovi** | 534d | 2023-05-03 | 2025-06-04 |  | 179d |  |  |  |
| 1441 | 3.21.3.1 | 接触网立柱、腕臂安装/OCS pole and cantilever installation/Postavljanje stubova kontaktne mreže, montaža konzola | 90d | 2023-11-17 | 2024-05-09 | 1438 | 454d |  |  |  |
| 1442 | 3.21.3.2 | 接触网承导线架设/OCS catenary stretching/Razvlačenje kontaktne mreže | 45d | 2024-04-04 | 2024-05-31 | 1882 | 435d |  |  |  |
| 1443 | 3.21.3.3 | 接触网悬挂精调/Fine adjustment of catenary suspension/Fina regulacija voznog voda | 70d | 2025-02-05 | 2025-05-03 | 1944 | 206d |  |  |  |
| 1444 | 3.21.3.4 | 热德尼克分区所房建主体工程/Main building works of Zednik TSPn/Strukturalni radovi na objektu PSN Жедник | 108d | 2023-05-03 | 2023-09-05 |  | 179d | 0d | finish no earlier than 2023-09-05 |  |
| 1445 | 3.21.3.5 | 热德尼克分区所房建装饰工程/Construction and decoration works of Zednik TSPn/Dekoraterski radovi na objektu PSN Жедник | 224d | 2023-09-06 | 2024-08-02 | 1444 | 381d |  | start no earlier than 2023-09-06 |  |
| 1446 | 3.21.3.6 | 变电所亭设备安装/Installation of ETS equipment/Montaža opreme u EVP | 426d | 2023-09-06 | 2025-06-04 | 1444 | 179d |  | start no earlier than 2023-08-07 |  |
| 1447 | 3.21.4 | **通信信号工程/Telecommunication and Signaling works / ТК и СС радови** | 590d | 2023-02-10 | 2025-05-27 |  | 186d |  |  |  |
| 1448 | 3.21.4.1 | 房建工程/Construction & renovation for Equipment house / Радови изградње и реновирању зграда | 280d | 2023-02-10 | 2024-03-16 | 1456SF-130d | 496d | 0d |  |  |
| 1449 | 3.21.4.2 | **SS工程/ Signaling works/ СС радови** | 180d | 2024-08-21 | 2025-05-27 |  | 186d |  |  |  |
| 1450 | 3.21.4.2.1 | 光电缆敷设/ Optical cable laying / Полагање оптичких каблова | 90d | 2024-08-21 | 2025-02-05 | 1451SF | 275d | 0d | start no earlier than 2023-05-10 |  |
| 1451 | 3.21.4.2.2 | 轨旁设备安装/ Trackside equipment mounting / Уградња пружних уређаја | 60d | 2025-02-05 | 2025-04-16 | 1944 | 186d | 0d |  |  |
| 1452 | 3.21.4.2.3 | 信号设备调试/ Testing of the station SS equipment/ Тестирање станичне СС опреме | 60d | 2025-03-13 | 2025-05-27 | 1451FS-30d | 186d |  |  |  |
| 1453 | 3.21.4.3 | **TT工程/ Telecommunication works / ТТ радови** | 510d | 2023-05-23 | 2025-05-27 |  | 186d |  |  |  |
| 1454 | 3.21.4.3.1 | 光电缆敷设/ Optical cable laying / Полагање оптичких каблова | 91d | 2024-08-21 | 2025-02-05 | 1450SS | 275d | 0d |  |  |
| 1455 | 3.21.4.3.2 | 轨旁设备安装/ Trackside equipment mounting / Уградња пружних уређаја | 60d | 2025-02-05 | 2025-04-16 | 1451SS | 186d | 0d |  |  |
| 1456 | 3.21.4.3.3 | 室内设备安装/ Indoor equipment mounting (at station) / Монтажа унутрашње опреме (у станици) | 91d | 2024-08-21 | 2025-02-05 | 1454SS | 275d | 0d |  |  |
| 1457 | 3.21.4.3.4 | 铁塔工程/Communication tower works/ Радови на ТК стубовима | 200d | 2023-05-23 | 2024-03-16 | 1448FF | 496d |  |  |  |
| 1458 | 3.21.4.3.5 | TK设备调试/ Testing of the station TK equipment/ Тестирање станичне TK опреме | 60d | 2025-03-13 | 2025-05-27 | 1455FS-30d | 186d |  |  |  |

| ID | WBS | Task | Type | Duration | Start | Finish | Predecessors | Total slack | Free slack | Text10 |
| --- | --- | --- | --- | --- | --- | --- | --- | --- | --- | --- |
| 1459 | 3.22 | **那维切沃站（Km165+943-Km167+585,基地） 2023.1.31/Naumovicevo station （Km165+943-Km167+585, base)/Stanica Naumovićevo（Km165+943-Km167+585, baza )** |  | 800d | 2022-07-01 | 2025-08-19 |  | 17d |  |  |
| 1460 | 3.22.1 | 交付土地/Land handover and access permit/Primopredaja zemljišta i pristupna dozvola | milestone | 0d | 2022-07-01 | 2022-07-01 |  | 69d | 0d |  |
| 1461 | 3.22.2 | **土建工程/civil engineering works/zemljani radovi** |  | 300d | 2022-07-01 | 2023-08-25 |  | 17d |  |  |
| 1462 | 3.22.2.1 | **那维切沃站（Km165+943-Km167+585,基地） 2023.1.31/Naumovicevo station （Km165+943-Km167+585, base)/Stanica Naumovićevo（Km165+943-Km167+585, baza )** |  | 300d | 2022-07-01 | 2023-08-25 |  | 17d |  |  |
| 1463 | 3.22.2.1.1 | 既有轨道拆除/demounting of existing tracks/demontaža postojećih koloseka | milestone | 0d | 2022-07-01 | 2022-07-01 | 1 | 17d | 0d |  |
| 1464 | 3.22.2.1.2 | **纳维彻沃站/Naumovicevo station/Stanica Naumovićevo** |  | 300d | 2022-07-01 | 2023-08-25 |  | 614d |  |  |
| 1465 | 3.22.2.1.2.1 | 征地及房屋拆迁，见附件3/For land acquisition and house demolition, see Annex 3/За куповину земљишта и рушење кућа, погледајте Анекс 3 |  | 30d | 2022-08-05 | 2022-09-08 | 1FS+30d | 854d |  |  |
| 1466 | 3.22.2.1.2.2 | 图纸批复/Approval of drawings |  | 30d | 2022-08-05 | 2022-09-08 | 1FS+30d | 614d | 0d |  |
| 1467 | 3.22.2.1.2.3 | 管线迁改，见附件4/Pipeline relocation, see Annex4/Премештање цевовода, видети Анекс 4 |  | 30d | 2022-07-01 | 2022-08-04 | 1460, 1463 | 884d |  |  |
| 1468 | 3.22.2.1.2.4 | **车站施工/station construction/изградња станице** |  | 290d | 2022-07-13 | 2023-08-25 |  | 614d |  |  |
| 1469 | 3.22.2.1.2.4.1 | 进站道路1500m/Access road 1500m/Prilazni put 1500m |  | 90d | 2023-02-01 | 2023-05-24 | 1482 | 664d | 0d |  |
| 1470 | 3.22.2.1.2.4.2 | 房屋建筑（装修）/Building construction (renovation)/izgradnja objekta (renoviranje) |  | 150d | 2022-09-09 | 2023-05-12 | 1466 | 614d | 0d |  |
| 1471 | 3.22.2.1.2.4.3 | 车站标志/Station signs/Stanični znakovi |  | 30d | 2023-05-25 | 2023-06-28 | 1476, 1469 | 664d |  |  |
| 1472 | 3.22.2.1.2.4.4 | 电梯/Elevator/Lift |  | 120d | 2022-07-13 | 2022-12-31 | 1475FF | 784d |  |  |
| 1473 | 3.22.2.1.2.4.5 | 消防设施/Fire fighting facilities/Protivpožarni objekti |  | 90d | 2023-05-13 | 2023-08-25 | 1470 | 614d |  |  |
| 1474 | 3.22.2.1.2.4.6 | 车站排水工程/Drainage works/Radovi na odvodu |  | 120d | 2023-02-27 | 2023-07-21 | 1470FF+60d | 644d |  |  |
| 1475 | 3.22.2.1.2.4.7 | 旅客通道/Passenger passage/Putnički prolaz |  | 126ed | 2022-08-27 | 2022-12-31 | 1482SS+40d | 2974.88d | 0d |  |
| 1476 | 3.22.2.1.2.4.8 | 站台雨蓬/Platform canopy/nadsteršnica na peronu |  | 126ed | 2022-11-05 | 2023-03-11 | 1460, 1463, 1475SS+60d | 2974.88d | 223.88d |  |
| 1477 | 3.22.2.1.3 | **路基工程/subgrade works/radovi na donjem stroju** |  | 130d | 2022-07-01 | 2022-12-31 |  | 59d |  |  |
| 1478 | 3.22.2.1.3.1 | 征地及房屋拆迁，见附件3/For land acquisition and house demolition, see Annex 3/За куповину земљишта и рушење кућа, погледајте Анекс 3 | milestone | 0d | 2022-07-01 | 2022-07-01 | 1 | 69d | 10d |  |
| 1479 | 3.22.2.1.3.2 | 图纸批复/Approval of drawings | milestone | 0d | 2022-07-01 | 2022-07-01 | 1 | 69d | 10d |  |
| 1480 | 3.22.2.1.3.3 | 管线迁改，见附件4/Pipeline relocation, see Annex4/Премештање цевовода, видети Анекс 4 |  | 10d | 2022-07-01 | 2022-07-12 | 1 | 59d | 0d |  |
| 1481 | 3.22.2.1.3.4 | **车站路基/Station Subgrade/donji stroj u stanici** |  | 120d | 2022-07-12 | 2022-12-31 |  | 59d |  |  |
| 1482 | 3.22.2.1.3.4.1 | KM165+000-KM167+585路基/Station Subgrade/donji stroj u stanici |  | 172ed | 2022-07-12 | 2022-12-31 | 1460, 1463, 1478, 1479, 1480 | 208.88d | 0d | KARIN CONFIRM |
| 1483 | 3.22.2.1.3.4.2 | 接触网基础/OCS Foundation/Temelj kontaktne mreže |  | 10ed | 2022-12-21 | 2022-12-31 | 1482FF | 763.88d | 0d |  |

| ID | WBS | Task | Type | Duration | Start | Finish | Predecessors | Total slack | Free slack | Constraint | Text10 |
| --- | --- | --- | --- | --- | --- | --- | --- | --- | --- | --- | --- |
| 1484 | 3.22.3 | **电力电气化工程/Electric power Electrification Engineering/Elektrifikacija i elektroenergetski radovi** |  | 627d | 2023-02-01 | 2025-06-30 |  | 157d |  |  |  |
| 1485 | 3.22.3.1 | 接触网立柱、腕臂安装/OCS pole and cantilever installation/Postavljanje stubova kontaktne mreže, montaža konzola |  | 84d | 2023-02-01 | 2023-05-17 | 1483 | 700d |  |  |  |
| 1486 | 3.22.3.2 | 接触网承导线架设/OCS catenary stretching/Razvlačenje kontaktne mreže |  | 45d | 2024-04-04 | 2024-05-31 | 1882 | 125d | 0d |  |  |
| 1487 | 3.22.3.3 | 接触网悬挂精调/Fine adjustment of catenary suspension/Fina regulacija voznog voda |  | 47d | 2025-05-07 | 2025-06-30 | 1945 | 157d |  |  |  |
| 1488 | 3.22.3.4 | 配电室改造/Transformation of distribution room/Rekonstrukcija distributivno transformatorske stanice |  | 35d | 2023-07-01 | 2023-08-10 | 1470 | 627d |  | finish no earlier than 2023-08-10 |  |
| 1489 | 3.22.3.5 | 室内电气安装 /Indoor electrical installation/Unutrašnja elektroinstalacija |  | 157d | 2023-02-13 | 2023-08-22 | 1470SF | 617d |  | start no earlier than 2023-02-13 |  |
| 1490 | 3.22.3.6 | 车站照明设备安装/Installation of station lighting equipment /Montaža stanične rasvete |  | 133d | 2023-02-13 | 2023-07-25 | 1476SS | 641d |  | start no earlier than 2023-02-13 |  |
| 1491 | 3.22.3.7 | 变电室外设备安装/Installation of outdoor equipment of Substation/Montaža spoljašnje opreme distributivno transformatorske stanice | manual | 310d | 2024-04-05 | 2025-06-16 | 1486 |  |  | start no earlier than 2023-08-08 |  |
| 1492 | 3.22.4 | **通信信号工程/Telecommunication and Signaling works / ТК и СС радови** |  | 640d | 2023-03-10 | 2025-08-19 |  | 114d |  |  |  |
| 1493 | 3.22.4.1 | 房建工程/Construction & renovation for Equipment house / Радови изградње и реновирању зграда |  | 260d | 2023-03-10 | 2024-03-19 | 1497SF-200d | 494d | 0d |  |  |
| 1494 | 3.22.4.2 | **SS工程/ Signaling works/ СС радови** |  | 180d | 2024-11-14 | 2025-08-19 |  | 114d |  |  |  |
| 1495 | 3.22.4.2.1 | 光电缆敷设/ Optical cable laying / Полагање оптичких каблова |  | 90d | 2024-11-14 | 2025-05-07 | 1496SF | 114d | 0d | start no earlier than 2023-05-10 |  |
| 1496 | 3.22.4.2.2 | 轨旁设备安装/ Trackside equipment mounting / Уградња пружних уређаја |  | 60d | 2025-05-07 | 2025-07-15 | 1945 | 114d | 0d |  |  |
| 1497 | 3.22.4.2.3 | 室内设备安装/ Indoor equipment mounting (at station) / Монтажа унутрашње опреме (у станици) |  | 90d | 2024-11-14 | 2025-05-06 | 1495SS | 204d | 0d | start no earlier than 2022-10-08 |  |
| 1498 | 3.22.4.2.4 | 信号设备调试/ Testing of the station SS equipment/ Тестирање станичне СС опреме |  | 60d | 2025-06-11 | 2025-08-19 | 1496FS-30d | 114d |  |  |  |
| 1499 | 3.22.4.3 | **TT工程/ Telecommunication works / ТТ радови** |  | 580d | 2023-05-25 | 2025-08-19 |  | 114d |  |  |  |
| 1500 | 3.22.4.3.1 | 光电缆敷设/ Optical cable laying / Полагање оптичких каблова |  | 90d | 2024-11-14 | 2025-05-06 | 1495SS | 114d | 0d |  |  |
| 1501 | 3.22.4.3.2 | 综合布线/ Integrated cabling system / структурно каблирање |  | 90d | 2023-09-30 | 2024-03-19 | 1493FF | 494d |  | start no earlier than 2022-09-08 |  |
| 1502 | 3.22.4.3.3 | 站内通信信息设备安装/Installation of telecommunication and information equipment in the station / Уградња телекомуникационе и информационе опреме у станици |  | 150d | 2024-11-14 | 2025-07-15 | 1500SS | 114d | 0d | finish no earlier than 2023-07-24 |  |
| 1503 | 3.22.4.3.4 | 铁塔工程/Communication tower works/ Радови на ТК стубовима |  | 200d | 2023-05-25 | 2024-03-19 | 1493FF | 494d |  | finish no earlier than 2023-07-24 |  |
| 1504 | 3.22.4.3.5 | TK设备调试/ Testing of the station TK equipment/ Тестирање станичне TK опреме |  | 60d | 2025-06-11 | 2025-08-19 | 1502FS-30d | 114d |  |  |  |
| 1505 | 3.23 | **那维切沃站（Km165+943）~苏博蒂察站（Km176+550，不含）/Naumovicevo station （Km165+943) ~ Subotica station (Km176+550, not included)/stanica Naumovićevo （Km165+943)~stanica Subotca （Km176+550，ne uključuje）** |  | 800d? | 2022-07-01 | 2025-08-19 |  | 114d |  |  |  |
| 1506 | 3.23.1 | 土地移交，进场许可/land is transfered, entrance allowed/zemljište je predato, dozvoljen ulazak na gradilište | milestone | 0d | 2022-07-01 | 2022-07-01 | 1 | 204d | 0d |  |  |
| 1507 | 3.23.2 | **土建工程/civil engineering works/zemljani radovi** |  | 428d | 2022-07-01 | 2024-03-27 |  | 204d |  |  |  |
| 1508 | 3.23.2.1 | **那维切沃站（Km167+585）~Km172+000 2023.12.15/Naumovicevo station （Km167+585）~Km172+000 15.12.2023./stanica Naumovićevo （Km167+585）~Km172+000 15.12.2023.** |  | 428d | 2022-07-01 | 2024-03-27 |  | 204d |  |  |  |
| 1509 | 3.23.2.1.1 | **Km168+690上跨立交桥/Km168+690 overpass/Km168+690 nadvožnjak** |  | 398d | 2022-08-05 | 2024-03-27 |  | 236d |  |  | KARIN CONFIRM |
| 1510 | 3.23.2.1.1.1 | 征地及房屋拆迁，见附件3/For land acquisition and house demolition, see Annex 3/За куповину земљишта и рушење кућа, погледајте Анекс 3 |  | 30d | 2022-08-05 | 2022-09-08 | 1FS+30d | 236d | 14d |  |  |
| 1511 | 3.23.2.1.1.2 | 图纸批复/Approval of drawings |  | 30d | 2022-08-05 | 2022-09-08 | 1FS+30d | 236d | 14d |  |  |

| ID | WBS | Task | Type | Duration | Start | Finish | Predecessors | Total slack | Free slack | Text10 |
| --- | --- | --- | --- | --- | --- | --- | --- | --- | --- | --- |
| 1512 | 3.23.2.1.1.3 | **桥梁施工/bridge construction/конструкција мостова** |  | 354d | 2022-09-26 | 2024-03-27 |  | 222d |  |  |
| 1513 | 3.23.2.1.1.3.1 | 施工准备/preparation works/pripremni radovi |  | 17d | 2022-09-26 | 2022-10-14 | 1546, 1506, 1510, 1511 | 222d | 27d |  |
| 1514 | 3.23.2.1.1.3.2 | 桩基/pile/šipovi |  | 64ed | 2022-11-29 | 2023-02-01 | 1513FS+38d | 988.88d | 1.88d |  |
| 1515 | 3.23.2.1.1.3.3 | 承台/pile caps/nadglavnice |  | 100ed | 2023-04-10 | 2023-07-19 | 1514SS+58d | 991.88d | 0d |  |
| 1516 | 3.23.2.1.1.3.4 | 墩柱/heavy-duty pier/noseći stubovi |  | 70ed | 2023-07-19 | 2023-09-27 | 1515 | 991.88d | 1.88d |  |
| 1517 | 3.23.2.1.1.3.5 | 梁/girder/nosači |  | 60d | 2023-10-21 | 2024-03-04 | 1516SS+80d | 222d | 0d |  |
| 1518 | 3.23.2.1.1.3.6 | 附属工程/auxiliary works/propratni radovi |  | 50d | 2023-11-27 | 2024-03-27 | 1517SS+30d | 486d |  |  |
| 1519 | 3.23.2.1.1.3.7 | 顺接地方公路/connect to local road/nastavljanje na lokalni put |  | 30ed | 2024-02-07 | 2024-03-08 | 1517SS+40d | 1989d |  |  |
| 1520 | 3.23.2.1.2 | **Km170+834上跨立交桥双绕/Km170+834 overpass/Km170+834 nadvožnjak** |  | 382d | 2022-07-01 | 2023-12-04 |  | 246d |  | KARIN CONFIRM |
| 1521 | 3.23.2.1.2.1 | 征地及房屋拆迁，见附件3/For land acquisition and house demolition, see Annex 3/За куповину земљишта и рушење кућа, погледајте Анекс 3 |  | 30d | 2022-07-01 | 2022-08-04 | 1 | 246d | 0d |  |
| 1522 | 3.23.2.1.2.2 | 图纸批复/Approval of drawings | milestone | 0d | 2022-07-01 | 2022-07-01 | 1 | 246d | 0d |  |
| 1523 | 3.23.2.1.2.3 | **桥梁施工/bridge construction/конструкција мостова** |  | 382d | 2022-07-01 | 2023-12-04 |  | 246d |  |  |
| 1524 | 3.23.2.1.2.3.1 | 试验桩 |  | 28d | 2022-07-01 | 2022-08-02 | 1521SS, 1522SS | 246d | 9.12d |  |
| 1525 | 3.23.2.1.2.3.2 | 桩基/pile/šipovi |  | 130ed | 2022-08-17 | 2022-12-25 | 1524FS+13d | 1075.88d | 0d |  |
| 1526 | 3.23.2.1.2.3.3 | 承台/pile caps/nadglavnice |  | 104ed | 2022-12-25 | 2023-04-08 | 1525 | 1075.88d | 0d |  |
| 1527 | 3.23.2.1.2.3.4 | 墩柱/heavy-duty pier/noseći stubovi |  | 77ed | 2023-04-08 | 2023-06-24 | 1526 | 1075.88d | 145d |  |
| 1528 | 3.23.2.1.2.3.5 | 梁/girder/nosači |  | 108ed | 2023-06-12 | 2023-09-28 | 1527SS+50d | 1072.88d | 203d |  |
| 1529 | 3.23.2.1.2.3.6 | 附属工程/auxiliary works/propratni radovi |  | 80ed | 2023-09-15 | 2023-12-04 | 1528SS+82d | 1072.88d | 588d |  |
| 1530 | 3.23.2.1.2.4 | 顺接地方公路/connect to local road/nastavljanje na lokalni put |  | 180d | 2022-08-05 | 2023-05-12 | 1521, 1522 | 704d |  |  |
| 1531 | 3.23.2.1.3 | **路基工程/subgrade works/radovi na donjem stroju** |  | 220d | 2022-07-01 | 2023-05-24 |  | 204d |  |  |
| 1532 | 3.23.2.1.3.1 | 征地及房屋拆迁，见附件3/For land acquisition and house demolition, see Annex 3/За куповину земљишта и рушење кућа, погледајте Анекс 3 |  | 30d | 2022-07-01 | 2022-08-04 | 1 | 204d | 0d |  |
| 1533 | 3.23.2.1.3.2 | 图纸批复/Approval of drawings | milestone | 0d | 2022-07-01 | 2022-07-01 | 1 | 204d | 0d |  |
| 1534 | 3.23.2.1.3.3 | 管线迁改，见附件4/Pipeline relocation, see Annex4/Премештање цевовода, видети Анекс 4 |  | 30d | 2022-07-01 | 2022-08-04 | 1506 | 204d | 0d |  |
| 1535 | 3.23.2.1.3.4 | **路基工程/subgrade works/radovi na donjem stroju** |  | 220d | 2022-07-01 | 2023-05-24 |  | 204d |  |  |
| 1536 | 3.23.2.1.3.4.1 | 区间路基/open track subgrade/donji stroj na otvorenoj pruzi |  | 190d | 2022-07-01 | 2023-04-13 | 1506SS, 1532SS, 1533SS, 1534SS | 204d | 0d | KARIN CONFIRM |
| 1537 | 3.23.2.1.3.4.2 | 排水工程/Drainage works/Radovi na odvodu |  | 80d | 2022-11-07 | 2023-04-13 | 1536FF | 724d |  |  |
| 1538 | 3.23.2.1.3.4.3 | 接触网基础/OCS Foundation/Temelj kontaktne mreže |  | 80d | 2023-02-13 | 2023-05-24 | 1536FF+30d | 604d | 0d |  |
| 1539 | 3.23.2.1.3.4.4 | 路基通信、信号过轨管/subgrade undertrack pipes for signalization and telecommunication/okiten cevi za signalizaciju i telekomunikaciju |  | 80d | 2022-11-19 | 2023-04-28 | 1536SS+120d | 714d |  |  |

| ID | WBS | Task | Type | Duration | Start | Finish | Predecessors | Total slack | Free slack | Constraint | Text10 |
| --- | --- | --- | --- | --- | --- | --- | --- | --- | --- | --- | --- |
| 1540 | 3.23.2.2 | **Km172+000~苏博蒂察站（Km174+174，不含） 2024.1.20/Km172+000~ Subotica station (km 174 + 174,not including) 20.1.2024./Km172+000~stanica Subotica (km174 +174, ne uključuje)** |  | 344d | 2022-07-01 | 2023-10-16 |  | 222d |  |  |  |
| 1541 | 3.23.2.2.1 | **Km172+193上跨立交桥双绕/Km172+193 overpass/Km172+193 nadvožnjak** |  | 344d | 2022-07-01 | 2023-10-16 |  | 222d |  |  | KARIN CONFIRM |
| 1542 | 3.23.2.2.1.1 | 征地及房屋拆迁，见附件3/For land acquisition and house demolition, see Annex 3/За куповину земљишта и рушење кућа, погледајте Анекс 3 |  | 30d | 2022-07-01 | 2022-08-04 | 1 | 222d | 0d |  |  |
| 1543 | 3.23.2.2.1.2 | 图纸批复/Approval of drawings | milestone | 0d | 2022-07-01 | 2022-07-01 | 1 | 222d | 0d |  |  |
| 1544 | 3.23.2.2.1.3 | **桥梁施工/bridge construction/конструкција мостова** |  | 324d | 2022-07-01 | 2023-09-22 |  | 222d |  |  |  |
| 1545 | 3.23.2.2.1.3.1 | 施工准备/preparation works/pripremni radovi |  | 17d | 2022-07-01 | 2022-07-20 | 1506SS, 1542SS, 1543SS | 222d | 0d | start no earlier than 2022-04-05 |  |
| 1546 | 3.23.2.2.1.3.2 | 桩基/pile/šipovi |  | 57d | 2022-07-21 | 2022-09-24 | 1545 | 222d | 0d |  |  |
| 1547 | 3.23.2.2.1.3.3 | 承台/pile caps/nadglavnice |  | 80d | 2022-09-29 | 2023-03-06 | 1546SS+60d | 306d | 0d |  |  |
| 1548 | 3.23.2.2.1.3.4 | 墩柱/heavy-duty pier/noseći stubovi |  | 58d | 2023-03-07 | 2023-05-18 | 1547 | 306d | 0d |  |  |
| 1549 | 3.23.2.2.1.3.5 | 梁/girder/nosači |  | 72d | 2023-05-19 | 2023-08-10 | 1548 | 306d | 0d |  |  |
| 1550 | 3.23.2.2.1.3.6 | 附属工程/auxiliary works/propratni radovi |  | 59d | 2023-07-17 | 2023-09-22 | 1549SS+50d | 306d | 0d |  |  |
| 1551 | 3.23.2.2.1.4 | 顺接地方公路/connect to local road/nastavljanje na lokalni put |  | 190d | 2023-03-03 | 2023-10-16 | 1550FF+20d | 570d |  |  |  |
| 1552 | 3.23.2.2.2 | Km173+629涵洞1-4.0m双绕/km 173+629 culvert 1-4.0/km 173+629 propust 1-4.0 |  | 60d | 2023-07-11 | 2023-09-18 | 1558, 1506 | 594d |  | start no earlier than 2022-06-01 |  |
| 1553 | 3.23.2.2.3 | **路基工程/subgrade works/radovi na donjem stroju** |  | 340d | 2022-07-01 | 2023-10-11 |  | 400d |  |  |  |
| 1554 | 3.23.2.2.3.1 | 征地及房屋拆迁，见附件3/For land acquisition and house demolition, see Annex 3/За куповину земљишта и рушење кућа, погледајте Анекс 3 |  | 30d | 2022-08-05 | 2022-09-08 | 1FS+30d | 370d | 0d |  |  |
| 1555 | 3.23.2.2.3.2 | 图纸和施工方案的批复/Approval of drawings and Method Statement/Одобрење цртежа и Изјава о методи |  | 30d | 2022-08-05 | 2022-09-08 | 1FS+30d | 370d | 0d |  |  |
| 1556 | 3.23.2.2.3.3 | 管线迁改，见附件4/Pipeline relocation, see Annex4/Премештање цевовода, видети Анекс 4 |  | 30d | 2022-07-01 | 2022-08-04 | 1460, 1463 | 400d | 30d |  |  |
| 1557 | 3.23.2.2.3.4 | **区间路基/open track subgrade/donji stroj na otvorenoj pruzi** |  | 280d | 2022-09-09 | 2023-10-11 |  | 370d |  |  |  |
| 1558 | 3.23.2.2.3.4.1 | 区间路基/open track subgrade/donji stroj na otvorenoj pruzi |  | 200d | 2022-09-09 | 2023-07-10 | 1536SS+60d, 1506, 1554, 1555, 1556 | 370d | 0d |  | KARIN CONFIRM |
| 1559 | 3.23.2.2.3.4.2 | 声屏障/Sound barrier/Zvučna barijera |  | 30d | 2023-07-11 | 2023-08-14 | 1558 | 624d |  |  |  |
| 1560 | 3.23.2.2.3.4.3 | 排水工程/Drainage works/Radovi na odvodu |  | 120d | 2023-03-22 | 2023-08-14 | 1558FF+30d | 624d |  |  |  |
| 1561 | 3.23.2.2.3.4.4 | 接触网基础/OCS Foundation/Temelj kontaktne mreže |  | 110d | 2023-02-27 | 2023-07-10 | 1558FF | 654d |  |  |  |
| 1562 | 3.23.2.2.3.4.5 | 路基通信、信号过轨管/subgrade undertrack pipes for signalization and telecommunication/okiten cevi za signalizaciju i telekomunikaciju |  | 220d | 2022-11-19 | 2023-10-11 | 1558SS+60d | 574d |  |  |  |
| 1563 | 3.23.3 | **电力电气化工程/Electric power Electrification Engineering/Elektrifikacija i elektroenergetski radovi** |  | 757d? | 2022-07-01 | 2025-06-30 |  | 157d |  |  |  |
| 1564 | 3.23.3.1 | 接触网立柱、腕臂安装/OCS pole and cantilever installation/Postavljanje stubova kontaktne mreže, montaža konzola |  | 90d | 2023-05-25 | 2023-09-06 | 1538 | 604d |  |  |  |
| 1565 | 3.23.3.2 | 接触网承导线架设/OCS catenary stretching/Razvlačenje kontaktne mreže |  | 50d | 2024-09-13 | 2024-11-09 | 1884 | 296d |  |  |  |
| 1566 | 3.23.3.3 | 接触网悬挂精调/Fine adjustment of catenary suspension/Fina regulacija voznog voda |  | 47d | 2025-05-07 | 2025-06-30 | 1945 | 157d |  |  |  |
| 1567 | 3.23.3.4 | 前置条件：苏博蒂察变电所停电2023年10月停电Precondition: Subotica substation power outage in October 2023 /Предуслов: Искључење напона у ЕВП Суботица у октобру 2023. године |  | 1d? | 2022-07-01 | 2022-07-01 |  | 913d |  |  |  |
| 1568 | 3.23.3.5 | 苏博蒂察变电所房建主体工程/Main building works of Subotica ETS/Strukturalni radovi na objektu EVP Subotica |  | 155d | 2023-11-01 | 2024-07-09 |  | 162d | 0d | start no earlier than 2023-11-01 |  |
| 1569 | 3.23.3.6 | 苏博蒂察变电所房建装饰工程/Decoration works of Subotica ETS/Dekoraterski radovi na objektu EVP Subotica |  | 122d | 2024-07-10 | 2024-11-29 | 1568 | 280d | 0d | finish no earlier than 2024-06-29 |  |
| 1570 | 3.23.3.7 | 室内电气安装 /Indoor electrical installation/Unutrašnja elektroinstalacija |  | 152d | 2023-11-04 | 2024-07-10 | 1569SF | 402d |  | finish no earlier than 2024-07-05 |  |
| 1571 | 3.23.3.8 | 变电所亭设备安装/Installation of ETS equipment/Montaža opreme u EVP |  | 240d | 2024-07-16 | 2025-06-30 | 1568 | 157d |  | finish no earlier than 2025-06-30 |  |
| 1572 | 3.23.3.9 | 电力迁改110kv/Electricity relocation 110kv/Izmeštanje kablova 110kV |  | 77d | 2023-09-01 | 2023-11-30 |  | 532d |  | start no earlier than 2023-09-01 |  |

| ID | WBS | Task | Duration | Start | Finish | Predecessors | Total slack | Free slack | Constraint |
| --- | --- | --- | --- | --- | --- | --- | --- | --- | --- |
| 1573 | 3.23.4 | **通信信号工程/Telecommunication and Signaling works / ТК и СС радови** | 660d | 2023-02-13 | 2025-08-19 |  | 114d |  |  |
| 1574 | 3.23.4.1 | 房建工程/Construction & renovation for Equipment house / Радови изградње и реновирању зграда | 280d | 2023-02-13 | 2024-03-19 | 1582SF-200d | 494d | 0d |  |
| 1575 | 3.23.4.2 | **SS工程/ Signaling works/ СС радови** | 180d | 2024-11-14 | 2025-08-19 |  | 114d |  |  |
| 1576 | 3.23.4.2.1 | 光电缆敷设/ Optical cable laying / Полагање оптичких каблова | 90d | 2024-11-14 | 2025-05-07 | 1577SF | 204d | 0d | start no earlier than 2023-05-10 |
| 1577 | 3.23.4.2.2 | 轨旁设备安装/ Trackside equipment mounting / Уградња пружних уређаја | 60d | 2025-05-07 | 2025-07-15 | 1945 | 114d | 0d |  |
| 1578 | 3.23.4.2.3 | 信号设备调试/ Testing of the station SS equipment/ Тестирање станичне СС опреме | 60d | 2025-06-11 | 2025-08-19 | 1577FS-30d | 114d |  |  |
| 1579 | 3.23.4.3 | **TT工程/ Telecommunication works / ТТ радови** | 580d | 2023-05-25 | 2025-08-19 |  | 114d |  |  |
| 1580 | 3.23.4.3.1 | 光电缆敷设/ Optical cable laying / Полагање оптичких каблова | 90d | 2024-11-14 | 2025-05-06 | 1576SS | 204d |  |  |
| 1581 | 3.23.4.3.2 | 轨旁设备安装/ Trackside equipment mounting / Уградња пружних уређаја | 60d | 2025-05-07 | 2025-07-15 | 1577SS | 114d | 0d |  |
| 1582 | 3.23.4.3.3 | 室内设备安装/ Indoor equipment mounting (at station) / Монтажа унутрашње опреме (у станици) | 150d | 2024-11-14 | 2025-07-15 | 1581FF | 144d | 0d |  |
| 1583 | 3.23.4.3.4 | 铁塔工程/Communication tower works/ Радови на ТК стубовима | 200d | 2023-05-25 | 2024-03-19 | 1574FF | 494d |  |  |
| 1584 | 3.23.4.3.5 | TK设备调试/ Testing of the station TK equipment/ Тестирање станичне TK опреме | 60d | 2025-06-11 | 2025-08-19 | 1581FS-30d | 114d |  |  |
| 1585 | 3.24 | **苏博蒂察站（Km174+174-Km178+000）2023.12.31/subotica station （Km174+174-Km178+000）2023.12.31/stanica Subotica (Km174+174-Km178+000）31.12.2023.** | 810d | 2022-07-01 | 2025-08-30 |  | 0d |  |  |
| 1586 | 3.24.1 | **前置条件/preconditions/preduslovi** | 27d | 2022-07-01 | 2022-08-01 |  | 376d | 80d |  |
| 1587 | 3.24.1.1 | 那维彻沃-边境段铁路停电/Power outage on the Naumovićevo-border section of the railway/Нестанак струје на деоници пруге Наумовићево-гранична | 27d | 2022-07-01 | 2022-08-01 |  | 376d |  |  |
| 1588 | 3.24.1.2 | 交付土地/land transmission/predaja zemljišta | 27d | 2022-07-01 | 2022-08-01 |  | 376d |  |  |
| 1589 | 3.24.2 | **第一步（货场左、右场区、客场右半幅、线下结构）/first step (right and left part of freight yard, right half of passanger yard,)** | 403d | 2022-07-01 | 2024-02-27 |  | 0d |  |  |
| 1590 | 3.24.2.1 | **土建工程/ground works/građevinski radovi** | 393d | 2022-07-01 | 2024-02-13 |  | 0d |  |  |
| 1591 | 3.24.2.1.1 | 征地及房屋拆迁，见附件3/For land acquisition and house demolition, see Annex 3/За куповину земљишта и рушење кућа, погледајте Анекс 3 | 30d | 2022-07-01 | 2022-08-04 | 1 | 884d |  |  |
| 1592 | 3.24.2.1.2 | 图纸批复/Approval of drawings | 30d | 2022-07-01 | 2022-08-04 | 1 | 884d |  |  |
| 1593 | 3.24.2.1.3 | 业主站场内旧枕木、旧钢轨清除完毕 | 15d | 2022-07-01 | 2022-07-18 | 1 | 899d |  |  |
| 1594 | 3.24.2.1.4 | **Km174+515下穿通道/km 174+515 Underpass/km174+515 Podvožnjak** | 179d | 2022-07-01 | 2023-03-31 |  | 0d |  |  |
| 1595 | 3.24.2.1.4.1 | 管线迁改/Pipeline relocation/Премештање цевовода | 92d | 2022-07-01 | 2022-10-15 | 1 | 822d |  |  |
| 1596 | 3.24.2.1.4.2 | 征地赔偿完毕/Compensation for land acquisition completed/Надокнада за откуп земљишта завршена | 6d | 2022-07-01 | 2022-07-07 | 1 | 0d |  |  |
| 1597 | 3.24.2.1.4.3 | 桥梁施工/bridge construction/конструкција мостова | 173d | 2022-07-08 | 2023-03-31 | 1596 | 0d |  |  |

| ID | WBS | Task | Duration | Start | Finish | Predecessors | Total slack | Free slack | Constraint |
| --- | --- | --- | --- | --- | --- | --- | --- | --- | --- |
| 1598 | 3.24.2.1.5 | **Km174+928下穿通道** | 378d | 2022-07-01 | 2023-11-25 |  | 252d |  |  |
| 1599 | 3.24.2.1.5.1 | 管线迁改/Pipeline relocation/Премештање цевовода | 130d | 2022-07-01 | 2022-11-30 | 1 | 252d | 0d |  |
| 1600 | 3.24.2.1.5.2 | 征地赔偿完毕/Compensation for land acquisition completed/Надокнада за откуп земљишта завршена | 27d | 2022-07-01 | 2022-08-01 | 1 | 887d |  |  |
| 1601 | 3.24.2.1.5.3 | 桥梁施工/bridge construction/конструкција мостова | 248d | 2023-02-01 | 2023-11-25 | 1599 | 252d | 115d |  |
| 1602 | 3.24.2.1.6 | **货运站右场、左场改建/renovation of right and middle side of marshalling yard/renoviranje desne strane ranžirne stanice** | 294d | 2022-08-20 | 2023-10-07 |  | 82d | 0d |  |
| 1603 | 3.24.2.1.6.1 | 封锁并拆除既有1-10道、19-25、25a道/closing and dismantling existing tracks 16-25/zatvor i demontaža postojećih koloseka 16-25 | 30d | 2022-08-20 | 2022-09-23 |  | 82d | 0d | start no earlier than 2022-08-20 |
| 1604 | 3.24.2.1.6.2 | 路基换填/subgrade replacement/zamena tla donjecg stroja | 140d | 2022-09-24 | 2023-05-16 | 1603 | 82d | 0d |  |
| 1605 | 3.24.2.1.6.3 | 路基检测/subgrade testing/ispitivanje donjeg storja | 5d | 2023-05-17 | 2023-05-22 | 1604 | 82d | 0d |  |
| 1606 | 3.24.2.1.6.4 | 底层道砟铺设/ballast laying/razastiranje tucanika | 50d | 2023-05-23 | 2023-07-19 | 1605 | 82d | 0d |  |
| 1607 | 3.24.2.1.6.5 | 接触网基础/OCS Foundation/Temelj kontaktne mreže | 90d | 2023-02-04 | 2023-05-27 | 1604FF+10d | 196d | 0d |  |
| 1608 | 3.24.2.1.6.6 | 顶层道砟铺设/Top layer ballast laying/Полагање горњег слоја туцаника | 50d | 2023-06-09 | 2023-08-05 | 1606SS+15d | 82d | 0d |  |
| 1609 | 3.24.2.1.6.7 | 轨道安装/Track mounting/Монтирање колосека | 90d | 2023-06-26 | 2023-10-07 | 1608SS+14d | 82d |  |  |
| 1610 | 3.24.2.1.7 | 货运站旅客地道/Passenger underpass at the Subotica freight station/Путнички потходник у станици Суботица-теретна | 140d | 2022-11-23 | 2023-07-13 | 1603FS+50d | 651d |  |  |
| 1611 | 3.24.2.1.8 | 客运站房屋工程/works on marshaling yard station building/radovi na staničnoj zgradi ranižirne stanice | 180d | 2023-05-17 | 2024-02-13 | 1604 | 521d |  |  |
| 1612 | 3.24.2.1.9 | **客运站右幅改建/renovation of teh right part of passangers station/renoviranje desnog dela putničke stanice** | 260d | 2022-09-24 | 2023-10-03 |  | 472d |  |  |
| 1613 | 3.24.2.1.9.1 | 既有线轨道拆除/dismantling existing track/demontaža postojećeg koloseka | 10d | 2022-09-24 | 2022-10-05 | 1603 | 472d | 0d | start no earlier than 2022-07-15 |
| 1614 | 3.24.2.1.9.2 | 旅客地道及站台墙(新建)/passangers passage and platform wall (newl construciton)/pothodnik za putnik i zid perona (nova gradnja) | 120d | 2022-11-23 | 2023-06-20 | 1613FS+40d | 581d | 0d | start no earlier than 2022-04-15 |
| 1615 | 3.24.2.1.9.3 | 站台风雨棚Site shelter/nadstrešnica perona/platform canopy | 90d | 2023-04-06 | 2023-07-25 | 1614FF+30d | 641d |  |  |
| 1616 | 3.24.2.1.9.4 | 路基换填Roadbed cut-to-fill replacement/subgrade replacement/zamena tla donjecg stroja | 140d | 2022-10-06 | 2023-05-27 | 1613 | 472d | 0d |  |
| 1617 | 3.24.2.1.9.5 | 路基检测Subgrade testing/subgrade testing/ispitivanje donjeg storja | 5d | 2023-05-29 | 2023-06-02 | 1616 | 472d | 15d |  |
| 1618 | 3.24.2.1.9.6 | 底层道碴铺设Base ballast laying/ballast laying/razastiranje tucanika | 30d | 2023-06-21 | 2023-07-25 | 1614, 1617 | 581d | 0d |  |
| 1619 | 3.24.2.1.9.7 | 接触网基础/OCS Foundation/Temelj kontaktne mreže | 90d | 2023-02-04 | 2023-05-27 | 1616FF | 691d |  |  |
| 1620 | 3.24.2.1.9.8 | 顶层道砟铺设/Top layer ballast laying/Полагање горњег слоја засторне призме | 30d | 2023-07-08 | 2023-08-11 | 1618SS+15d | 581d | 0d |  |
| 1621 | 3.24.2.1.9.9 | 轨道安装/Track mounting/Монтирање колосека | 60d | 2023-07-26 | 2023-10-03 | 1620SS+15d | 581d |  |  |

| ID | WBS | Task | Duration | Start | Finish | Predecessors | Total slack | Free slack | Constraint | Calendar |
| --- | --- | --- | --- | --- | --- | --- | --- | --- | --- | --- |
| 1622 | 3.24.2.2 | **电力电气化工程/Electric power Electrification Engineering/Elektrifikacija i elektroenergetski radovi** | 90d | 2023-09-11 | 2024-02-27 |  | 511d |  |  |  |
| 1623 | 3.24.2.2.1 | 接触网立柱安装/OCS pole installation/Postavljanje stubova kontaktne mreže | 90d | 2023-09-11 | 2024-02-27 | 1607FS+90d | 511d |  |  |  |
| 1624 | 3.24.3 | **第二步（K176+274桥、轨道铺设）/The second step (K176+274 bridge, track laying)/Други корак (мост К176+274, полагање колосека)** | 368d | 2023-04-01 | 2024-08-19 |  | 0d |  |  |  |
| 1625 | 3.24.3.1 | **土建工程/civil engineering works/građevinski radovi** | 288d | 2023-04-01 | 2024-05-17 |  | 0d |  |  |  |
| 1626 | 3.24.3.1.1 | **Km176+274下穿通道/Km176+274 underpass /Km176+274 podvožnjak** | 273d | 2023-04-01 | 2024-04-24 |  | 0d |  |  |  |
| 1627 | 3.24.3.1.1.1 | 管线迁改/Pipeline relocation/Премештање цевовода | 30d | 2023-04-01 | 2023-05-11 | 1597 | 243d |  | start no earlier than 2023-03-01 |  |
| 1628 | 3.24.3.1.1.2 | 暖气迁改/Heating relocation/Премештање грејања | 90d | 2023-04-01 | 2023-07-20 | 1597 | 0d |  | start no earlier than 2023-04-01 |  |
| 1629 | 3.24.3.1.1.3 | **桥梁施工/bridge construction/конструкција мостова** | 273d | 2023-04-01 | 2024-04-24 |  | 0d |  |  |  |
| 1630 | 3.24.3.1.1.3.1 | 基坑防护、开挖/foundadtion pit protection, digging (first U-shaped channel is mounted)/zaštita iskopa temelja, iskop (prethodno se radi kanalica U profila) | 90d | 2023-04-01 | 2023-07-20 | 1628SS | 0d |  |  |  |
| 1631 | 3.24.3.1.1.3.2 | 垫层混凝土/Lean concrete/podloga | 115d | 2023-04-10 | 2023-08-26 | 1630SS+7d | 0d |  |  |  |
| 1632 | 3.24.3.1.1.3.3 | 框构底板/frame base/sandučasta ploča | 69d | 2023-04-12 | 2023-07-06 | 1631SS+2d | 0d |  |  |  |
| 1633 | 3.24.3.1.1.3.4 | 框构侧墙/frame side walls/bočni zidovi | 90d | 2023-07-07 | 2023-10-19 | 1632 | 0d |  |  |  |
| 1634 | 3.24.3.1.1.3.5 | 框构顶板(含砼养生期)/frame roof/gornja ploča | 120ed | 2023-10-19 | 2024-02-16 | 1633 | 25.88d | 24d |  |  |
| 1635 | 3.24.3.1.1.3.6 | U型槽/U- shapped channel/propusti U profila | 120ed | 2023-10-19 | 2024-02-16 | 1633 | 1.88d |  |  | 非冬季施工 |
| 1636 | 3.24.3.1.1.3.7 | 挡土墙/Retaining wall/Potporni zid | 120ed | 2023-10-27 | 2024-02-24 | 1635SS+7d | 1.88d | 0d |  |  |
| 1637 | 3.24.3.1.1.3.8 | 回填/filling/zatrpavanje | 60ed | 2024-02-24 | 2024-04-24 | 1636, 1634, 1635 | 1.88d |  |  |  |
| 1638 | 3.24.3.1.2 | **货运站中场改造/Track laying in themiddle range of the freight station** | 84d | 2023-10-09 | 2024-03-19 |  | 82d |  |  |  |
| 1639 | 3.24.3.1.2.1 | 轨道拆除/Track removal/Демонтирање колосека | 15d | 2023-10-09 | 2023-10-25 | 1602 | 82d | 0d |  |  |
| 1640 | 3.24.3.1.2.2 | 路基换填/Subgrade replacement/Замена подтла | 80ed | 2023-10-25 | 2024-01-13 | 1639 | 1675.88d | 0d |  |  |
| 1641 | 3.24.3.1.2.3 | 接触网基础/Overhead catanary system foundations/Темељи контактне мреже | 20ed | 2023-12-24 | 2024-01-13 | 1640FF | 1675.88d | 0d |  |  |
| 1642 | 3.24.3.1.2.4 | 道砟铺设/ballast laying upper layer/razastrianje tucanika gornji sloj | 10ed | 2024-01-13 | 2024-01-23 | 1641 | 1675.88d | 0d |  | 非冬季施工 |
| 1643 | 3.24.3.1.2.5 | 轨道铺设/track laying/polaganje koloseka | 55ed | 2024-01-18 | 2024-03-13 | 1642SS+5ed | 1675.88d | 1.88d |  | 非冬季施工 |
| 1644 | 3.24.3.1.2.6 | 轨道应力放散锁定及精调/track stress relief locking and fine tuning/zaključavanje napregnutosti koloseka fina podešavanja | 20d | 2024-02-26 | 2024-03-19 | 1643FF+5d | 413d | 46d |  |  |
| 1645 | 3.24.3.1.3 | **客场右幅剩余工程/Remaining works on the right side of Subotica passenger station/Преостали радови на десној страни станице Суботица-путничка** | 115d | 2023-10-25 | 2024-05-17 |  | 82d |  |  |  |
| 1646 | 3.24.3.1.3.1 | 轨道拆除/Track removal/Демонтирање колосека | 15ed | 2023-10-25 | 2023-11-09 | 1639 | 484.88d | 0d |  |  |
| 1647 | 3.24.3.1.3.2 | 路基换填/Subgrade replacement/Замена подтла | 125ed | 2023-11-09 | 2024-03-13 | 1646 | 484.88d | 0d |  |  |
| 1648 | 3.24.3.1.3.3 | 接触网基础/Overhead catanary system foundations/Темељи контактне мреже | 45ed | 2024-01-22 | 2024-03-07 | 1647FF-5d | 1992d |  |  |  |
| 1649 | 3.24.3.1.3.4 | 道砟铺设/ballast laying upper layer/razastrianje tucanika gornji sloj | 60ed | 2024-03-13 | 2024-05-12 | 1647 | 484.88d | 0d |  | 非冬季施工 |
| 1650 | 3.24.3.1.3.5 | 轨道铺设/track laying/polaganje koloseka | 55ed | 2024-03-18 | 2024-05-12 | 1649SS+5ed | 484.88d | 0d |  | 非冬季施工 |
| 1651 | 3.24.3.1.3.6 | 轨道应力放散锁定及精调/track stress relief locking and fine tuning/zaključavanje napregnutosti koloseka fina podešavanja | 10ed | 2024-05-07 | 2024-05-17 | 1650FF+5ed | 484.88d | 1.88d |  |  |

| ID | WBS | Task | Type | Duration | Start | Finish | Predecessors | Total slack | Free slack | Constraint |
| --- | --- | --- | --- | --- | --- | --- | --- | --- | --- | --- |
| 1652 | 3.24.3.2 | **电力电气化工程/Electric power Electrification Engineering/Elektrifikacija i elektroenergetski radovi** |  | 85d | 2024-05-13 | 2024-08-19 |  | 367d |  |  |
| 1653 | 3.24.3.2.1 | 接触网承导线架设/OCS catenary stretching/Razvlačenje kontaktne mreže |  | 60d | 2024-05-13 | 2024-07-20 | 1643, 1650 | 392d |  | finish no earlier than 2023-03-12 |
| 1654 | 3.24.3.2.2 | 接触网悬挂精调/Fine adjustment of catenary suspension/Fina regulacija voznog voda |  | 80d | 2024-05-18 | 2024-08-19 | 1644, 1651 | 367d |  | start no earlier than 2023-03-13 |
| 1655 | 3.24.4 | **第三步（客运站左幅、货运站左场）/third step** |  | 724d | 2022-07-01 | 2025-05-22 |  | 30d |  |  |
| 1656 | 3.24.4.1 | **土建工程/civil engineering works/građevinski radovi** |  | 724d | 2022-07-01 | 2025-05-22 |  | 30d |  |  |
| 1657 | 3.24.4.1.1 | 封锁既有正线/closing of the existing Novi Sad track/zatvaranje postojećeg novosadskog koloseka |  | 27d | 2022-07-01 | 2022-08-01 | 1 | 30d | 0d |  |
| 1658 | 3.24.4.1.2 | **Km177+329立交桥/Km177+329overpass/Km177+329 nadvožnjak** |  | 156d | 2024-09-12 | 2025-05-22 |  | 0d |  | start no earlier than 2023-08-01 |
| 1659 | 3.24.4.1.2.1 | 桥梁拆除/Old bridge removal/Uklanjanje starog mosta |  | 21ed | 2024-09-12 | 2024-10-03 | 1657, 1680 | 1.88d | 0d |  |
| 1660 | 3.24.4.1.2.2 | 试验桩/Test pile/Probni šip |  | 32ed | 2024-10-03 | 2024-11-04 | 1659 | 1.88d | 0d |  |
| 1661 | 3.24.4.1.2.3 | 桩基/Pile foundation/Temelj šipova |  | 20ed | 2024-11-04 | 2024-11-24 | 1660 | 1.88d |  |  |
| 1662 | 3.24.4.1.2.4 | 承台/Pile caps/Naglavnice |  | 25ed | 2025-02-01 | 2025-02-26 | 1661SS+23d | 4.88d | 1.88d |  |
| 1663 | 3.24.4.1.2.5 | 墩柱、桥台/Pier column/Mostovski stub |  | 36ed | 2025-02-10 | 2025-03-18 | 1662SS+7d | 676.88d | 0d |  |
| 1664 | 3.24.4.1.2.6 | 梁/Precast beam installation/Montaža prefabrikovane grede |  | 20ed | 2025-03-18 | 2025-04-07 | 1663 | 676.88d | 0d |  |
| 1665 | 3.24.4.1.2.7 | 桥面铺装/Bridge deck pavement/Плочник моста |  | 20ed | 2025-04-07 | 2025-04-27 | 1664 | 676.88d | 1.88d |  |
| 1666 | 3.24.4.1.2.8 | **顺接地方公路/Local road connection/Povezivanje sa lokanim putevima** |  | 70d | 2025-02-25 | 2025-05-22 |  | 190d |  |  |
| 1667 | 3.24.4.1.2.8.1 | 路基施工（开挖、填筑）/Subgrade works (excavation and filling)/Radovi na posteljici (iskop i nasipanje) |  | 60d | 2025-02-25 | 2025-05-10 | 1665FF+10d | 190d | 0d |  |
| 1668 | 3.24.4.1.2.8.2 | 路面施工（含标线）/Road surface works (including marking)/Radovi na kolovoznom zastoru (uključujući označavanje) |  | 20d | 2025-04-28 | 2025-05-22 | 1667FF+10d | 190d | 0d |  |
| 1669 | 3.24.4.1.2.8.3 | 路灯、边坡腐殖土、水沟等附属工程施工/Construction of road light, humus slope, ditch andother subsidary works/Izgradnja putne rasvete, humusne kosine, jarka i ostali pomoćni radovi |  | 20d | 2025-04-28 | 2025-05-22 | 1668FF | 190d |  | start no earlier than 2022-04-01 |
| 1670 | 3.24.4.1.3 | **Km177+627铁铁立交/Km177+627/Km177+627** |  | 254d | 2022-11-03 | 2023-11-04 | 1586 | 296d | 295d |  |
| 1671 | 3.24.4.1.3.1 | 机械进场、围挡安装 |  | 30d | 2022-11-03 | 2023-02-08 | 1657FS+80d | 296d | 0d |  |
| 1672 | 3.24.4.1.3.2 | 基坑防护、开挖/foundadtion pit protection, digging (first U-shaped channel is mounted)/zaštita iskopa temelja, iskop (prethodno se radi kanalica U profila) |  | 42d | 2023-02-09 | 2023-03-31 | 1671 | 296d | 0d |  |
| 1673 | 3.24.4.1.3.3 | 垫层混凝土/Lean concrete/podloga |  | 30d | 2023-02-20 | 2023-03-25 | 1672SS+7d | 296d | 0d |  |
| 1674 | 3.24.4.1.3.4 | 框构底板/frame base/sandučasta ploča |  | 60d | 2023-02-28 | 2023-05-13 | 1673SS+7d | 296d | 0d |  |
| 1675 | 3.24.4.1.3.5 | 框构侧墙/frame side walls/bočni zidovi |  | 70d | 2023-05-15 | 2023-08-03 | 1674 | 296d | 0d |  |
| 1676 | 3.24.4.1.3.6 | 框构顶板/frame roof/gornja ploča |  | 70d | 2023-08-04 | 2023-10-24 | 1675 | 296d | 0d |  |
| 1677 | 3.24.4.1.3.7 | 回填/filling/zatrpavanje |  | 10d | 2023-10-25 | 2023-11-04 | 1676 | 296d |  |  |
| 1678 | 3.24.4.1.4 | “Km177+850-Km179+100”1.3kmU型槽施工图批复与征地完成/Construction drawing approved and land acquisition for the 1.3km U-shaped trench duct "Km177+850-Km179+100" completed/Цртеж је одобрен и експропријација завршена за канелету 1.3км од "км177+850-км179+100" | milestone | 0d | 2022-08-01 | 2022-08-01 | 1657 | 90d | 60d |  |
| 1679 | 3.24.4.1.5 | “Km177+850-Km179+100”1.3kmU型槽/“Km177+850-Km179+100” U-shapped channels/“Km177+850-Km179+100” propusti U profila |  | 518d | 2022-10-11 | 2024-10-25 | 1657FS+60d, 1678 | 30d | 0d |  |

| ID | WBS | Task | Type | Duration | Start | Finish | Predecessors | Total slack | Free slack | Constraint | Calendar |
| --- | --- | --- | --- | --- | --- | --- | --- | --- | --- | --- | --- |
| 1680 | 3.24.4.1.6 | **Km177+857下穿通道/Km177+857/Km177+857** |  | 116d | 2024-04-25 | 2024-09-12 |  | 0d |  |  |  |
| 1681 | 3.24.4.1.6.1 | 基坑防护、开挖/foundadtion pit protection, digging (first U-shaped channel is mounted)/zaštita iskopa temelja, iskop (prethodno se radi kanalica U profila) |  | 19d | 2024-04-25 | 2024-05-22 | 1626 | 0d |  |  |  |
| 1682 | 3.24.4.1.6.2 | 垫层混凝土/Lean concrete/podloga |  | 9d | 2024-05-09 | 2024-05-18 | 1681SS+7d | 0d |  |  |  |
| 1683 | 3.24.4.1.6.3 | 框构底板/frame base/sandučasta ploča |  | 29d | 2024-05-11 | 2024-06-13 | 1682SS+2d | 0d |  |  |  |
| 1684 | 3.24.4.1.6.4 | 框构侧墙/frame side walls/bočni zidovi |  | 39d | 2024-06-14 | 2024-07-29 | 1683 | 0d |  |  |  |
| 1685 | 3.24.4.1.6.5 | 框构顶板/frame roof/gornja ploča |  | 8d | 2024-07-30 | 2024-08-07 | 1684 | 0d |  |  |  |
| 1686 | 3.24.4.1.6.6 | U型槽/U- shapped channel/propusti U profila |  | 77d | 2024-06-05 | 2024-09-02 | 1684FF+30d | 2d | 0d |  |  |
| 1687 | 3.24.4.1.6.7 | 挡土墙/Retaining wall/Potporni zid |  | 43d | 2024-07-23 | 2024-09-10 | 1686FF+7d | 2d |  | start no earlier than 2023-02-23 |  |
| 1688 | 3.24.4.1.6.8 | 回填/filling/zatrpavanje |  | 20d | 2024-08-08 | 2024-08-30 | 1685 | 0d |  |  |  |
| 1689 | 3.24.4.1.6.9 | 路面施工（含标线）/connect to local road/nastavljanje na lokalni put |  | 31d | 2024-08-08 | 2024-09-12 | 1688SS | 0d |  |  |  |
| 1690 | 3.24.4.2 | **货运站正线土建/Civil works of the main line of the Subotica freight station /Грађевински радови на главним колосецима станице Суботица-теретна** |  | 130d | 2024-05-18 | 2024-10-16 |  | 138d |  |  |  |
| 1691 | 3.24.4.2.1 | 轨道拆除/Track removal/Демонтирање колосека |  | 30d | 2024-05-18 | 2024-06-21 | 1651 | 138d | 0d |  |  |
| 1692 | 3.24.4.2.2 | 路基换填/Subgrade replacement/Замена подтла |  | 100d | 2024-06-22 | 2024-10-16 | 1691 | 156d | 0d |  | 非冬季施工 |
| 1693 | 3.24.4.2.3 | 接触网基础/Overhead catanary system foundations/Темељи контактне мреже |  | 70d | 2024-07-27 | 2024-10-16 | 1692FF | 317d |  |  |  |
| 1694 | 3.24.4.3 | **客场右幅剩余工程/Remaining works on the right side of Subotica passenger station/Преостали радови на десној страни станице Суботица-путничка** |  | 168d | 2024-05-18 | 2024-12-14 |  | 138d |  |  |  |
| 1695 | 3.24.4.3.1 | 轨道拆除/Track removal/Демонтирање колосека |  | 30d | 2024-05-18 | 2024-06-21 | 1651 | 138d | 0d |  |  |
| 1696 | 3.24.4.3.2 | 路基换填/Subgrade replacement/Замена подтла |  | 100d | 2024-06-22 | 2024-10-16 | 1695 | 156d | 0d |  | 非冬季施工 |
| 1697 | 3.24.4.3.3 | 接触网基础/Overhead catanary system foundations/Темељи контактне мреже |  | 50d | 2024-08-20 | 2024-10-16 | 1696FF | 317d |  |  |  |
| 1698 | 3.24.4.3.4 | 道砟铺设/ballast laying upper layer/razastrianje tucanika gornji sloj |  | 35d | 2024-10-17 | 2024-11-27 | 1696 | 189d | 0d |  | 非冬季施工 |
| 1699 | 3.24.4.3.5 | 轨道铺设/track laying/polaganje koloseka |  | 30d | 2024-11-09 | 2024-12-14 | 1698FF+15d | 189d | 41d |  | 非冬季施工 |
| 1700 | 3.24.5 | **第四步（客场左半场、线下结构）/Step 4 (Left side of passinger station, subgrade)/Корак 4 ( лева страна путничке станице, доњи строј)** |  | 124d | 2024-11-29 | 2025-06-30 |  | 23d | 0d |  |  |
| 1701 | 3.24.5.1 | **前置条件/Pre-conditions/Предуслови** |  | 0d | 2025-01-04 | 2025-01-04 |  | 21d |  |  |  |
| 1702 | 3.24.5.1.1 | 松博尔左线开通/ Opening of the left track in Sombor/Пуштање у саобраћај сомборског левог колосека | milestone | 0d | 2025-01-04 | 2025-01-04 | 1679FS+60d | 44d | 0d |  | 非冬季施工 |
| 1703 | 3.24.5.2 | **土建工程/civil engineering works/građevinski radovi** |  | 25d | 2024-11-29 | 2025-02-28 |  | 23d |  |  |  |
| 1704 | 3.24.5.2.1 | **客运站剩余工程改建/Remaining reconstruction works of the Subotica passenger station /Преостали радови на реконструкцији станице Суботица-путничка** |  | 25d | 2024-11-29 | 2025-02-28 |  | 23d |  |  |  |
| 1705 | 3.24.5.2.1.1 | 既有线拆除(左场及正线)//demontaža postojećeg koloseka (levi plato i novosadski kolosek) |  | 5ed | 2025-01-04 | 2025-01-09 | 1702 | 160.88d | 0d |  | 非冬季施工 |
| 1706 | 3.24.5.2.1.2 | 路基换填/subgrade replacement/zamena tla donjecg stroja |  | 45ed | 2025-01-09 | 2025-02-23 | 1705 | 160.88d | 0d |  |  |
| 1707 | 3.24.5.2.1.3 | 路基检测/subgrade testing/ispitivanje donjeg storja |  | 5ed | 2025-02-23 | 2025-02-28 | 1706 | 160.88d | 0d |  |  |
| 1708 | 3.24.5.2.1.4 | 接触网基础/OCS Foundation/Temelj kontaktne mreže |  | 20d | 2024-11-29 | 2025-02-23 | 1706FF | 151d | 0d |  |  |

| ID | WBS | Task | Type | Duration | Start | Finish | Predecessors | Total slack | Free slack | Constraint |
| --- | --- | --- | --- | --- | --- | --- | --- | --- | --- | --- |
| 1709 | 3.24.5.3 | **电力电气化工程/Electric power Electrification Engineering/Elektrifikacija i elektroenergetski radovi** |  | 122d | 2025-02-01 | 2025-06-30 |  | 107d |  |  |
| 1710 | 3.24.5.3.1 | 接触网立柱、腕臂安装/OCS pole and cantilever installation/Postavljanje stubova kontaktne mreže, montaža konzola |  | 60d | 2025-02-24 | 2025-05-09 | 1708 | 151d |  |  |
| 1711 | 3.24.5.3.2 | 接触网承导线架设/OCS catenary stretching/Razvlačenje kontaktne mreže |  | 58d | 2025-02-01 | 2025-04-10 | 1699 | 148d | 41d |  |
| 1712 | 3.24.5.3.3 | 接触网悬挂精调/Fine adjustment of catenary suspension/Fina regulacija voznog voda |  | 23d | 2025-06-04 | 2025-06-30 | 1946, 1711 | 107d |  |  |
| 1713 | 3.24.6 | 第五步（要点封锁完成剩余工程）/fifth step (partially close the railway in order to complete remained work)/peti korak (traži se zatvor za deo pruge radi završetka preostalog posla) |  | 59ed | 2025-06-30 | 2025-08-28 | 1700 | 375d |  |  |
| 1714 | 3.24.7 | **通信信号工程/Telecommunication and Signaling works / ТК и СС радови** |  | 622d | 2023-04-12 | 2025-08-30 |  | 104d |  |  |
| 1715 | 3.24.7.1 | 房建工程/Construction & renovation for Equipment house / Радови изградње и реновирању зграда |  | 232d | 2023-04-12 | 2024-03-19 | 1720SF-220d | 494d | 0d |  |
| 1716 | 3.24.7.2 | **SS工程/ Signaling works/ СС радови** |  | 170d | 2025-02-07 | 2025-08-30 |  | 104d |  |  |
| 1717 | 3.24.7.2.1 | 临时连锁/Temporary interlocking device / Мобилни уређај међусигналне зависности |  | 20d | 2025-05-12 | 2025-06-03 | 1946FF | 180d |  |  |
| 1718 | 3.24.7.2.2 | 光电缆敷设/ Optical cable laying / Полагање оптичких каблова |  | 90d | 2025-02-07 | 2025-05-30 | 1719SF | 134d | 0d |  |
| 1719 | 3.24.7.2.3 | 轨旁设备安装/ Trackside equipment mounting / Уградња пружних уређаја |  | 58ed | 2025-05-30 | 2025-07-27 | 1946FS-4d | 367.12d | 0d |  |
| 1720 | 3.24.7.2.4 | 室内设备安装/ Indoor equipment mounting (at station) / Монтажа унутрашње опреме (у станици) |  | 90d | 2025-02-07 | 2025-05-29 | 1718SS | 184d | 0d | start no earlier than 2022-10-08 |
| 1721 | 3.24.7.2.5 | 信号设备调试/ Testing of the station SS equipment/ Тестирање станичне СС опреме |  | 60d | 2025-06-23 | 2025-08-30 | 1719FS-30d | 104d |  |  |
| 1722 | 3.24.7.3 | **TT工程/ Telecommunication works / ТТ радови** |  | 590d | 2023-05-25 | 2025-08-30 |  | 104d |  |  |
| 1723 | 3.24.7.3.1 | 光电缆敷设/ Optical cable laying / Полагање оптичких каблова |  | 90d | 2025-02-07 | 2025-05-29 | 1718SS | 134d | 0d |  |
| 1724 | 3.24.7.3.2 | 综合布线/ Integrated cabling system / структурно каблирање |  | 90d | 2023-09-30 | 2024-03-19 | 1715FF | 494d |  | start no earlier than 2022-09-08 |
| 1725 | 3.24.7.3.3 | 站内通信信息设备安装/Installation of telecommunication and information equipment in the station / Уградња телекомуникационе и информационе опреме у станици |  | 140d | 2025-02-07 | 2025-07-26 | 1723SS | 134d |  | finish no earlier than 2023-07-24 |
| 1726 | 3.24.7.3.4 | 铁塔工程/Communication tower works/ Радови на ТК стубовима |  | 200d | 2023-05-25 | 2024-03-19 | 1715FF | 494d |  | finish no earlier than 2023-07-24 |
| 1727 | 3.24.7.3.5 | TK设备调试/ Testing of the station TK equipment/ Тестирање станичне TK опреме |  | 60d | 2025-06-23 | 2025-08-30 | 1719FS-30d | 104d |  |  |
| 1728 | 3.25 | **苏博蒂察站（Km178+000）~终点（Km184+635.07）/stanica Subotica (Km178+000)~kraj trase (Km184+635.07)** |  | 810d | 2022-07-01 | 2025-08-30 |  | 104d |  |  |
| 1729 | 3.25.1 | **土建工程/civil engineering works/građevinski radovi** |  | 532d | 2022-07-01 | 2024-08-01 |  | 272d |  |  |
| 1730 | 3.25.1.1 | **苏博蒂察站（Km178+000） ~Km181+000 2024.2.15/Subotica station (Km178+000) ~Km181+000 2024.2.15/stanica Subotica (Km178+000) ~Km181+000 2024.2.15** |  | 532d | 2022-07-01 | 2024-08-01 |  | 272d |  |  |
| 1731 | 3.25.1.1.1 | 交付土地/land transmission/predaja zemljišta | milestone | 0d | 2022-07-01 | 2022-07-01 |  | 367d | 72d |  |
| 1732 | 3.25.1.1.2 | 既有轨道拆除/demounting of existing tracks/demontaža postojećih koloseka |  | 5d | 2022-09-17 | 2022-09-22 | 1657FS+40d | 205d | 0d |  |
| 1733 | 3.25.1.1.3 | 征地及房屋拆迁，见附件3/For land acquisition and house demolition, see Annex 3/За куповину земљишта и рушење кућа, погледајте Анекс 3 |  | 30d | 2022-08-05 | 2022-09-08 | 1FS+30d | 854d |  |  |
| 1734 | 3.25.1.1.4 | 图纸和施工方案的批复/Approval of drawings and Method Statement/Одобрење цртежа и Изјава о методи |  | 30d | 2022-08-05 | 2022-09-08 | 1FS+30d | 854d |  |  |
| 1735 | 3.25.1.1.5 | 管线迁改，见附件4/Pipeline relocation, see Annex4/Премештање цевовода, видети Анекс 4 |  | 30d | 2022-09-23 | 2022-10-27 | 1731, 1732 | 812d |  |  |

| ID | WBS | Task | Duration | Start | Finish | Predecessors | Total slack | Free slack |
| --- | --- | --- | --- | --- | --- | --- | --- | --- |
| 1736 | 3.25.1.1.6 | **涵洞工程/Culvert Engineering/Цулверт Енгинееринг** | 340d | 2023-04-20 | 2024-08-01 |  | 205d |  |
| 1737 | 3.25.1.1.6.1 | Km178+780涵洞/Km178+780 culvert/Km178+780 propust | 90d | 2023-04-20 | 2023-08-04 | 1732FS+120d | 205d | 0d |
| 1738 | 3.25.1.1.6.2 | Km179+373涵洞/Km179+373 culvert/Km179+373 propust | 90d | 2023-05-27 | 2023-09-08 | 1737SS+30d | 205d | 0d |
| 1739 | 3.25.1.1.6.3 | Km182+000涵洞/Km182+000 culvert/Km182+000 propust | 90d | 2023-07-01 | 2023-10-13 | 1738SS+30d | 205d | 0d |
| 1740 | 3.25.1.1.6.4 | Km182+200涵洞/Km182+200 culvert/Km182+200 propust | 90d | 2023-08-05 | 2023-11-18 | 1739SS+30d | 205d | 0d |
| 1741 | 3.25.1.1.6.5 | Km182+400涵洞/Km182+400 culvert/Km182+400 propust | 90d | 2023-09-09 | 2024-02-26 | 1740SS+30d | 205d | 0d |
| 1742 | 3.25.1.1.6.6 | Km182+600涵洞/Km182+600 culvert/Km182+600 propust | 90d | 2023-10-14 | 2024-04-01 | 1741SS+30d | 205d | 0d |
| 1743 | 3.25.1.1.6.7 | Km182+800涵洞/Km182+800 culvert/Km182+800 propust | 90d | 2023-11-07 | 2024-04-24 | 1742SS+20d | 205d | 0d |
| 1744 | 3.25.1.1.6.8 | Km183+000涵洞/Km183+000 culvert/Km183+000 propust | 90d | 2024-02-01 | 2024-05-23 | 1743SS+20d | 382d | 0d |
| 1745 | 3.25.1.1.6.9 | Km183+600涵洞/Km183+600 culvert/Km183+600 propust | 90d | 2024-02-27 | 2024-06-15 | 1744SS+20d | 382d | 0d |
| 1746 | 3.25.1.1.6.10 | Km183+800涵洞/Km183+800 culvert/Km183+800 propust | 90d | 2024-03-21 | 2024-07-09 | 1745SS+20d | 382d | 0d |
| 1747 | 3.25.1.1.6.11 | Km184+000涵洞/Km184+000 culvert/Km184+000 propust | 90d | 2024-04-13 | 2024-08-01 | 1746SS+20d | 382d |  |
| 1748 | 3.25.1.1.6.12 | Km184+600涵洞/Km184+600 culvert/Km184+600 propust | 90d | 2023-11-07 | 2024-04-24 | 1743SS | 205d | 204d |
| 1749 | 3.25.1.1.7 | **Km179+395上跨立交桥/Km179+395 overpass/Km179+395 nadvožnjak** | 401d | 2022-08-05 | 2024-03-30 |  | 456d |  |
| 1750 | 3.25.1.1.7.1 | 征地及房屋拆迁，见附件3/For land acquisition and house demolition, see Annex 3/За куповину земљишта и рушење кућа, погледајте Анекс 3 | 30d | 2022-08-05 | 2022-09-08 | 1FS+30d | 456d | 12d |
| 1751 | 3.25.1.1.7.2 | 图纸和施工方案的批复/Approval of drawings and Method Statement/Одобрење цртежа и Изјава о методи | 30d | 2022-08-05 | 2022-09-08 | 1FS+30d | 456d | 12d |
| 1752 | 3.25.1.1.7.3 | **桥梁施工/bridge construction/конструкција мостова** | 359d | 2022-09-23 | 2024-03-30 |  | 444d |  |
| 1753 | 3.25.1.1.7.3.1 | 施工准备/preparation works/pripremni radovi | 17d | 2022-09-23 | 2022-10-12 | 1731, 1732, 1750, 1751 | 444d | 0d |
| 1754 | 3.25.1.1.7.3.2 | 桩基/pile/šipovi | 64d | 2022-10-13 | 2023-03-01 | 1753 | 444d | 0d |
| 1755 | 3.25.1.1.7.3.3 | 承台/pile caps/nadglavnice | 100d | 2022-11-30 | 2023-06-03 | 1754SS+40d | 483d | 0d |
| 1756 | 3.25.1.1.7.3.4 | 墩柱/heavy-duty pier/noseći stubovi | 70d | 2023-06-05 | 2023-08-24 | 1755 | 483d | 0d |
| 1757 | 3.25.1.1.7.3.5 | 梁/girder/nosači | 83d | 2023-08-25 | 2023-11-30 | 1756 | 483d | 0d |
| 1758 | 3.25.1.1.7.3.6 | 附属工程/auxiliary works/propratni radovi | 61d | 2023-10-23 | 2024-03-06 | 1757SS+50d | 504d |  |
| 1759 | 3.25.1.1.7.3.7 | 顺接地方公路/connect to local road/nastavljanje na lokalni put | 82d | 2023-10-23 | 2024-03-30 | 1757SS+50d | 483d |  |

| ID | WBS | Task | Type | Duration | Start | Finish | Predecessors | Total slack | Free slack |
| --- | --- | --- | --- | --- | --- | --- | --- | --- | --- |
| 1760 | 3.25.1.1.8 | **Km180+969铁跨公立交桥/Km180+969 overpass/Km180+969 nadvožnjak** |  | 440d | 2022-08-05 | 2024-05-21 |  | 444d |  |
| 1761 | 3.25.1.1.8.1 | 征地及房屋拆迁，见附件3/For land acquisition and house demolition, see Annex 3/За куповину земљишта и рушење кућа, погледајте Анекс 3 |  | 30d | 2022-08-05 | 2022-09-08 | 1FS+30d | 537d | 93d |
| 1762 | 3.25.1.1.8.2 | 图纸和施工方案的批复/Approval of drawings and Method Statement/Одобрење цртежа и Изјава о методи |  | 30d | 2022-08-05 | 2022-09-08 | 1FS+30d | 537d | 93d |
| 1763 | 3.25.1.1.8.3 | **桥梁施工/bridge construction/конструкција мостова** |  | 317d | 2023-03-02 | 2024-05-21 | 1761, 1762, 1772, 1773, 1795, 1796, 1806, 1807 | 444d |  |
| 1764 | 3.25.1.1.8.3.1 | 施工准备/preparation works/pripremni radovi |  | 17d | 2023-03-02 | 2023-03-21 | 1731, 1754 | 444d | 0d |
| 1765 | 3.25.1.1.8.3.2 | 桩基/pile/šipovi |  | 64d | 2023-03-22 | 2023-06-09 | 1764 | 444d | 0d |
| 1766 | 3.25.1.1.8.3.3 | 承台/pile caps/nadglavnice |  | 100d | 2023-05-13 | 2023-09-06 | 1765SS+40d | 444d | 0d |
| 1767 | 3.25.1.1.8.3.4 | 墩柱/heavy-duty pier/noseći stubovi |  | 70d | 2023-09-07 | 2023-11-28 | 1766 | 444d | 0d |
| 1768 | 3.25.1.1.8.3.5 | 梁/girder/nosači |  | 83d | 2023-11-29 | 2024-05-13 | 1767 | 444d | 0d |
| 1769 | 3.25.1.1.8.3.6 | 附属工程/auxiliary works/propratni radovi |  | 40d | 2024-03-19 | 2024-05-09 | 1768SS+40d | 454d |  |
| 1770 | 3.25.1.1.8.3.7 | 顺接地方公路/connect to local road/nastavljanje na lokalni put |  | 50d | 2024-03-19 | 2024-05-21 | 1768SS+40d | 444d |  |
| 1771 | 3.25.1.1.9 | **路基工程/subgrade works/radovi na donjem stroju** |  | 382d | 2022-08-05 | 2024-03-08 |  | 337d |  |
| 1772 | 3.25.1.1.9.1 | 征地及房屋拆迁，见附件3/For land acquisition and house demolition, see Annex 3/За куповину земљишта и рушење кућа, погледајте Анекс 3 |  | 30d | 2022-08-05 | 2022-09-08 | 1FS+30d | 337d | 42d |
| 1773 | 3.25.1.1.9.2 | 图纸批复/Approval of drawings |  | 30d | 2022-08-05 | 2022-09-08 | 1FS+30d | 337d | 42d |
| 1774 | 3.25.1.1.9.3 | 管线迁改，见附件4/Pipeline relocation, see Annex4/Премештање цевовода, видети Анекс 4 |  | 30d | 2022-09-23 | 2022-10-27 | 1731, 1732 | 295d | 0d |
| 1775 | 3.25.1.1.9.4 | **区间路基/open track subgrade/donji stroj na otvorenoj pruzi** |  | 310d | 2022-10-28 | 2024-03-08 |  | 295d |  |
| 1776 | 3.25.1.1.9.4.1 | 区间路基/open track subgrade/donji stroj na otvorenoj pruzi |  | 260d | 2022-10-28 | 2023-11-06 | 1772, 1773, 1774 | 295d | 0d |
| 1777 | 3.25.1.1.9.4.2 | 声屏障/Sound barrier/Zvučna barijera |  | 60d | 2023-10-26 | 2024-03-08 | 1776SS+250d | 502d |  |
| 1778 | 3.25.1.1.9.4.3 | 排水工程/Drainage works/Radovi na odvodu |  | 200d | 2023-04-20 | 2024-02-12 | 1776FF+30d | 522d |  |
| 1779 | 3.25.1.1.9.4.4 | 接触网基础/OCS Foundation/Temelj kontaktne mreže |  | 220d | 2023-02-17 | 2023-11-06 | 1776FF | 462d | 0d |
| 1780 | 3.25.1.1.9.4.5 | 路基通信、信号过轨管/subgrade undertrack pipes for signalization and telecommunication/okiten cevi za signalizaciju i telekomunikaciju |  | 220d | 2023-04-20 | 2024-03-08 | 1776SS+90d | 502d |  |
| 1781 | 3.25.1.2 | **Km181+000~终点（Km184+635.07） 2024.3.10/Km181+000~end point（Km184+635.07）/Km181+000~kraj trase（Km184+635.07）** |  | 427d | 2022-07-01 | 2024-03-26 |  | 362d |  |
| 1782 | 3.25.1.2.1 | 交付土地/land is transfered, entrance allowed/zemljište je predato, dozvoljen ulazak na gradilište | milestone | 0d | 2022-07-01 | 2022-07-01 |  | 367d | 77d |
| 1783 | 3.25.1.2.2 | 既有轨道拆除/demounting of existing tracks/demontaža postojećih koloseka |  | 5d | 2022-09-23 | 2022-09-28 | 1732 | 290d | 0d |

| ID | WBS | Task | Duration | Start | Finish | Predecessors | Total slack | Free slack |
| --- | --- | --- | --- | --- | --- | --- | --- | --- |
| 1784 | 3.25.1.2.3 | **Km181+950动物通道/Km181+950 tunnel (propusti za svetlo, prelazi za životinje )/Km181+950 tunel (propusti za svetlo, prelazi za životinje )** | 271d | 2022-10-14 | 2023-11-04 |  | 553d |  |
| 1785 | 3.25.1.2.3.1 | 征地及房屋拆迁，见附件3/For land acquisition and house demolition, see Annex 3/За куповину земљишта и рушење кућа, погледајте Анекс 3 | 30d | 2022-10-14 | 2022-11-18 | 1FS+90d | 794d |  |
| 1786 | 3.25.1.2.3.2 | 图纸批复/Approval of drawings | 30d | 2022-10-14 | 2022-11-18 | 1FS+90d | 553d | 0d |
| 1787 | 3.25.1.2.3.3 | **桥梁施工/bridge construction/конструкција мостова** | 171d | 2023-04-18 | 2023-11-04 |  | 553d |  |
| 1788 | 3.25.1.2.3.3.1 | 试验桩/Test pile/Probni šip | 32d | 2023-04-18 | 2023-05-26 | 1786FS+70d | 553d | 0d |
| 1789 | 3.25.1.2.3.3.2 | 桩基/Pile foundation/Temelj šipova | 19d | 2023-05-27 | 2023-06-17 | 1788 | 553d | 0d |
| 1790 | 3.25.1.2.3.3.3 | 基础/Foundation/Temelj | 20d | 2023-06-19 | 2023-07-11 | 1789 | 553d | 0d |
| 1791 | 3.25.1.2.3.3.4 | Springline wall/Springline wall/Springline zid | 20d | 2023-07-12 | 2023-08-03 | 1790 | 553d | 0d |
| 1792 | 3.25.1.2.3.3.5 | 隧道顶建设/Tunnel roof construction/Krovna konstukcija tunela | 70d | 2023-08-04 | 2023-10-24 | 1791 | 553d | 0d |
| 1793 | 3.25.1.2.3.3.6 | 回填/Backfilling/Zatrpavanje | 10d | 2023-10-25 | 2023-11-04 | 1792 | 553d |  |
| 1794 | 3.25.1.2.4 | **Km184+258上跨立交桥/Km184+258 overpass/Km184+258 nadvožnjak** | 378d | 2022-08-05 | 2024-03-04 |  | 506d |  |
| 1795 | 3.25.1.2.4.1 | 征地及房屋拆迁，见附件3/For land acquisition and house demolition, see Annex 3/За куповину земљишта и рушење кућа, погледајте Анекс 3 | 30d | 2022-08-05 | 2022-09-08 | 1FS+30d | 537d | 93d |
| 1796 | 3.25.1.2.4.2 | 图纸批复/Approval of drawings | 30d | 2022-08-05 | 2022-09-08 | 1FS+30d | 506d | 0d |
| 1797 | 3.25.1.2.4.3 | **桥梁施工/bridge construction/конструкција мостова** | 318d | 2022-10-14 | 2024-03-04 |  | 506d |  |
| 1798 | 3.25.1.2.4.3.1 | 施工准备/preparation works/pripremni radovi | 17d | 2022-10-14 | 2022-11-02 | 1796FS+30d | 506d | 0d |
| 1799 | 3.25.1.2.4.3.2 | 桩基/pile/šipovi | 64d | 2022-11-03 | 2023-03-22 | 1798 | 506d | 0d |
| 1800 | 3.25.1.2.4.3.3 | 承台/pile caps/nadglavnice | 80d | 2023-02-23 | 2023-06-01 | 1799SS+40d | 506d | 0d |
| 1801 | 3.25.1.2.4.3.4 | 墩柱/heavy-duty pier/noseći stubovi | 70d | 2023-06-02 | 2023-08-22 | 1800 | 506d | 0d |
| 1802 | 3.25.1.2.4.3.5 | 梁/girder/nosači | 83d | 2023-08-23 | 2023-11-28 | 1801 | 506d | 0d |
| 1803 | 3.25.1.2.4.3.6 | 附属工程/auxiliary works/propratni radovi | 61d | 2023-10-20 | 2024-03-04 | 1802SS+50d | 506d |  |
| 1804 | 3.25.1.2.4.3.7 | 顺接地方公路/connect to local road/nastavljanje na lokalni put | 70d | 2023-09-15 | 2024-02-06 | 1802SS+20d | 527d |  |
| 1805 | 3.25.1.2.5 | **路基工程/subgrade works/radovi na donjem stroju** | 397d | 2022-08-05 | 2024-03-26 |  | 337d |  |
| 1806 | 3.25.1.2.5.1 | 征地及房屋拆迁，见附件3/For land acquisition and house demolition, see Annex 3/За куповину земљишта и рушење кућа, погледајте Анекс 3 | 30d | 2022-08-05 | 2022-09-08 | 1FS+30d | 337d | 47d |
| 1807 | 3.25.1.2.5.2 | 图纸批复/Approval of drawings | 30d | 2022-08-05 | 2022-09-08 | 1FS+30d | 337d | 47d |
| 1808 | 3.25.1.2.5.3 | 管线迁改，见附件4/Pipeline relocation, see Annex4/Премештање цевовода, видети Анекс 4 | 30d | 2022-09-29 | 2022-11-02 | 1782, 1783 | 290d | 0d |

| ID | WBS | Task | Type | Duration | Start | Finish | Predecessors | Total slack | Free slack | Constraint |
| --- | --- | --- | --- | --- | --- | --- | --- | --- | --- | --- |
| 1809 | 3.25.1.2.5.4 | **区间路基/open track subgrade/donji stroj na otvorenoj pruzi** |  | 320d | 2022-11-03 | 2024-03-26 |  | 290d |  |  |
| 1810 | 3.25.1.2.5.4.1 | 区间路基/open track subgrade/donji stroj na otvorenoj pruzi |  | 260d | 2022-11-03 | 2023-11-13 | 1806, 1807, 1808 | 290d | 0d |  |
| 1811 | 3.25.1.2.5.4.2 | 声屏障/Sound barrier/Zvučna barijera |  | 60d | 2023-10-09 | 2024-02-20 | 1810FF+30d | 517d |  |  |
| 1812 | 3.25.1.2.5.4.3 | 排水工程/Drainage works/Radovi na odvodu |  | 200d | 2023-06-02 | 2024-03-26 | 1810FF+60d | 487d |  |  |
| 1813 | 3.25.1.2.5.4.4 | 接触网基础/OCS Foundation/Temelj kontaktne mreže |  | 220d | 2023-02-23 | 2023-11-13 | 1810FF | 547d |  |  |
| 1814 | 3.25.1.2.5.4.5 | 路基通信、信号过轨管/subgrade undertrack pipes for signalization and telecommunication/okiten cevi za signalizaciju i telekomunikaciju |  | 220d | 2023-03-18 | 2024-02-06 | 1810SS+60d | 527d |  |  |
| 1815 | 3.25.2 | **电力电气化工程/Electric power Electrification Engineering/Elektrifikacija i elektroenergetski radovi** |  | 548d | 2023-05-12 | 2025-06-30 |  | 157d |  |  |
| 1816 | 3.25.2.1 | 接触网立柱、腕臂安装/OCS pole and cantilever installation/Postavljanje stubova kontaktne mreže, montaža konzola |  | 90d | 2023-11-07 | 2024-04-24 | 1779 | 462d |  |  |
| 1817 | 3.25.2.2 | 接触网承导线架设/OCS catenary stretching/Razvlačenje kontaktne mreže |  | 15d | 2025-05-26 | 2025-06-11 | 1885 | 157d | 0d |  |
| 1818 | 3.25.2.3 | 接触网悬挂精调/Fine adjustment of catenary suspension/Fina regulacija voznog voda |  | 16d | 2025-06-12 | 2025-06-30 | 1946, 1817 | 157d |  | start no earlier than 2025-06-01 |
| 1819 | 3.25.2.4 | 苏博蒂察分区所房建主体工程Main building works of Subotica /Strukturalni radovi na objektu PSN Subotica |  | 180d | 2023-07-01 | 2024-04-01 |  | 362d | 27d | finish no earlier than 2024-04-01 |
| 1820 | 3.25.2.5 | 苏博蒂察分区所房建装饰工程/ Construction and decoration works of Subotica PSN/Dekoraterski radovi na objektu PSN Subodica |  | 120d | 2024-05-09 | 2024-09-25 | 1819 | 335d |  | finish no earlier than 2024-09-25 |
| 1821 | 3.25.2.6 | 苏博蒂察开闭所房建主体工程/ Main building works of PS Subotica /Strukturalni radovi na objektu PS Subotica |  | 150d | 2023-09-30 | 2024-06-01 |  | 157d | 0d | finish no earlier than 2024-06-01 |
| 1822 | 3.25.2.7 | 苏博蒂察开闭所房建装饰工程/ Construction and decoration works of Subotica PS/ Dekoraterski radovi na objektu PS Subotica |  | 120d | 2024-06-03 | 2024-10-19 | 1821 | 195d | 0d | finish no earlier than 2024-04-10 |
| 1823 | 3.25.2.8 | 配电室改造/Transformation of distribution room/Rekonstrukcija distributivno transformatorske stanice |  | 22d | 2023-11-04 | 2023-12-29 |  | 532d |  | finish no earlier than 2023-12-29 |
| 1824 | 3.25.2.9 | 室内电气安装 /Indoor electrical installation/Unutrašnja elektroinstalacija |  | 119d | 2024-10-21 | 2025-05-16 | 1822 | 195d |  | start no earlier than 2024-06-03 |
| 1825 | 3.25.2.10 | 车站照明设备安装/Installation of station lighting equipment /Montaža stanične rasvete |  | 173d | 2023-05-12 | 2024-01-01 |  | 532d |  | finish no earlier than 2024-01-01 |
| 1826 | 3.25.2.11 | 变电所亭设备安装/Installation of ETS equipment/Montaža opreme u EVP | manual | 277d | 2024-06-03 | 2025-06-30 | 1821 |  |  | start no earlier than 2024-06-01 |
| 1827 | 3.25.3 | **通信信号工程/Telecommunication and Signaling works / ТК и СС радови** |  | 622d | 2023-04-12 | 2025-08-30 |  | 104d |  |  |
| 1828 | 3.25.3.1 | 房建工程/Construction & renovation for Equipment house / Радови изградње и реновирању зграда |  | 232d | 2023-04-12 | 2024-03-19 | 1836SF-220d | 494d | 0d |  |
| 1829 | 3.25.3.2 | **SS工程/ Signaling works/ СС радови** |  | 170d | 2025-02-07 | 2025-08-30 |  | 104d |  |  |
| 1830 | 3.25.3.2.1 | 光电缆敷设/ Optical cable laying / Полагање оптичких каблова |  | 90d | 2025-02-07 | 2025-05-30 | 1831SF | 184d | 0d | start no earlier than 2023-05-10 |
| 1831 | 3.25.3.2.2 | 轨旁设备安装/ Trackside equipment mounting / Уградња пружних уређаја |  | 58ed | 2025-05-30 | 2025-07-27 | 1946FS-4d | 367.12d | 0d |  |
| 1832 | 3.25.3.2.3 | 信号设备调试/ Testing of the station SS equipment/ Тестирање станичне СС опреме |  | 60d | 2025-06-23 | 2025-08-30 | 1831FS-30d | 104d |  |  |

| ID | WBS | Task | Duration | Start | Finish | Predecessors | Total slack | Free slack | Constraint |
| --- | --- | --- | --- | --- | --- | --- | --- | --- | --- |
| 1833 | 3.25.3.3 | **TT工程/ Telecommunication works / ТТ радови** | 590d | 2023-05-25 | 2025-08-30 |  | 104d |  |  |
| 1834 | 3.25.3.3.1 | 光电缆敷设/ Optical cable laying / Полагање оптичких каблова | 90d | 2025-02-07 | 2025-05-29 | 1830SS | 184d | 0d |  |
| 1835 | 3.25.3.3.2 | 轨旁设备安装/ Trackside equipment mounting / Уградња пружних уређаја | 60d | 2025-05-30 | 2025-08-07 | 1831SS | 124d |  |  |
| 1836 | 3.25.3.3.3 | 室内设备安装/ Indoor equipment mounting (at station) / Монтажа унутрашње опреме (у станици) | 90d | 2025-02-07 | 2025-05-29 | 1834SS | 184d | 0d |  |
| 1837 | 3.25.3.3.4 | 铁塔工程/Communication tower works/ Радови на ТК стубовима | 200d | 2023-05-25 | 2024-03-19 | 1828FF | 494d |  |  |
| 1838 | 3.25.3.3.5 | TK设备调试/ Testing of the station TK equipment/ Тестирање станичне TK опреме | 60d | 2025-06-23 | 2025-08-30 | 1831FS-30d | 104d |  |  |
| 1839 | 4 | **NS-Ⅰ标段轨道工程NS-Ⅰbidding section track construction Радови на колосеку NS-Ⅰсекције** | 604d | 2023-01-01 | 2025-06-03 |  | 0d |  |  |
| 1840 | 4.1 | **道岔铺设Turnouts laying Постављање скретница** | 333d | 2023-10-24 | 2025-03-30 |  | 31d |  |  |
| 1841 | 4.1.1 | **Km76+243.66~Km144+327.41** | 241d | 2023-10-24 | 2024-10-10 |  | 31d |  |  |
| 1842 | 4.1.1.1 | 鲁门卡站（Km84+043.75，11组-3组18.5#,8组14#）Rumenka station（Km84+043.75，11 turnouts -3 turnouts 18.5#,8 turnouts 14#） станица Руменка（Km84+043.75，11скретница-3 скретнице 18.5#,8 скретница 14#） | 47ed | 2023-10-24 | 2023-12-10 | 287, 50SS+220d | 123d | 0d |  |
| 1843 | 4.1.1.2 | 克萨彻站（Km90+407，10组14#）Kisač station（Km90+407，10 turnouts 14#） станица Кисач（Km90+407，10 скретница 14#） | 40ed | 2023-12-10 | 2024-01-19 | 416, 1842 | 123d | 0d |  |
| 1844 | 4.1.1.3 | 斯帕诺维切沃站（Km97+300，10组14#）Stepanovićevo station（Km97+300，10 turnouts 14#） станица Степановићево（Km97+300，10 скретнице 14#） | 41ed | 2024-01-19 | 2024-02-29 | 541, 1843 | 123d | 0d |  |
| 1845 | 4.1.1.4 | 热麻耶沃站（Km102+514，12组,10组14#,2组60-200-6°）Zmajevo station（Km102+514，12 turnouts,10 turnouts 14#,2 turnouts 60-200-6°） станица Змајево（Km102+514，12 скретница ,10 скретница 14#, 2 скретнице 60-200-6°） | 45ed | 2024-02-29 | 2024-04-14 | 666, 1844 | 123d | 0d | start no earlier than 2023-07-01 |
| 1846 | 4.1.1.5 | 维尔巴斯站（Km113+610.13,16组,12组14#,4组60-300-6°）Vrbas station（Km113+610.13,16 turnouts ,12组+ turnouts 14#,4 turnouts 60-300-6°） станица Врбас（Km113+610.13,16 скретница,12 скретница 14#,4 скретнице 60-300-6°） | 61ed | 2024-04-14 | 2024-06-14 | 788, 1845 | 123d | 0d |  |
| 1847 | 4.1.1.6 | 新罗沃彻纳茨站（Km129+523,10组14#）New Lovćenac station（Km129+523,10 turnouts 14#） нова станица Ловћенац（Km129+523,10 скретница 14#） | 42ed | 2024-06-14 | 2024-07-26 | 987, 1846 | 123d | 0d | start no earlier than 2023-07-01 |
| 1848 | 4.1.1.7 | 巴奇卡托波拉站（Km143+536，23组,15组14#,2组60-300-6°,6组49-300-6°）Bačka Topola station（Km143+536，23 turnouts,15 turnouts 14#,2 turnouts 60-300-6°,6 turnouts 49-300-6°） станица Бачка Топола（Km143+536，23 скретнице, 15 скретница 14#,2 скретнице 60-300-6°,6 скретница 49- | 76ed | 2024-07-26 | 2024-10-10 | 1195, 1847 | 123d |  |  |
| 1849 | 4.1.2 | **Km144+327.41~Km184+635.07** | 333d | 2023-10-24 | 2025-03-30 |  | 31d |  |  |
| 1850 | 4.1.2.1 | 热徳尼克站（Km157+116，13组,10组14#,2组60-300-6°,1组49-300-6°）Žednik station（Km157+116，13 turnouts ,10 turnouts 14#,2 turnouts 60-300-6°,1 turnouts 49-300-6°） станица Жедник（Km157+116，13 скретница ,10 скретница 14#,2 скретнице 60-300-6°,1 скретница 49-300-6°） | 46ed | 2024-02-09 | 2024-03-26 | 1365, 1851 | 601.88d | 1.88d |  |
| 1851 | 4.1.2.2 | 那维切沃站（Km166+519.63，大里程咽喉区6组14#）Naumovićevo station（Km166+519.63，big mileage throat area 6 turnouts 14#） станица Наумовићево（Km166+519.63，подручје грла велике километраже 6 скретница 14#） | 18d | 2023-10-24 | 2023-11-14 | 1482FS+220d | 31d | 22d |  |
| 1852 | 4.1.2.3 | 那维切沃站（Km166+519.63，8组14#）Naumovićevo station（Km166+519.63， 8 turnouts 14#） станица Наумовићево（Km166+519.63， 8 скретница 14#） | 28d | 2024-03-27 | 2024-04-27 | 1850 | 203d | 89d |  |
| 1853 | 4.1.2.4 | 苏博蒂察站（Km176+550，29组 60-300-6°）Subotica station（Km176+550，29 turnouts 60-300-6°） станица Суботица（Km176+550，29 скретница 60-300-6°） | 90ed | 2024-12-30 | 2025-03-30 | 1605FF+30ed, 1617FF+30ed, 1707FF+30ed, 1647FF+30ed, 1692FF+30ed, 1696FF+30ed, 1634FF+30ed, 1601FF+30ed, 1597FF+30ed, 1852FF+30ed | 160.88d | 157.88d |  |
| 1854 | 4.2 | **底碴道碴摊铺Bottom ballast ballast laying Постављање доњег слоја туцаника** | 581d | 2023-01-01 | 2025-05-07 |  | 1d |  |  |
| 1855 | 4.2.1 | **Km76+243.66~Km144+327.41** | 333d | 2023-10-30 | 2025-04-06 |  | 0d |  |  |
| 1856 | 4.2.1.1 | 萨耶罗沃基地~鲁门卡站（Km84+043.75,不含）（包含货车疏解线）Base Sajlovo-Rumenka station（Km84+043.75 not included）（includes freight untwining line） Камп Сајлово-станица Руменка（без Km84+043.75）（укључује теретну распутницу） | 25ed | 2023-10-30 | 2023-11-24 | 247FS+60ed, 256, 47SS, 248 | 250.88d | 0d | start no earlier than 2023-10-01 |
| 1857 | 4.2.1.2 | 鲁门卡站（Km84+043.75）~克萨彻站（Km90+407,不含）/ Rumenka station（Km84+043.75）~Kisač station（Km90+407, not including）/ Станица Руменка（Km84+043.75） ~ Станица Кисач（Km90+407, не укључујући） | 22ed | 2023-11-24 | 2023-12-16 | 1856, 376, 367, 368 | 637.88d | 333d |  |
| 1858 | 4.2.1.3 | 克萨彻站（Km90+407）~斯帕诺维切沃站（Km97+300,不含）/Kisač station~ Stepanovićevo station /Станица Кисач（Km90+407）~Станица Степановићево (Km97+300,не укључујући) | 24ed | 2024-04-05 | 2024-04-29 | 1857, 505, 496, 497 | 304.88d | 0d |  |
| 1859 | 4.2.1.4 | 斯帕诺维切沃站（Km97+300）~热麻耶沃站（Km102+514,不含）Stepanovićevo station~Zmajevo station / Станица Степановићево~Станица Змајево | 18ed | 2024-04-29 | 2024-05-17 | 1858, 607, 630, 622 | 304.88d | 0d |  |
| 1860 | 4.2.1.5 | 热麻耶沃站（Km102+514）~维尔巴斯站（含）~Km115+000（含联络线）Zmajevo station（Km102+514）~Vrbas station（included）~Km115+000（connecting railway included） станица Змајево（Km102+514）~станица Врбас（са）~Km115+000（железничка веза укљулена） | 50ed | 2024-05-17 | 2024-07-06 | 1859, 734, 747, 735, 828, 841, 842, 850 | 304.88d | 4.88d |  |
| 1861 | 4.2.1.6 | Km115+000~Km122+500 | 20ed | 2025-03-17 | 2025-04-06 | 1863, 892, 970 | 1.88d |  |  |
| 1862 | 4.2.1.7 | Km122+500~新罗沃彻纳茨站（Km129+523,不含）Km122+500~new Lovćenac station（Km129+523 not included） Km122+500~нова станица Ловћенац（без Km129+523） | 20d | 2024-07-08 | 2024-07-30 | 1860, 936, 928 | 86d |  |  |
| 1863 | 4.2.1.8 | 新罗沃彻纳茨站（Km129+523）~巴奇卡托波拉站（Km144+327.41，含） | 40d | 2024-11-08 | 2025-02-26 | 1862, 1043, 1066, 1081, 1109, 1118 | 0d |  |  |

| ID | WBS | Task | Duration | Start | Finish | Predecessors | Total slack | Free slack | Constraint |
| --- | --- | --- | --- | --- | --- | --- | --- | --- | --- |
| 1864 | 4.2.2 | **Km142+682.79~Km184+635.07** | 581d | 2023-01-01 | 2025-05-07 |  | 1d |  |  |
| 1865 | 4.2.2.1 | 热徳尼克站（Km157+116）~巴奇卡托波接站（Km143+536,不含） | 72ed | 2024-04-06 | 2024-06-17 | 1246, 1273, 1293, 1167, 1195, 1236, 1286, 1328, 1866 | 430.88d | 0d |  |
| 1866 | 4.2.2.2 | 那维切沃基地（Km166+500）~热徳尼克站（Km157+116）Naumovićevo base（Km166+500）~Žednik station（Km157+116） камп Наумовићево（Km166+500）~станица Жедник（Km157+116） | 51ed | 2023-09-19 | 2023-11-09 | 1411, 1436, 1342, 1867, 1418, 1428 | 1.88d |  |  |
| 1867 | 4.2.2.3 | 那维切沃基地（Km166+500）~Km168+800Naumovićevo base（Km166+500）~Km168+800） камп Наумовићево（Km166+500）~Km168+800） | 7ed | 2023-01-01 | 2023-01-08 | 1482FS+1ed, 1483FS+1ed, 1536SS+130ed | 763.88d | 0d |  |
| 1868 | 4.2.2.4 | Km168+800~苏博蒂察站（Km176+550）Naumovićevo base（Km168+800）~Subotica station（Km176+550） камп Наумовићево（Km166+500）~станица Суботица（Km176+550） | 70ed | 2024-06-17 | 2024-08-26 | 1536, 1558, 1517, 1529, 1550, 1597, 1601, 1634, 1865 | 484.88d | 82d |  |
| 1869 | 4.2.2.5 | 苏博蒂察站（Km176+550）~终点（Km184+635.07）Subotica station（Km176+550）~end point（Km184+635.07） станица Суботица（Km176+550）~крајња тачка（Km184+635.07） | 55d | 2025-02-27 | 2025-05-07 | 1776, 1748, 1810, 1868, 1676, 1679, 1685, 1680, 1670, 1662 | 1d | 0d |  |
| 1870 | 4.3 | **铺设240m长钢轨Laying 240m rails полагање 240m шина** | 596d | 2023-01-08 | 2025-05-24 |  | 1d |  |  |
| 1871 | 4.3.1 | **Km76+243.66~Km144+327.41** | 312d | 2023-12-16 | 2025-04-11 |  | 0d |  |  |
| 1872 | 4.3.1.1 | 萨耶罗沃基地~鲁门卡站（Km84+043.75,不含）（包含货车疏解线）Base Sajlovo-Rumenka station（Km84+043.75 not included）（includes freight untwining line） Камп Сајлово-станица Руменка（без Km84+043.75）（укључује теретну распутницу） | 30ed | 2023-12-16 | 2024-01-15 | 1856SS+47ed, 39, 48SS, 49SS | 250.88d | 49.88d | start no earlier than 2023-08-01 |
| 1873 | 4.3.1.2 | 鲁门卡站（Km84+043.75）~克萨彻站（Km90+407,不含）/ Rumenka station（Km84+043.75）~Kisač station（Km90+407, not including）/ Станица Руменка（Km84+043.75） ~ Станица Кисач（Km90+407, не укључујући） | 24d | 2024-02-01 | 2024-03-01 | 1872, 1842 | 55d | 0d |  |
| 1874 | 4.3.1.3 | 克萨彻站（Km90+407）~斯帕诺维切沃站（Km97+300,不含）/Kisač station~ Stepanovićevo station /Станица Кисач（Km90+407）~Станица Степановићево (Km97+300,не укључујући) | 26d | 2024-03-02 | 2024-04-01 | 1873, 1843 | 78d | 0d |  |
| 1875 | 4.3.1.4 | 斯帕诺维切沃站（Km97+300）~热麻耶沃站（Km102+514,不含）Stepanovićevo station~Zmajevo station / Станица Степановићево~Станица Змајево | 26d | 2024-04-02 | 2024-05-07 | 1874, 1844 | 78d | 0d |  |
| 1876 | 4.3.1.5 | 热麻耶沃站（Km102+514）~维尔巴斯站（含）~Km115+000（含联络线）Zmajevo station（Km102+514）~Vrbas station（included）~Km115+000（connecting railway included） станица Змајево（Km102+514）~станица Врбас（са）~Km115+000（железничка веза укљулена） | 51d | 2024-06-15 | 2024-08-13 | 1875, 1845, 1846 | 45d | 0d |  |
| 1877 | 4.3.1.6 | Km115+000~Km122+500 | 20ed | 2025-03-22 | 2025-04-11 | 1879, 1861FF+5d | 1.88d |  |  |
| 1878 | 4.3.1.7 | Km122+500~新罗沃彻纳茨站（Km129+523,不含）Km122+500~new Lovćenac station（Km129+523 not included） Km122+500~нова станица Ловћенац（без Km129+523） | 23d | 2024-08-14 | 2024-09-09 | 1876 | 51d | 1d |  |
| 1879 | 4.3.1.8 | 新罗沃彻纳茨站（Km129+523）~巴奇卡托波拉站（Km144+327.41，含） | 45d | 2024-11-08 | 2025-03-04 | 1878, 1863SS, 1847, 1848FS-10d | 0d |  |  |
| 1880 | 4.3.2 | **Km144+327.41~Km184+635.07** | 596d | 2023-01-08 | 2025-05-24 |  | 1d |  |  |
| 1881 | 4.3.2.1 | 热徳尼克站（Km157+116）~巴奇卡托波接站（Km144+327.41,不含） | 76d | 2024-04-13 | 2024-07-16 | 1850SS+5d, 1882, 1865SS+5d | 117d | 0d |  |
| 1882 | 4.3.2.2 | 那维切沃基地（Km166+500）~热徳尼克站（Km157+116）Naumovićevo base（Km166+500）~Žednik station（Km157+116） камп Наумовићево（Km166+500）~станица Жедник（Km157+116） | 53d | 2023-11-30 | 2024-04-03 | 1866SS+60d, 1851SS, 1883 | 0d |  |  |
| 1883 | 4.3.2.3 | 那维切沃基地（Km166+500）~Km168+800Naumovićevo base（Km166+500）~Km168+800） камп Наумовићево（Km166+500）~Km168+800） | 10ed | 2023-01-08 | 2023-01-18 | 1867 | 946.88d |  |  |
| 1884 | 4.3.2.4 | Km168+800）~苏博蒂察站（Km176+550）Km168+800）~Subotica station（Km176+550） Km168+800）~станица Суботица（Km176+550） | 58ed | 2024-07-16 | 2024-09-12 | 1881, 1852SS+5d, 1868SS+5d | 523.88d | 1.88d |  |
| 1885 | 4.3.2.5 | 苏博蒂察站（Km176+550）~终点（Km184+635.07）Subotica station（Km176+550）~end point（Km184+635.07） станица Суботица（Km176+550）~крајња тачка（Km184+635.07） | 65d | 2025-03-05 | 2025-05-24 | 1884, 1853SS+10d, 1869SS+5d | 1d | 0d |  |
| 1886 | 4.4 | 既有轨道拆除/ Dismantling of existing track / Демонтажа постојећег колосека | 20ed | 2025-03-04 | 2025-03-24 | 692, 1879 | 213d |  |  |
| 1887 | 4.5 | **上砟整道ballast laying, constructing ballast bed постављање туцаника и конструкција засторне призме** | 377d | 2023-10-31 | 2025-06-02 |  | 1d |  |  |
| 1888 | 4.5.1 | **Km76+243.66~Km144+327.41** | 368d | 2023-10-31 | 2025-05-22 |  | 10d |  |  |
| 1889 | 4.5.1.1 | 诺维萨德~萨耶罗沃基地（包含客车疏解线、松博尔支线、贝切伊支线）Novi Sad~base Sajlovo（including passenger untwining line, branch line Sombor and Bečej） Нови Сад~камп Сајлово（укључује путничку распутницу, огранак Сомбор, огранак Бечеј） | 61d | 2023-10-31 | 2024-03-14 | 1856SS | 28d | 0d |  |
| 1890 | 4.5.1.2 | 萨耶罗沃基地~鲁门卡站（Km84+043.75,不含）（包含货车疏解线）Base Sajlovo-Rumenka station（Km84+043.75 not included）（includes freight untwining line） Камп Сајлово-станица Руменка（без Km84+043.75）（укључује теретну распутницу） | 94d | 2024-02-03 | 2024-05-30 | 1872SS+2d, 1889SS | 55d | 0d |  |
| 1891 | 4.5.1.3 | 鲁门卡站（Km84+043.75）~克萨彻站（Km90+407,不含）/ Rumenka station（Km84+043.75）~Kisač station（Km90+407, not including）/ Станица Руменка（Km84+043.75） ~ Станица Кисач（Km90+407, не укључујући） | 95d | 2024-02-03 | 2024-05-31 | 1873SS+2d, 1842SS, 1890SS | 55d | 0d | start no earlier than 2022-04-01 |
| 1892 | 4.5.1.4 | 克萨彻站（Km90+407）~斯帕诺维切沃站（Km97+300,不含）/Kisač station~ Stepanovićevo station /Станица Кисач（Km90+407）~Станица Степановићево (Km97+300,не укључујући) | 154d | 2024-03-05 | 2024-09-05 | 1874SS+2d, 1843SS, 1891SS | 130d | 26d |  |
| 1893 | 4.5.1.5 | 斯帕诺维切沃站（Km97+300）~热麻耶沃站（Km102+514,不含）Stepanovićevo station~Zmajevo station / Станица Степановићево~Станица Змајево | 145ed | 2024-04-03 | 2024-08-26 | 1875SS+2d, 1844SS, 1892SS | 382.88d | 225d |  |
| 1894 | 4.5.1.6 | 热麻耶沃站（Km102+514）~维尔巴斯站（含）~Km115+000（含联络线、旧维尔巴斯站）Zmajevo station（Km102+514）~Vrbas station（included）~Km115+000（connecting railway , old Vrbas station included） станица Змајево（Km102+514）~станица Врбас（укључује）~Km115+000（железничка веза и стара станица Врб | 173ed | 2024-06-17 | 2024-12-07 | 1876SS+2d, 1845SS, 1846SS, 1893SS | 157.88d | 1.88d |  |
| 1895 | 4.5.1.7 | Km115+000~Km122+500 | 45ed | 2025-04-07 | 2025-05-22 | 1877FF+30d | 1.88d |  |  |
| 1896 | 4.5.1.8 | Km122+500~新罗沃彻纳茨站（Km129+523,不含）Km122+500~new Lovćenac station（Km129+523 not included） Km122+500~нова станица Ловћенац（без Km129+523） | 156ed | 2024-08-15 | 2025-01-18 | 1878SS+2d, 1894SS | 408d | 300d |  |
| 1897 | 4.5.1.9 | 新罗沃彻纳茨站（Km129+523）~巴奇卡托波拉站（Km143+536，含） | 120ed | 2024-11-09 | 2025-03-09 | 1879SS+2d, 1847 | 7.88d |  |  |

| ID | WBS | Task | Duration | Start | Finish | Predecessors | Total slack | Free slack |
| --- | --- | --- | --- | --- | --- | --- | --- | --- |
| 1898 | 4.5.2 | **Km144+327.41~Km184+635.07** | 350d | 2024-02-02 | 2025-06-02 |  | 0d |  |
| 1899 | 4.5.2.1 | 热徳尼克站（Km157+116）~巴奇卡托波接站（Km143+536，不含） | 240ed | 2024-04-15 | 2024-12-11 | 1900SS, 1881SS+2d, 1850SS | 522d | 283.88d |
| 1900 | 4.5.2.2 | 那维切沃基地（Km166+500）~热徳尼克站（Km157+116）Naumovićevo base（Km166+500）~Žednik station（Km157+116） камп Наумовићево（Km166+500）~станица Жедник（Km157+116） | 180d | 2024-02-02 | 2024-09-06 | 1882SS+2d, 1851SS | 0d |  |
| 1901 | 4.5.2.3 | 那维切沃基地（Km166+500）~苏博蒂察站（Km176+550）Naumovićevo base（Km166+500）~Subotica station（Km176+550） камп Наумовићево（Km166+500）~станица Суботица（Km176+550） | 90d | 2024-07-19 | 2024-10-31 | 1884SS+2d, 1899SS, 1852SS | 124d |  |
| 1902 | 4.5.2.4 | 苏博蒂察站（Km176+550）~终点（Km184+635.07）Subotica station（Km176+550）~end point（Km184+635.07） станица Суботица（Km176+550）~крајња тачка（Km184+635.07） | 70d | 2025-03-07 | 2025-06-02 | 1885SS+2d, 1901SS, 1853SS | 1d |  |
| 1903 | 4.6 | **道岔内部接头焊接（铝热焊）Welding turnouts inner joints (aluminothermic welding) Заваривање унутрашњих спојева скретница (алуминотермијско заваривање)** | 290d | 2024-04-16 | 2025-06-03 |  | 0d |  |
| 1904 | 4.6.1 | **Km76+243.66~Km144+327.41** | 290d | 2024-04-16 | 2025-06-03 |  | 0d |  |
| 1905 | 4.6.1.1 | 鲁门卡站（Km84+043.75，11组-3组18.5#,8组14#）Rumenka station（Km84+043.75，11 turnouts -3 turnouts 18.5#,8 turnouts 14#） станица Руменка（Km84+043.75，11скретница-3 скретнице 18.5#,8 скретница 14#） | 24d | 2024-04-16 | 2024-05-18 | 1891SS+60d | 55d | 0d |
| 1906 | 4.6.1.2 | 克萨彻站（Km90+407，10组14#）Kisač station（Km90+407，10 turnouts 14#） станица Кисач（Km90+407，10 скретница 14#） | 20d | 2024-07-13 | 2024-08-05 | 1905FS+47d | 55d | 0d |
| 1907 | 4.6.1.3 | 斯帕诺维切沃站（Km97+300，10组14#）Stepanovićevo station（Km97+300，10 turnouts 14#） станица Степановићево（Km97+300，10 скретнице 14#） | 20d | 2024-08-06 | 2024-08-28 | 1906 | 55d | 0d |
| 1908 | 4.6.1.4 | 热麻耶沃站（Km102+514，12组,10组14#,2组60-200-6°）Zmajevo station（Km102+514，12 turnouts,10 turnouts 14#,2 turnouts 60-200-6°） станица Змајево（Km102+514，12 скретница ,10 скретница 14#, 2 скретнице 60-200-6°） | 25d | 2024-08-29 | 2024-09-26 | 1907, 1894SS+60d | 55d | 3d |
| 1909 | 4.6.1.5 | 维尔巴斯站（Km113+610.13,16组,12组14#,2组60-300-6°）Vrbas station（Km113+610.13,16 turnouts,12 turnouts 14#,2 turnouts 60-300-6°） станица Врбас（Km113+610.13,16 скретница ,12 скретница 14#,2 скретнице 60-300-6°） | 32ed | 2024-09-30 | 2024-11-01 | 1908, 1894SS+90d | 358.88d | 10.88d |
| 1910 | 4.6.1.6 | 旧维尔巴斯站（12组）Old Vrbas station（12 turnouts） стара станица Врбас（12 скретница） | 20d | 2024-11-05 | 2024-11-28 | 1894SS+120d, 1909 | 45d |  |
| 1911 | 4.6.1.7 | 新罗沃彻纳茨站（Km129+523,10组14#）New Lovćenac station（Km129+523,10 turnouts 14#） нова станица Ловћенац（Km129+523,10 скретница 14#） | 20d | 2025-03-25 | 2025-04-16 | 1910, 1897SS+60d | 0d |  |
| 1912 | 4.6.1.8 | 巴奇卡托波拉站（Km143+536，23组,15组14#,2组60-300-6°,6组49-300-6°）Bačka Topola station（Km143+536，23 turnouts,15 turnouts 14#,2 turnouts 60-300-6°,6 turnouts 49-300-6°） станица Бачка Топола（Km143+536，23 скретнице, 15 скретница 14#,2 скретнице 60-300-6°,6 скретница 49- | 36d | 2025-04-17 | 2025-06-03 | 1911, 1848 | 0d |  |
| 1913 | 4.6.2 | **Km144+327.41~Km184+635.07** | 102d | 2024-09-07 | 2025-03-08 |  | 69d |  |
| 1914 | 4.6.2.1 | 热徳尼克站（Km157+116，13组,10组14#,2组60-300-6°,1组49-300-6°）Žednik station（Km157+116，13 turnouts ,10 turnouts 14#,2 turnouts 60-300-6°,1 turnouts 49-300-6°） станица Жедник（Km157+116，13 скретница ,10 скретница 14#,2 скретнице 60-300-6°,1 скретница 49-300-6°） | 26d | 2024-10-07 | 2024-11-05 | 1899SS+60d, 1915 | 69d | 0d |
| 1915 | 4.6.2.2 | 那维切沃站（Km166+519.63，14组14#）Naumovićevo station（Km166+519.63，14 turnouts 14#） станица Наумовићево（Km166+519.63，14 скретница 14#） | 25d | 2024-09-07 | 2024-10-05 | 1900SS+180d | 69d | 0d |
| 1916 | 4.6.2.3 | 苏博蒂察站（Km176+550，29组 60-300-6°）Subotica station（Km176+550，29 turnouts 60-300-6°） станица Суботица（Km176+550，29 скретница 60-300-6°） | 51d | 2024-11-06 | 2025-03-08 | 1914 | 69d |  |
| 1917 | 4.7 | **应力放散及锁定（区间采用移动闪光接触焊、道岔接头采用铝热焊）Stress relieving and fastening-down ( Open track using mobile spark contact welding, turnouts joints use aluminothermic welding) Ослобађање напона и закивање (на отвореној прузи користи се моблнотачкасто контактно заваривање,** | 312d | 2024-03-15 | 2025-05-28 |  | 5d |  |
| 1918 | 4.7.1 | **Km76+243.66~Km144+327.41** | 312d | 2024-03-15 | 2025-05-28 |  | 0d |  |
| 1919 | 4.7.1.1 | 诺维萨德~鲁门卡站（Km84+043.75,不含）（包含客车疏解线、货车疏解线、松博尔支线、贝切伊支线）Novi Sad~Rumenka station（Km84+043.75 not included）（includes passengers untwining line, freight untwining line, Sombor and Bečej branch line） Нови Сад~станица Руменка（не укључује Km84+043.75）（укључује пу | 56d | 2024-03-15 | 2024-05-24 | 1889SS+61d, 1890SS | 28d | 0d |
| 1920 | 4.7.1.2 | 鲁门卡站（Km84+043.75）~克萨彻站（Km90+407,不含）/ Rumenka station（Km84+043.75）~Kisač station（Km90+407, not including）/ Станица Руменка（Km84+043.75） ~ Станица Кисач（Km90+407, не укључујући） | 23d | 2024-08-03 | 2024-08-29 | 1891SS, 1919FS+60d | 28d | 0d |
| 1921 | 4.7.1.3 | 克萨彻站（Km90+407）~斯帕诺维切沃站（Km97+300,不含）/Kisač station~ Stepanovićevo station /Станица Кисач（Km90+407）~Станица Степановићево (Km97+300,не укључујући) | 23d | 2024-08-30 | 2024-09-25 | 1892SS, 1920 | 28d | 0d |
| 1922 | 4.7.1.4 | 斯帕诺维切沃站（Km97+300）~热麻耶沃站（Km102+514,不含）Stepanovićevo station~Zmajevo station / Станица Степановићево~Станица Змајево | 18d | 2024-09-26 | 2024-10-16 | 1921, 1893SS | 28d | 0d |
| 1923 | 4.7.1.5 | 热麻耶沃站（Km102+514）~维尔巴斯站（Km113+610,不含）Zmajevo station ~ Vrbas station Станица Змајево~ ст. Врбас | 32d | 2024-10-17 | 2024-11-23 | 1922, 1894SS | 28d | 0d |
| 1924 | 4.7.1.6 | Km115+000~Km122+500 | 20ed | 2025-05-08 | 2025-05-28 | 1895FF+5d, 1926FF+10d | 1.88d |  |
| 1925 | 4.7.1.7 | Km122+500~新罗沃彻纳茨站（Km129+523,不含）Km122+500~new Lovćenac station（Km129+523 not included） Km122+500~нова станица Ловћенац（без Km129+523） | 30ed | 2024-11-23 | 2024-12-23 | 1896SS, 1923 | 288d | 0d |
| 1926 | 4.7.1.8 | 新罗沃彻纳茨站（Km129+523）~巴奇卡托波拉站（Km143+536，含） | 30ed | 2024-12-23 | 2025-01-22 | 1925, 1897SS | 313.88d | 143d |

| ID | WBS | Task | Duration | Start | Finish | Predecessors | Total slack | Free slack | Constraint |
| --- | --- | --- | --- | --- | --- | --- | --- | --- | --- |
| 1927 | 4.7.2 | **Km144+327.41~Km184+635.07** | 153d | 2024-09-21 | 2025-05-27 |  | 0d |  |  |
| 1928 | 4.7.2.1 | 热徳尼克站（Km157+116）~巴奇卡托波接站（Km143+536，不含） | 55d | 2024-11-04 | 2025-03-11 | 1929, 1899SS | 6d | 0d |  |
| 1929 | 4.7.2.2 | 那维切沃基地（Km166+500）~热徳尼克站（Km157+116）Naumovićevo base（Km166+500）~Žednik station（Km157+116） камп Наумовићево（Km166+500）~станица Жедник（Km157+116） | 37d | 2024-09-21 | 2024-11-02 | 1900SS+192d, 1882 | 0d |  |  |
| 1930 | 4.7.2.3 | 那维切沃基地（Km166+500）~苏博蒂察站（Km176+550）Naumovićevo base（Km166+500）~Subotica station（Km176+550） камп Наумовићево（Km166+500）~станица Суботица（Km176+550） | 33d | 2025-03-12 | 2025-04-22 | 1901SS, 1928 | 6d | 0d |  |
| 1931 | 4.7.2.4 | 苏博蒂察站（Km176+550）~终点（Km184+635.07）Subotica station（Km176+550）~end point（Km184+635.07） станица Суботица（Km176+550）~крајња тачка（Km184+635.07） | 28d | 2025-04-23 | 2025-05-27 | 1930, 1902SS | 6d |  |  |
| 1932 | 4.8 | **轨道精调Track fine adjustment Регулисање колосека** | 231d | 2024-06-29 | 2025-06-03 |  | 0d |  |  |
| 1933 | 4.8.1 | **Km76+243.66~Km144+327.41** | 231d | 2024-06-29 | 2025-06-03 |  | 0d |  |  |
| 1934 | 4.8.1.1 | Km76+243.66~诺维萨德站（Km77+010）~鲁门卡站（Km84+043.75,不含）（包含货车疏解线）Km76+243.66~Novi Sad station（Km77+010）~Rumenka station（Km84+043.75 not included）（passenger untwining line included） Km76+243.66~станица Нови сад（Km77+010）~станица Руменка（не укључујеKm84+043.75）（ук | 17d | 2024-06-29 | 2024-07-18 | 1919FS+30d, 1889FS+30d | 84d | 0d |  |
| 1935 | 4.8.1.2 | 鲁门卡站（Km84+043.75）~克萨彻站（Km90+407,不含）/ Rumenka station（Km84+043.75）~Kisač station（Km90+407, not including）/ Станица Руменка（Km84+043.75） ~ Станица Кисач（Km90+407, не укључујући） | 14d | 2024-08-15 | 2024-08-30 | 1934, 1920SS+10d | 61d | 0d |  |
| 1936 | 4.8.1.3 | 克萨彻站（Km90+407）~斯帕诺维切沃站（Km97+300,不含）/Kisač station~ Stepanovićevo station /Станица Кисач（Km90+407）~Станица Степановићево (Km97+300,не укључујући) | 17d | 2024-09-11 | 2024-09-30 | 1935, 1921SS+10d | 52d | 0d |  |
| 1937 | 4.8.1.4 | 斯帕诺维切沃站（Km97+300）~热麻耶沃站（Km102+514,不含）Stepanovićevo station~Zmajevo station / Станица Степановићево~Станица Змајево | 12d | 2024-10-08 | 2024-10-21 | 1936, 1922SS+10d | 46d | 0d |  |
| 1938 | 4.8.1.5 | 热麻耶沃站（Km102+514）~维尔巴斯站（Km113+610,不含）Zmajevo station ~ Vrbas station Станица Змајево~ ст. Врбас | 26d | 2024-10-29 | 2024-11-28 | 1937, 1923SS+10d | 40d | 0d |  |
| 1939 | 4.8.1.6 | Km115+000~Km122+500 | 17ed | 2025-05-17 | 2025-06-03 | 1941, 1924FF+5d, 1895FF+10d | 0d |  |  |
| 1940 | 4.8.1.7 | Km122+500~新罗沃彻纳茨站（Km129+523,不含）Km122+500~new Lovćenac station（Km129+523 not included） Km122+500~нова станица Ловћенац（без Km129+523） | 30ed | 2024-11-28 | 2024-12-28 | 1925FS-10d, 1938 | 330d | 138d |  |
| 1941 | 4.8.1.8 | 新罗沃彻纳茨站（Km129+523）~巴奇卡托波拉站（Km142+682.79，含） | 30ed | 2025-02-12 | 2025-03-14 | 1926SS+10d, 1940 | 192d | 1.88d |  |
| 1942 | 4.8.2 | **Km144+327.41~Km184+635.07** | 122d | 2024-11-04 | 2025-06-03 |  | 0d |  |  |
| 1943 | 4.8.2.1 | 巴奇卡托波接站（Km143+536，不含）~热徳尼克站（Km157+116,不含） | 42d | 2025-02-05 | 2025-03-26 | 1944 | 0d |  |  |
| 1944 | 4.8.2.2 | 热徳尼克站（Km157+116）~那维切沃站（Km166+500，不含）Žednik station（Km157+116）~Naumvićevo station（Km166+500 not included） станица Жедник（Km157+116）~станица Наумвићево（Km166+500 није укључено） | 26d | 2024-11-04 | 2025-02-04 | 1929SS+37d, 1900SS+37d | 0d |  |  |
| 1945 | 4.8.2.3 | 那维切沃站（Km166+500）~苏博蒂察（Km176+550,不含）Naumovićevo station（Km166+500）~Subotica（Km176+550） станица Наумовићево（Km166+500）~Суботица（Km176+550） | 30d | 2025-03-27 | 2025-05-06 | 1943 | 0d |  |  |
| 1946 | 4.8.2.4 | 苏博蒂察站（Km176+550）~终点（Km184+635.07）Subotica station（Km176+550）~end point（Km184+635.07） станица Суботица（Km176+550）~крајња тачка（Km184+635.07） | 24d | 2025-05-07 | 2025-06-03 | 1945 | 0d |  |  |
| 1947 | 4.9 | **钢轨打磨Grinding rails брушење шина** | 46d | 2025-04-04 | 2025-06-03 |  | 0d |  |  |
| 1948 | 4.9.1 | Km76+243.66~Km144+327.41 | 60ed | 2025-04-04 | 2025-06-03 | 1939FF | 0d |  |  |
| 1949 | 4.9.2 | Km144+327.41~Km184+635.07 | 60ed | 2025-04-04 | 2025-06-03 | 1946FF | 0d |  |  |
| 1950 | 5 | 竣工试验(联调联试)Completion test (integrated commissioning) Тестирање по завршетку радова (интегрисано пуштање у рад) | 121ed | 2025-09-01 | 2025-12-31 | 1839FS+90ed, 803, 804 | 0d |  | finish no earlier than 2025-02-28 |
| 1951 | 6 | Overpass above the branch line for Sombor at km 177+455 (due to a collision with the track, the performance must be organized after the closure of the Sombor branch line); | 1d? | 2022-07-01 | 2022-07-01 |  | 913d |  |  |
| 1952 | 7 | U-frames at K0+137-K0+483 and K0+558-K1+314 in Subotica (due to the collision with the Sombor branch line and insufficient expropriation, etc., they can only be constructed after the closure of the branch line and additional expropriation of plots) | 278d? | 2022-07-01 | 2023-07-31 |  | 636d |  |  |
